# 3GPP_Release-2000

Schedule from MS Project, 2000-01-01 to 2009-12-25, A marks actual dates.

## Calendars

- Standard: Mon-Fri 08:00-12:00, 13:00-17:00; Sat-Sun off.

## Resources

| Resource |
| --- |
| NP |
| N1 |
| N2 |
| N3 |
| N4 |
| N5 |
| TP |
| T1 |
| T2 |
| T3 |
| RP |
| R1 |
| R2 |
| R3 |
| R4 |
| SP |
| S1 |
| S2 |
| S3 |
| S4 |
| S5 |
| PCG |
| GP |
| No |
| CN4 |
| ? |
| WG G2 |
| G2 |
| G1 |
| G4 |
| G3 |
| All |
| Generic |
| MLST |
| G5 |
| S3; G2 |
| WG T2 |
| GP;G1 |
| G4;G5 |
| OMA |
| GP-G2 |
| Yes |
| GP; |
| N4; |
| GP; N1 |
| CT5 |
| C5 |
| C1 |
| C4 |
| C3 |
| C6 |
| G1; |
| 4 |
| ct |
| c;s;r |
| CT,RAN,SA |
| G2, |
| G1, G3 |
| CT6 |
| CT1 |
| CT1, CT3, CT4 |
| C1, C3, C4 |
| CP |
| R5 |
| C |
| Rel-8 |
| GP, G2 |
| R1,R4 |
| S5,C1 |
| CT,RAN,SA,GERAN |
| S3,C1,C4 |
| 5 |
| S1,C1,C3,C4,S5 |
| S1,C1,C3,C5 |
| S1,C1,C3,C4 |
| S1,S5 |
| S2,S3 |
| RAN,SA |
| RP,S5 |
| S2,CT |
| S1,CT |
| S1,CT,GERAN |
| S1,C5 |
| S3,CT |
| S4,CT |
| C1,SA |
| S1,S2 |
| S1,S4 |
| S2,S2,S3,CT |
| S2,S3,CT |
| S1,CT,GX |
| S1,S4,CT |
| S2,S2,S3,S5,CT |
| S1,S2,CT |
| S1,S2,S3,CT |
| S1,S2,S3,S5CT |
| S1,S2,S3,S5,CT |
| S2,S5,CT |
| S4,S3 |
| S1,C1 |
| CP,C1 |
| C1,C3 |
| C1,C3,C4 |
| S1,S5,CT |
| C4,C3 |
| CP,RAN,SA,GERAN |
| S1,S2,S3,S5,CP |
| S2,S3,CP |
| S2,CP |
| S1,CP,GX |
| S1,CP |
| S1,S4,CP |
| S1,S2,CP |
| S1,S2,S3,CP |
| S2,S5,CP |
| S3,CP |
| S1,S5,CP |
| RAN,SA,GERAN |
| S1,S2,S3,S5,C1,C3,C4,C6 |
| S2,S3,C1,C3,C4 |
| S2,C4 |
| S2,C1,C3,C4 |
| S2,C1,C4 |
| S2,S3,C1,C4 |
| S1,C1,C4,G2 |
| C1,C4 |
| S1,C1,C3 |
| S1,S4,C1,C3,C4 |
| S1,S2,S3,C1,C3,C4 |
| S2,S5,C3 |
| S1,S2,C1,C4 |
| S2,C1 |
| S2,C1,C3 |
| S3,C1,C3,C4 |
| S1,S5,C1,C3,C4 |
| S2,C3,C4 |
| C3,C1 |
| R2,R4 |
| R2,R5 |
| RP,R5 |
| RP,S5,R5 |
| R1,R5 |
| S1,C1,R5 |
| S1,C1,S4,R5 |
| GERAN |

## Schedule

| ID | WBS | Task | Type | Duration | Start | Finish | Complete | Remaining | Baseline start | Baseline finish | Baseline duration | Total slack | Constraint | Resources | Work | Actual work | Text9 | Text6 | Text1 | Text4 | Text5 | Text8 | Text12 |
| --- | --- | --- | --- | --- | --- | --- | --- | --- | --- | --- | --- | --- | --- | --- | --- | --- | --- | --- | --- | --- | --- | --- | --- |
| 1 | 1 | VERSION 2008 April 30 |  | 1d | 2000-01-03 | 2000-01-03 |  |  | 2000-01-03 | 2000-01-03 | 1d | 2604d | start no earlier than 2000-01-01 |  |  |  | 2044 |  |  |  |  |  |  |
| 2 | 2 | "CTRL + a" to display all the 3GPP fields |  | 1d | 2000-01-03 | 2000-01-03 |  |  | 2000-01-03 | 2000-01-03 | 1d | 2604d |  |  |  |  | 1462 |  |  |  |  |  |  |
| 3 | 3 | Content of Rel-8 (Stage 1 frozen) and Rel-9 |  | 1d | 2000-01-03 | 2000-01-03 |  |  | 2000-01-03 | 2000-01-03 | 1d | 2604d |  |  |  |  | 2058 |  |  |  |  |  |  |
| 4 | 4 | Gantt: dark blue=done; light blue=to be done; grey: previous values; black=summary |  | 1d? | 2000-01-03 | 2000-01-03 |  |  | 2000-01-03 | 2000-01-03 | 1d? | 2604d |  |  |  |  |  |  |  |  |  |  |  |
| 6 | 5 | Release 9 Features | milestone | 0d? | 2000-01-03 | 2000-01-03 |  |  | 2000-01-03 | 2000-01-03 | 0d? | 2604d | finish no earlier than 2000-01-03 | RAN,SA,GERAN |  |  |  | Rel-9 |  |  |  |  |  |
| 7 | 6 | Services Alignment and Migration |  | 537d? | 2006-12-06 A | 2008-12-25 | 80% | 107.4d? | 2006-12-06 | 2008-12-25 | 537d? | 261d | finish no earlier than 2008-12-25 | S1 | 4296h | 3436.8h |  | Rel-9 | ServAl | China Mobile | fenglingjuan@chinamobile.com | Alain |  |
| 8 | 7 | End-User Identity |  | 344d? | 2007-09-03 A | 2008-12-25 | 5% | 326.8d? | 2007-09-03 | 2008-12-25 | 344d? | 261d | finish no earlier than 2008-12-25 | S1 | 2752h | 137.6h |  | Rel-9 | EUI | NSN | Joerg.Swetina@Siemens.com | Alain |  |
| 9 | 8 | Customized Ringing Signal |  | 276d? | 2007-12-06 A | 2008-12-25 | 60% | 110.4d? | 2007-12-06 | 2008-12-25 | 276d? | 261d | finish no earlier than 2008-12-25 | S1 | 2208h | 1324.8h |  | Rel-9 | CRS | Telecom Italia |  | Alain |  |
| 10 | 9 | **Public Warning System** |  | 276d? | 2007-12-06 | 2008-12-25 |  |  | 2007-12-06 | 2008-12-25 | 276d? | 261d |  | S1 | 4416h |  |  | Rel-9 | PWS | Telecom Italia |  | Alain |  |
| 11 | 9.1 | Stage 1 for PWS |  | 276d? | 2007-12-06 | 2008-12-25 |  |  | 2007-12-06 | 2008-12-25 | 276d? | 261d | finish no earlier than 2008-12-25 | S1 | 2208h |  |  | Rel-9 | PWS-S1 | Telecom Italia |  | Alain |  |
| 12 | 10 | Support for IMS Emergency Calls over GPRS and EPS |  | 171d? | 2008-01-14 A | 2008-09-08 | 25% | 128.25d? | 2008-01-14 | 2008-09-08 | 171d? | 339d | finish no earlier than 2008-09-08 | S2 | 1368h | 342h |  | Rel-9 | IMS_EMER_GPRS_EPS | Alcatel-Lucent |  | Maurice |  |
| 13 | 11 | **Deleted - SAES Enhancements (non RAN aspects)** |  | 381d? | 2007-06-25 A | 2008-12-08 A | 100% |  | 2007-06-25 | 2008-12-08 | 381d? |  |  | S2 | 14768h | 14768h |  | Rel-9 | SAES_Ph2 | NSN |  | Maurice | SP-39 |
| 14 | 11.1 | Deleted - SAE aspects of Emergency Calls (both GPRS and LTE) |  | 194d? | 2008-03-12 A | 2008-12-08 A | 100% |  | 2008-03-12 | 2008-12-08 | 194d? |  | finish no earlier than 2008-12-08 | S2 | 1552h | 1552h |  | Rel-9 | SAES_Ph2 |  |  | Maurice | SP-39 |
| 15 | 11.2 | Deleted - Functions and procedures for SAE to support LTE MBMS |  | 381d? | 2007-06-25 A | 2008-12-08 A | 100% |  | 2007-06-25 | 2008-12-08 | 381d? |  | finish no earlier than 2008-12-08 | S2 | 3048h | 3048h |  | Rel-9 | SAES_Ph2 |  |  | Maurice | SP-39 |
| 16 | 11.3 | Deleted - Functions and procedures for SAE to support Control Plane LCS |  | 194d? | 2008-03-12 A | 2008-12-08 A | 100% |  | 2008-03-12 | 2008-12-08 | 194d? |  | start no earlier than 2008-03-12 | S2 | 1552h | 1552h |  | Rel-9 | SAES_Ph2 |  |  | Maurice | SP-39 |
| 17 | 11.4 | Deleted - CS over EPS |  | 194d? | 2008-03-12 A | 2008-12-08 A | 100% |  | 2008-03-12 | 2008-12-08 | 194d? |  | finish no earlier than 2008-12-08 | S2 | 1552h | 1552h |  | Rel-9 | SAES_Ph2 |  |  | Maurice | SP-39 |
| 18 | 11.5 | **Deleted - SAE for generic support for non-3GPP accesses** |  | 251d? | 2007-06-25 A | 2008-06-09 A | 100% |  | 2007-06-25 | 2008-06-09 | 251d? |  |  | S2 | 4016h | 4016h |  | Rel-9 | SAES_Ph2 |  |  | Maurice | SP-39 |
| 19 | 11.5.1 | Deleted - Single Radio Aspects of SAE for Optimized Handover with WiMAX |  | 251d? | 2007-06-25 A | 2008-06-09 A | 100% |  | 2007-06-25 | 2008-06-09 | 251d? |  | finish no earlier than 2008-06-09 | S2 | 2008h | 2008h |  | Rel-9 | SAES_Ph2 |  |  | Maurice | SP-39 |
| 20 | 12 | Deleted - Support of WiMAX - LTE Mobility |  | 406d? | 2008-06-06 A | 2009-12-25 A | 100% |  | 2008-06-06 | 2009-12-25 | 406d? |  | start no earlier than 2008-06-06 | R2 | 3248h | 3248h |  | Rel-9 | WiMAX_LTE_Mobility | Samsung |  | MCC_RAN | SP-39 |
| 21 | 13 | Deleted - Support of WiMAX - UMTS Mobility |  | 406d? | 2008-06-06 A | 2009-12-25 A | 100% |  | 2008-06-06 | 2009-12-25 | 406d? |  | start no earlier than 2008-06-06 | R2 | 3248h | 3248h |  | Rel-9 | WiMAX_UMTS_Mobility | Intel |  | MCC_RAN | SP-39 |
| 22 | 14 | Release 8 Features | milestone | 0d? | 2000-01-03 | 2000-01-03 |  |  | 2000-01-03 | 2000-01-03 | 0d? | 2604d | start no earlier than 2000-01-03 | CP,RAN,SA,GERAN |  |  |  | Rel-8 |  |  |  |  |  |
| 23 | 15 | **3G Long Term Evolution - Evolved Packet System RAN part** |  | 644d? | 2006-09-25 A | 2009-03-12 | 42% | 375.67d? | 2006-09-25 | 2009-03-12 | 644d? | 206d |  | RP,S5,R5 | 46067.2h | 15930.2h |  | Rel-8 | LTE | NTT DoCoMo |  | MCC_RAN |  |
| 24 | 15.1 | LTE – Physical Layer |  | 380d? | 2006-09-25 A | 2008-03-07 A | 100% |  | 2006-09-25 | 2008-03-07 | 380d? |  | finish no earlier than 2007-09-14 | R1 | 3040h | 3040h |  | Rel-8 | LTE-Phys | NTT DoCoMo |  | MCC_RAN |  |
| 25 | 15.2 | LTE – Radio Interface Layer 2 and 3 Protocol Aspect |  | 449d? | 2006-09-25 A | 2008-06-12 | 90% | 44.9d? | 2006-09-25 | 2008-06-12 | 449d? | 401d | finish no earlier than 2008-06-12 | R2 | 3592h | 3232.8h |  | Rel-8 | LTE-L23 | Nokia |  | MCC_RAN |  |
| 26 | 15.3 | LTE – eUTRAN Interfaces |  | 449d? | 2006-09-25 A | 2008-06-12 | 90% | 44.9d? | 2006-09-25 | 2008-06-12 | 449d? | 401d | finish no earlier than 2008-06-12 | R3 | 3592h | 3232.8h |  | Rel-8 | LTE-interfaces | Ericsson |  | MCC_RAN |  |
| 27 | 15.4 | LTE – RF Radio Transmission/Reception, System Performance Requirements and Conformance Testing |  | 449d? | 2006-09-25 A | 2008-06-12 | 40% | 269.4d? | 2006-09-25 | 2008-06-12 | 449d? | 401d | finish no earlier than 2008-06-12 | R4 | 3592h | 1436.8h |  | Rel-8 | LTE-RF | NSN |  | MCC_RAN |  |
| 28 | 15.5 | LTE FDD repeaters |  | 261d? | 2007-09-14 A | 2008-09-12 | 20% | 208.8d? | 2007-09-14 | 2008-09-12 | 261d? | 335d | finish no earlier than 2008-09-12 | R4 | 2088h | 417.6h |  | Rel-8 | LTE-Repeaters | Powerwave, Andrew Wireless |  | MCC_RAN |  |

Notes:
- 7: SA#39 moved to Rel-9. / Text3: 22.182
- 8: SA#38 moved to Rel-9 / Text3: 22.101
- 9: SA#39 moved to Rel-9
- 12: WID approved SA#38 / Text3: 23.8xx,22.101,23.060,23.167,23.228,23.271,23.203,23.401,23.402,23.221
- 13: SA#39 created to host Rel-9 Wis. BUT no agreed WID
- 14: SA#39 SAE functionality moved to Rel-9. BUT no agreed WID
- 15: SA#39 SAE functionality moved to Rel-9. WID returned to SA2 for re-consideration & remove MBMS for EPS from Rel 8
- 16: SA#39 SAE functionality moved to Rel-9. BUT no agreed WID
- 17: SA#39 SAE functionality moved to Rel-9. BUT no agreed WID
- 18: SA#39 SAE functionality moved to Rel-9. BUT no agreed WID
- 19: SA#39 SAE functionality moved to Rel-9. BUT no agreed WID
- 20: RAN#39: No agreed WID / Text3: 36.306,36.331,36.413,36.300,36.214,36.133,36.304
- 21: RAN#39: No agreed WID / Text3: 25.306,25.331,25.413
- 23: Status report in RP-070738.
- 24: Status report in RP-080207. Completed at RAN#39 / Text3: 36.2xy
- 25: Status report in RP-080207 / Text3: 36.3xy
- 26: Status report in RP-080207 / Text3: 36.4xy
- 27: Status report in RP-080207 / Text3: 36.1xy
- 28: WI Description in RP-0080034 / Text3: 36.x,25.113

| ID | WBS | Task | Duration | Start | Finish | Complete | Remaining | Baseline start | Baseline finish | Baseline duration | Total slack | Constraint | Resources | Work | Actual work | Text1 | Text4 | Text5 | Text6 | Text8 | Text3 |
| --- | --- | --- | --- | --- | --- | --- | --- | --- | --- | --- | --- | --- | --- | --- | --- | --- | --- | --- | --- | --- | --- |
| 29 | 15.6 | **LTE – Terminal Conformance Test Specifications** | 401d? | 2007-06-01 A | 2008-12-12 | 10% | 360.9d? | 2007-06-01 | 2008-12-12 | 401d? | 270d |  | R5 | 7672h | 589.6h | LTE-UEConTest | NEC | catherine.salinoc@nectech.fr | Rel-8 | MCC_RAN |  |
| 30 | 15.6.1 | 3G Long Term Evolution – Terminal Protocol Conformance Test Specifications | 401d? | 2007-06-01 A | 2008-12-12 | 10% | 360.9d? | 2007-06-01 | 2008-12-12 | 401d? | 270d | finish no earlier than 2008-12-12 | R5 | 3208h | 320.8h | LTE-UEConTest_SIG | NEC, Motorola | catherine.salinoc@nectech.fr, Jacob.John@motorola.com | Rel-8 | Stoyan | 36.508,36.523-1/2/3 |
| 31 | 15.6.2 | 3G Long Term Evolution – Terminal Radio Transmission and Reception Conformance Test Specifications | 336d? | 2007-06-01 A | 2008-09-12 | 10% | 302.4d? | 2007-06-01 | 2008-09-12 | 336d? | 335d | finish no earlier than 2008-09-12 | R5 | 2688h | 268.8h | LTE-UEConTest_RF | Agilent | andrea_leonardi@agilent.com | Rel-8 | Stoyan | 36.508,36.521-1/2 |
| 32 | 15.7 | **E-UTRAN Data Definitions** | 389d? | 2007-09-17 A | 2009-03-12 | 26% | 289.47d? | 2007-09-17 | 2009-03-12 | 389d? | 206d |  | S5 | 12056h | 3084.63h | E-UTRAN-OAM | Huawei |  | Rel-8 | Dionisio |  |
| 33 | 15.7.1 | Subscriber and Equipment Trace for eUTRAN and EPC | 324d? | 2007-09-17 A | 2008-12-11 | 50% | 162d? | 2007-09-17 | 2008-12-11 | 324d? | 271d | finish no earlier than 2008-12-11 | S5 | 2592h | 1296h | E-UTRAN-OAM | Ericsson |  | Rel-8 | Dionisio | 32.42x,32.44x |
| 34 | 15.7.2 | E-UTRAN Network Resource Model (NRM) Integration Reference Point (IRP) | 309d? | 2008-01-07 A | 2009-03-12 | 20% | 247.2d? | 2008-01-07 | 2009-03-12 | 309d? | 206d | finish no earlier than 2009-03-12 | S5 | 2472h | 494.4h | E-UTRAN-OAM | Ericsson |  | Rel-8 | Dionisio | 32.761/2/3/5 |
| 35 | 15.7.3 | Performance measurements for E-UTRAN | 210d? | 2008-02-22 A | 2008-12-11 | 10% | 189d? | 2008-02-22 | 2008-12-11 | 210d? | 271d | start no earlier than 2008-02-22 | S5 | 1680h | 168h | E-UTRAN-OAM | Motorola, Huawei |  | Rel-8 | Dionisio | 32.4yz |
| 36 | 15.7.4 | Key Performance Indicators (KPIs) for E-UTRAN | 275d? | 2008-02-22 A | 2009-03-12 | 15% | 233.75d? | 2008-02-22 | 2009-03-12 | 275d? | 206d | finish no earlier than 2009-03-12 | S5 | 2200h | 330h | E-UTRAN-OAM | Ericsson |  | Rel-8 | Dionisio | 32.4bc/d |
| 37 | 15.8 | **Management of Self-Organizing Networks (SON)** | 210d? | 2008-02-22 A | 2008-12-11 | 13% | 182d? | 2008-02-22 | 2008-12-11 | 210d? | 271d |  | S5 | 6720h | 896h | LTE_SON-OAM | Vodafone |  | Rel-8 | Dionisio | 32.xy1 |
| 38 | 15.8.1 | Self-Establishment of eNBs | 210d? | 2008-02-22 A | 2008-12-11 | 20% | 168d? | 2008-02-22 | 2008-12-11 | 210d? | 271d | start no earlier than 2008-02-22 | S5 | 1680h | 336h | LTE_SON-OAM | NSN |  | Rel-8 | Dionisio | 32.sc0,32.76x/32.75x |
| 39 | 15.8.2 | SON Automatic Neighbour Relations (ANR) List Management | 210d? | 2008-02-22 A | 2008-12-11 | 10% | 189d? | 2008-02-22 | 2008-12-11 | 210d? | 271d | finish no earlier than 2008-12-11 | S5 | 1680h | 168h | LTE_SON-OAM | Ericsson |  | Rel-8 | Dionisio | 32.xy1,32.76x |
| 40 | 15.8.3 | SON Self-Optimization & Self-Healing handling | 210d? | 2008-02-22 A | 2008-12-11 | 10% | 189d? | 2008-02-22 | 2008-12-11 | 210d? | 271d | finish no earlier than 2008-12-11 | S5 | 1680h | 168h | LTE_SON-OAM | Huawei |  | Rel-8 | Dionisio | 32.xyz |
| 41 | 16 | **3GPP System Architecture Evolution Specification - Evolved Packet System (non RAN aspects)** | 762d? | 2006-04-12 A | 2009-03-12 | 30% | 533.72d? | 2006-04-12 | 2009-03-12 | 762d? | 206d |  | S1,S2,S3,S5,C1,C3,C4,C6 | 213174h | 58470.2h | SAES | Samsung | osok.song@samsung.com | Rel-8 | Maurice | 23.228,23.279,23.402 |
| 42 | 16.1 | Requirements for evolution of the 3GPP system architecture | 395d? | 2006-06-08 A | 2007-12-12 A | 100% |  | 2006-06-08 | 2007-12-12 | 395d? |  | finish no earlier than 2007-11-30 | S1 | 3160h | 3160h | AIPN-SAE | T-Mobile | michael.kurz@t-mobile.at | Rel-8 | Alain | 22.278,22.011,22.246 |
| 43 | 16.2 | **High level and common (for all accesses) functions** | 514d? | 2007-01-02 A | 2008-12-19 | 23% | 396.59d? | 2007-01-02 | 2008-12-19 | 514d? | 265d |  | S2,S3,C1,C3,C4 | 36216h | 7525.2h | EPS-ComF | NSN |  | Rel-8 | Maurice |  |
| 44 | 16.2.1 | Stage 2 for High level functions | 370d? | 2007-01-02 A | 2008-06-02 | 95% | 18.5d? | 2007-01-02 | 2008-06-02 | 370d? | 409d | finish no earlier than 2008-06-02 | S2 | 2960h | 2812h | SAES-SA-HLF | NSN |  | Rel-8 | Maurice | 23.402 |
| 45 | 16.2.2 | Stage 2 Security Architecture | 62d? | 2008-03-12 A | 2008-06-05 | 50% | 31d? | 2008-03-12 | 2008-06-05 | 62d? | 406d | finish no earlier than 2008-06-05 | S3 | 496h | 248h | SAES | NSN | BLOMMAERT, Marc | Rel-8 | Dioniso | 33.401, 33.210,33.310 |
| 46 | 16.2.3 | Stage 3 (CT1) for SAE impact on services, network functions and capabilities | 485d? | 2007-02-05 A | 2008-12-15 | 18% | 397.7d? | 2007-02-05 | 2008-12-15 | 485d? | 270d | finish no earlier than 2008-12-15 | C1 | 3880h | 698.4h | SAES | NSN | robert.zaus@nsn.com | Rel-8 | Andrijana | 24.229, 24.305, 27.007 |
| 47 | 16.2.4 | Stage 3 SAE impact on existing capabilities | 490d? | 2007-02-05 | 2008-12-19 |  |  | 2007-02-05 | 2008-12-19 | 490d? | 265d | finish no earlier than 2008-12-19 | C3 | 3920h |  | SAES | Huawei |  | Rel-8 | Gwiho |  |
| 48 | 16.2.5 | Stage 3 (CT4) of SAE impact on existing capabilities | 480d? | 2007-02-05 A | 2008-12-05 | 10% | 432d? | 2007-02-05 | 2008-12-05 | 480d? | 275d | finish no earlier than 2008-12-05 | C4 | 3840h | 384h | SAES | Huawei |  | Rel-8 | Kimmo |  |
| 49 | 16.2.6 | Stage 2/3 for Network selection procedures | 485d? | 2007-02-05 A | 2008-12-15 | 40% | 291d? | 2007-02-05 | 2008-12-15 | 485d? | 270d | finish no earlier than 2008-12-15 | C1 | 3880h | 1552h | SAES | NSN | robert.zaus@nsn.com | Rel-8 | Andrijana | 23.122, 24.302 |
| 50 | 16.2.7 | Stage 3 PCC within SAE | 490d? | 2007-02-05 A | 2008-12-19 | 5% | 465.5d? | 2007-02-05 | 2008-12-19 | 490d? | 265d | finish no earlier than 2008-12-19 | C3 | 3920h | 196h | SAES-PCC | Ericsson | j.javier.pastor@ericsson.com | Rel-8 | Gwiho |  |
| 51 | 16.2.8 | Stage 3 EPC interworking with external PDNs (SGi) | 490d? | 2007-02-05 A | 2008-12-19 | 3% | 475.3d? | 2007-02-05 | 2008-12-19 | 490d? | 265d | finish no earlier than 2008-12-19 | C3 | 3920h | 117.6h | SAES-IW | Huawei | weiwh@huawei.com | Rel-8 | Gwiho |  |
| 52 | 16.2.9 | Stage 3 for SAE / LTE identities | 480d? | 2007-02-05 A | 2008-12-05 | 10% | 432d? | 2007-02-05 | 2008-12-05 | 480d? | 275d | finish no earlier than 2008-12-05 | C4 | 3840h | 384h | SAES | Huawei |  | Rel-8 | Kimmo |  |
| 53 | 16.2.10 | Unified guidelines for Diameter usage within 3GPP | 181d? | 2007-09-21 A | 2008-05-30 | 65% | 63.35d? | 2007-09-21 | 2008-05-30 | 181d? | 410d | finish no earlier than 2008-05-30 | C3 | 1448h | 941.2h | SAES-DIAM | Huawei | Javier Gonzalez Gallego | Rel-8 | Gwiho | 29.909 |

Notes:
- 29: BB place holder for a number of RAN5 Tasks
- 30: Dependent on RAN as well as on CT/SA WIs
- 34: 12/07 SA#38 WID Approval
- 35: SA#39 WID Approval
- 36: SA#39 WID Approval
- 37: SA#39 WID Approval
- 38: SA#39 WID Approval
- 39: SA#39 WID Approval
- 40: SA#39 WID Approval
- 42: SA#38 completed
- 45: SA#39: WID update of SP-070933. WP record created
- 50: C3-46: Progress made but completion date now estimated end 2008
- 53: CP-37: WI approved. C3-46: early draft of 29.909 available.

| ID | WBS | Task | Type | Duration | Start | Finish | Complete | Remaining | Baseline start | Baseline finish | Baseline duration | Total slack | Constraint | Resources | Work | Actual work | Text1 | Text3 | Text4 | Text6 | Text8 | Text5 | Text12 |
| --- | --- | --- | --- | --- | --- | --- | --- | --- | --- | --- | --- | --- | --- | --- | --- | --- | --- | --- | --- | --- | --- | --- | --- |
| 54 | 16.3 | **SAE for LTE access** |  | 514d? | 2007-01-02 A | 2008-12-19 | 29% | 365d? | 2007-01-02 | 2008-12-19 | 514d? | 265d |  | S2,C1,C3,C4 | 49016h | 12023.6h | SAES-LTE | 23.402 | NSN | Rel-8 | Maurice |  |  |
| 55 | 16.3.1 | CT4 Stage 3 for protocol between EPCs |  | 480d? | 2007-02-05 A | 2008-12-05 | 10% | 432d? | 2007-02-05 | 2008-12-05 | 480d? | 275d | finish no earlier than 2008-12-05 | C4 | 3840h | 384h | SAES |  | Huawei | Rel-8 | Kimmo |  |  |
| 56 | 7.2.2.1 | **SAES-SA-FP_LTE with GTP variant** |  | 504d? | 2007-01-02 A | 2008-12-05 | 46% | 273.7d? | 2007-01-02 | 2008-12-05 | 504d? | 275d |  | S2,C4 | 10832h | 3683.2h | SAES-SA-FP_LTE-GTP |  | NSN | Rel-8 | Maurice |  |  |
| 57 | 16.3.2.1 | Stage 2 for SAES-SA-FP_LTE with GTP variant |  | 370d? | 2007-01-02 A | 2008-06-02 | 92% | 29.6d? | 2007-01-02 | 2008-06-02 | 370d? | 409d | finish no earlier than 2008-06-02 | S2 | 2960h | 2723.2h | SAES-SA-FP_LTE-GTP-St2 |  | NSN | Rel-8 | Maurice |  |  |
| 58 | 16.3.2.2 | CT4 Stage 3 for GTP v2 protocol |  | 480d? | 2007-02-05 A | 2008-12-05 | 10% | 432d? | 2007-02-05 | 2008-12-05 | 480d? | 275d | finish no earlier than 2008-12-05 | C4 | 3840h | 384h | SAES |  | Huawei | Rel-8 | Kimmo |  |  |
| 59 | 7.2.2.2 | **SAES-SA-FP_LTE with PMIP variant** |  | 504d? | 2007-01-02 A | 2008-12-05 | 47% | 267.12d? | 2007-01-02 | 2008-12-05 | 504d? | 275d |  | S2,C4 | 10832h | 3772h | SAES-SA-FP_LTE-IETF |  | NSN | Rel-8 | Maurice |  |  |
| 60 | 16.3.3.1 | Stage 2 for SAES-SA-FP_LTE with PMIP variant |  | 370d? | 2007-01-02 A | 2008-06-02 | 95% | 18.5d? | 2007-01-02 | 2008-06-02 | 370d? | 409d | finish no earlier than 2008-06-02 | S2 | 2960h | 2812h | SAES-SA-FP_LTE-IETF-St2 |  | NSN | Rel-8 | Maurice |  |  |
| 61 | 16.3.3.2 | CT4 Stage 3 for PMIP protocol within EPC |  | 480d? | 2007-02-05 A | 2008-12-05 | 10% | 432d? | 2007-02-05 | 2008-12-05 | 480d? | 275d | finish no earlier than 2008-12-05 | C4 | 3840h | 384h | SAES |  | Huawei | Rel-8 | Kimmo |  |  |
| 62 | 16.3.4 | Stage 3 for UE NAS mobility procedures in idle and active mode |  | 485d? | 2007-02-05 A | 2008-12-15 | 35% | 315.25d? | 2007-02-05 | 2008-12-15 | 485d? | 270d | finish no earlier than 2008-12-15 | C1 | 3880h | 1358h | SAES | 24.007, 24.301 | NSN | Rel-8 | Andrijana | robert.zaus@nsn.com |  |
| 63 | 16.3.5 | Stage 3 for Session management, bearer control and QoS aspects |  | 485d? | 2007-02-05 A | 2008-12-15 | 33% | 324.95d? | 2007-02-05 | 2008-12-15 | 485d? | 270d | finish no earlier than 2008-12-15 | C1 | 3880h | 1280.4h | SAES | 24.007, 24.301 | NSN | Rel-8 | Andrijana | robert.zaus@nsn.com |  |
| 64 | 16.3.6 | Stage 3 for security aspects of LTE Access |  | 485d? | 2007-02-05 A | 2008-12-15 | 25% | 363.75d? | 2007-02-05 | 2008-12-15 | 485d? | 270d | finish no earlier than 2008-12-15 | C1 | 3880h | 970h | SAES | 24.008, 24.301 | NSN | Rel-8 | Andrijana | robert.zaus@nsn.com |  |
| 65 | 16.3.7 | Stage 3 for QoS mechanisms |  | 490d? | 2007-02-05 | 2008-12-19 |  |  | 2007-02-05 | 2008-12-19 | 490d? | 265d | finish no earlier than 2008-12-19 | C3 | 3920h |  | SAES |  | Ericsson | Rel-8 | Gwiho | j.javier.pastor@ericsson.com |  |
| 66 | 16.3.8 | Stage 3 for EPC - HSS interface |  | 480d? | 2007-02-05 A | 2008-12-05 | 10% | 432d? | 2007-02-05 | 2008-12-05 | 480d? | 275d | finish no earlier than 2008-12-05 | C4 | 3840h | 384h | SAES |  | Huawei | Rel-8 | Kimmo |  |  |
| 67 | 16.4 | **SAE for Interoperation between LTE and legacy cellular PS accesses** |  | 485d? | 2007-02-05 A | 2008-12-15 | 23% | 374.84d? | 2007-02-05 | 2008-12-15 | 485d? | 270d |  | S2,C1,C4 | 33048h | 6818.8h | SAES-SA-FP_3GPP | 23.402 | NSN | Rel-8 | Maurice |  |  |
| 68 | 16.4.1 | Stage 2 for Interoperation between LTE and 2G/3G |  | 351d? | 2007-02-05 A | 2008-06-09 | 85% | 52.65d? | 2007-02-05 | 2008-06-09 | 351d? | 404d | finish no earlier than 2008-06-09 | S2 | 2808h | 2386.8h | EPSto2_3G |  | NSN | Rel-8 | Maurice |  |  |
| 69 | 16.4.2 | Stage 3 for Inter-system mobility between E-UTRAN and 2G/3G |  | 485d? | 2007-02-05 A | 2008-12-12 | 5% | 460.75d? | 2007-02-05 | 2008-12-12 | 485d? | 270d | start no earlier than 2007-02-05 | C1 | 3880h | 194h | SAES | 24.008, 24.301 | NSN | Rel-8 | Andrijana | robert.zaus@nsn.com |  |
| 70 | 16.4.3 | Stage 2 GPRS for EPC (23.060, etc.) |  | 180d? | 2008-01-14 A | 2008-09-19 | 15% | 153d? | 2008-01-14 | 2008-09-19 | 180d? | 330d | start no earlier than 2008-01-14 | S2 | 1440h | 216h | SAES |  | NSN | Rel-8 | Maurice |  |  |
| 71 | 16.4.4 | Stage 3 for EPC - GPRS |  | 480d? | 2007-02-05 A | 2008-12-05 | 10% | 432d? | 2007-02-05 | 2008-12-05 | 480d? | 275d | finish no earlier than 2008-12-05 | C4 | 3840h | 384h | SAES |  | Huawei | Rel-8 | Kimmo |  |  |
| 72 | 16.4.5 | Stage 3 for EPC to UTRAN |  | 480d? | 2007-02-05 A | 2008-12-05 | 10% | 432d? | 2007-02-05 | 2008-12-05 | 480d? | 275d | finish no earlier than 2008-12-05 | C4 | 3840h | 384h | SAES |  | Huawei | Rel-8 | Kimmo |  |  |
| 73 | 16.4.6 | Stage 3 for EPC to 3GPP2 |  | 480d? | 2007-02-05 A | 2008-12-05 | 10% | 432d? | 2007-02-05 | 2008-12-05 | 480d? | 275d | finish no earlier than 2008-12-05 | C4 | 3840h | 384h | SAES |  | Huawei | Rel-8 | Kimmo |  |  |
| 74 | 16.4.7 | Stage 2 for Interoperation between LTE and CDMA2000 |  | 225d? | 2007-06-18 A | 2008-04-25 | 95% | 11.25d? | 2007-06-18 | 2008-04-25 | 225d? | 435d | finish no earlier than 2008-04-25 | S2 | 1800h | 1710h | EPStoC2k |  | NSN | Rel-8 | Maurice |  |  |
| 75 | 16.4.8 | Stage 3 for Inter-system mobility between E-UTRAN and CDMA2000 |  | 485d? | 2007-02-05 A | 2008-12-15 | 15% | 412.25d? | 2007-02-05 | 2008-12-15 | 485d? | 270d | finish no earlier than 2008-12-15 | C1 | 3880h | 582h | SAES | 24.301, 24.302 | NSN | Rel-8 | Andrijana | robert.zaus@nsn.com |  |
| 76 | 16.4.9 | Stage 3 for MME - SGSN "signalling free" protocol |  | 480d? | 2007-02-05 A | 2008-12-05 | 10% | 432d? | 2007-02-05 | 2008-12-05 | 480d? | 275d | finish no earlier than 2008-12-05 | C4 | 3840h | 384h | SAES |  | Huawei | Rel-8 | Kimmo |  |  |
| 77 | 16.5 | **SAE for support for non-3GPP accesses** |  | 509d? | 2007-01-02 A | 2008-12-15 | 28% | 368.37d? | 2007-01-02 | 2008-12-15 | 509d? | 270d |  | S2,S3,C1,C4 | 49592h | 12962.8h | SAES-SA-FP_n3GPP | 23.402 | NSN | Rel-8 | Maurice |  |  |
| 78 | 7.2.4.1 | Stage 2 for Host-based Mobility aspects |  | 334d? | 2007-01-02 A | 2008-04-11 | 95% | 16.7d? | 2007-01-02 | 2008-04-11 | 334d? | 445d | finish no earlier than 2008-04-11 | S2 | 2672h | 2538.4h | SAES-SA-FP_n3GPP-HBMob |  | NSN | Rel-8 | Maurice |  |  |
| 79 | 7.2.4.2 | Stage 2 for Network-based Mobility aspects |  | 375d? | 2007-01-02 A | 2008-06-09 | 85% | 56.25d? | 2007-01-02 | 2008-06-09 | 375d? | 404d | finish no earlier than 2008-06-09 | S2 | 3000h | 2550h | SAES-SA-FP_n3GPP-NBMob |  | NSN | Rel-8 | Maurice |  |  |
| 80 | 16.5.3 | Stage 3 for Mobility management based on DSMIP v6 |  | 485d? | 2007-02-05 A | 2008-12-15 | 55% | 218.25d? | 2007-02-05 | 2008-12-15 | 485d? | 270d | finish no earlier than 2008-12-15 | C1 | 3880h | 2134h | SAES | 24.303 | NSN | Rel-8 | Andrijana | robert.zaus@nsn.com |  |
| 81 | 16.5.4 | Stage 3 for Mobility management based on MIP v4 |  | 485d? | 2007-02-05 A | 2008-12-12 | 20% | 388d? | 2007-02-05 | 2008-12-12 | 485d? | 270d | start no earlier than 2007-02-05 | C1 | 3880h | 776h | SAES | 24.304 | NSN | Rel-8 | Andrijana | robert.zaus@nsn.com |  |
| 82 | 16.5.5 | Stage 3 for Inter-system mobility between E-UTRAN and non 3GPP accesses |  | 485d? | 2007-02-05 A | 2008-12-12 | 5% | 460.75d? | 2007-02-05 | 2008-12-12 | 485d? | 270d | start no earlier than 2007-02-05 | C1 | 3880h | 194h | SAES | 24.301 | NSN | Rel-8 | Andrijana | robert.zaus@nsn.com |  |
| 83 | 16.5.6 | Stage 2 for Optimized Dual-Radio Handover with WiMAX |  | 251d? | 2007-06-25 A | 2008-06-09 | 65% | 87.85d? | 2007-06-25 | 2008-06-09 | 251d? | 404d | finish no earlier than 2008-06-09 | S2 | 2008h | 1305.2h | SAES-SA-FP_n3GPP-OptWIMAX |  | NSN | Rel-8 | Maurice |  |  |
| 84 | 16.5.7 | Stage 2 Security aspects for 3GPP Access |  | 62d? | 2008-03-12 A | 2008-06-05 | 40% | 37.2d? | 2008-03-12 | 2008-06-05 | 62d? | 406d | finish no earlier than 2008-06-05 | S3 | 496h | 198.4h | SAES | 33.402, 33.210,33.310 | NSN | Rel-8 | Dioniso | BLOMMAERT, Marc |  |
| 85 | 16.5.8 | Stage 3 security aspects for DSMIP v6 Access |  | 485d? | 2007-02-05 A | 2008-12-15 | 15% | 412.25d? | 2007-02-05 | 2008-12-15 | 485d? | 270d | finish no earlier than 2008-12-15 | C1 | 3880h | 582h | SAES | 24.303 | NSN | Rel-8 | Andrijana | robert.zaus@nsn.com |  |
| 86 | 16.5.9 | Stage 3 security aspects for MIPv4 Access |  | 485d? | 2007-02-05 | 2008-12-15 |  |  | 2007-02-05 | 2008-12-15 | 485d? | 270d | finish no earlier than 2008-12-15 | C1 | 3880h |  | SAES | 24.304 | NSN | Rel-8 | Andrijana | robert.zaus@nsn.com |  |
| 87 | 16.5.10 | Stage 3 for Access to the EPC via non-3GPP access networks |  | 485d? | 2007-02-05 A | 2008-12-15 | 23% | 373.45d? | 2007-02-05 | 2008-12-15 | 485d? | 270d | finish no earlier than 2008-12-15 | C1 | 3880h | 892.4h | SAES | 24.302 | NSN | Rel-8 | Andrijana | robert.zaus@nsn.com |  |
| 88 | 16.5.11 | Stage 3 for interfaces within EPC |  | 318d? | 2007-09-19 A | 2008-12-05 | 10% | 286.2d? | 2007-09-19 | 2008-12-05 | 318d? | 275d | finish no earlier than 2008-12-05 | C4 | 2544h | 254.4h | SAES |  | Huawei | Rel-8 | Kimmo |  |  |
| 89 | 16.5.12 | Stage 3 for Interfaces EPC - non-3GPP IP access |  | 480d? | 2007-02-05 A | 2008-12-05 | 10% | 432d? | 2007-02-05 | 2008-12-05 | 480d? | 275d | finish no earlier than 2008-12-05 | C4 | 3840h | 384h | SAES |  | Huawei | Rel-8 | Kimmo |  |  |
| 90 | 16.5.13 | Stage 3 for AAA/HSS related |  | 480d? | 2007-02-05 A | 2008-12-05 | 10% | 432d? | 2007-02-05 | 2008-12-05 | 480d? | 275d | finish no earlier than 2008-12-05 | C4 | 3840h | 384h | SAES |  | Huawei | Rel-8 | Kimmo |  |  |
| 91 | 16.5.14 | Stage 3 for EPC - AAA interface |  | 480d? | 2007-02-05 A | 2008-12-05 | 10% | 432d? | 2007-02-05 | 2008-12-05 | 480d? | 275d | finish no earlier than 2008-12-05 | C4 | 3840h | 384h | SAES |  | Huawei | Rel-8 | Kimmo |  |  |
| 92 | 16.5.15 | Deleted (already covered) SAES-SA-FP_n3GPP Optimized Handover with CDMA | milestone | 0d? | 2007-06-25 A | 2007-06-25 A | 100% |  | 2007-06-25 | 2007-06-25 | 0d? |  | finish no earlier than 2007-06-25 | S2 |  |  | SAES-SA-FP_n3GPP-OptCDMA |  | NSN | Rel-8 | Maurice |  | SP-37 |
| 93 | 16.6 | Single Radio Voice Call Continuity for 3GPP |  | 445d? | 2007-01-02 A | 2008-09-15 | 50% | 222.5d? | 2007-01-02 | 2008-09-15 | 445d? | 334d | finish no earlier than 2008-09-15 | S2 | 3560h | 1780h | SAES | 23.216 | NSN | Rel-8 | Maurice |  |  |
| 94 | 16.7 | Voice Call Continuity for CDMA2000 1X |  | 255d? | 2007-06-25 A | 2008-06-13 | 80% | 51d? | 2007-06-25 | 2008-06-13 | 255d? | 400d | finish no earlier than 2008-06-13 | S2 | 2040h | 1632h | SAES |  | NSN | Rel-8 | Maurice |  |  |
| 95 | 16.8 | SAE impacts on IMS (e.g. Local Break Out aspects) |  | 379d? | 2007-01-02 A | 2008-06-13 | 40% | 227.4d? | 2007-01-02 | 2008-06-13 | 379d? | 400d | finish no earlier than 2008-06-13 | S2 | 3032h | 1212.8h | SAES-SA-SR_VCC |  | NSN | Rel-8 | Maurice |  |  |
| 96 | 16.9 | CS Fallback in EPS |  | 127d? | 2008-03-12 A | 2008-09-04 | 60% | 50.8d? | 2008-03-12 | 2008-09-04 | 127d? | 341d | start no earlier than 2008-03-12 | S2 | 1016h | 609.6h | SAES-CSFB | 23272,23.401 | T-Mobile | Rel-8 | Maurice | Sabine Demel |  |
| 97 | 16.10 | System enhancements for the use of IMS services in local breakout |  | 62d? | 2008-03-12 | 2008-06-05 |  |  | 2008-03-12 | 2008-06-05 | 62d? | 406d | finish no earlier than 2008-06-05 | S2 | 496h |  | SAES-SA-on_IMS | 23.228,23.221,23.203 | Telecom Italia | Rel-8 | Maurice | mario.madella@telecomitalia.it |  |

Notes:
- 55: Name changed from "Stage 3 for PMIP protocol between EPCs" to incorporate GTP part also
- 77: SA#39: retained in Rel 8 (in addition to the essential functionality defined in SP-070699)
- 84: SA#39: WID update of SP-070933. WP record created
- 85: post-CT#39: split into DSMIP v6 and MIPv4 Access
- 86: post-CT#39: split into DSMIP v6 and MIPv4 Access
- 92: SA#37 stopped
- 93: SA#38 WID approved. SA#39: retained in Rel 8 (in addition to the essential functionality defined in SP-070699)
- 95: SA#39: retained in Rel 8 (in addition to the essential functionality defined in SP-070699)
- 96: SA#39: retained in Rel 8 (in addition to the essential functionality defined in SP-070699)

| ID | WBS | Task | Type | Duration | Start | Finish | Complete | Remaining | Baseline start | Baseline finish | Baseline duration | Total slack | Constraint | Resources | Work | Actual work | Text1 | Text4 | Text6 | Text8 | Text5 | Text12 |
| --- | --- | --- | --- | --- | --- | --- | --- | --- | --- | --- | --- | --- | --- | --- | --- | --- | --- | --- | --- | --- | --- | --- |
| 98 | 16.11 | **EPC Data Definitions** |  | 309d? | 2008-01-07 A | 2009-03-12 | 20% | 247.2d? | 2008-01-07 | 2009-03-12 | 309d? | 206d |  | S5 | 6624h | 1324.8h | EPC-OAM | Huawei | Rel-8 | Dionisio |  |  |
| 99 | 16.11.1 | EPC Network Resource Model (NRM) Integration Reference Point (IRP) |  | 309d? | 2008-01-07 A | 2009-03-12 | 20% | 247.2d? | 2008-01-07 | 2009-03-12 | 309d? | 206d | finish no earlier than 2009-03-12 | S5 | 2472h | 494.4h | EPC-OAM | Huawei | Rel-8 | Dionisio |  |  |
| 100 | 16.11.2 | Performance measurements for EPC |  | 210d? | 2008-02-22 A | 2008-12-11 | 20% | 168d? | 2008-02-22 | 2008-12-11 | 210d? | 271d | start no earlier than 2008-02-22 | S5 | 1680h | 336h | EPC-OAM | China Mobile | Rel-8 | Dionisio |  |  |
| 101 | 16.12 | EPC Charging |  | 309d? | 2008-01-07 A | 2009-03-12 | 40% | 185.4d? | 2008-01-07 | 2009-03-12 | 309d? | 206d | finish no earlier than 2009-03-12 | S5 | 2472h | 988.8h | EPC-CH | NSN | Rel-8 | Dionisio |  |  |
| 102 | 16.13 | Issues for CT4 TR 24.801 |  | 425d? | 2007-01-04 A | 2008-09-19 | 45% | 233.75d? | 2007-01-04 | 2008-09-19 | 425d? | 330d | finish no earlier than 2008-09-19 | C1 | 3400h | 1530h | SAES | NSN | Rel-8 | Andrijana | robert.zaus@nsn.com |  |
| 103 | 16.14 | Issues for CT4 TR 29.804 |  | 425d? | 2007-02-05 A | 2008-09-19 | 25% | 318.75d? | 2007-02-05 | 2008-09-19 | 425d? | 330d | finish no earlier than 2008-09-19 | C3 | 3400h | 850h | SAES | Ericsson | Rel-8 | Gwiho | j.javier.pastor@ericsson.com |  |
| 104 | 16.15 | Issues for CT4 TR 29.803 |  | 425d? | 2007-01-04 A | 2008-09-19 | 30% | 297.5d? | 2007-01-04 | 2008-09-19 | 425d? | 330d | finish no earlier than 2008-09-19 | C4 | 3400h | 1020h | SAES | Huawei | Rel-8 | Kimmo |  |  |
| 105 | 16.16 | CT6 aspects of SAE |  | 425d? | 2007-02-05 | 2008-09-19 |  |  | 2007-02-05 | 2008-09-19 | 425d? | 330d | start no earlier than 2007-02-05 | C6 | 3400h |  | SAES | Nokia | Rel-8 | Xavier | Peter.vestergaard@nokia.com |  |
| 106 | 16.17 | Deleted (covered by 380068): Functions and procedures for SAE to support LCS | milestone | 0d? | 2008-03-03 A | 2008-03-03 A | 100% |  | 2008-03-03 | 2008-03-03 | 0d? |  | finish no earlier than 2008-03-03 | S2 |  |  | SAES-SA-FP_LCS | NSN | Rel-8 | Maurice |  | SP-37 |
| 107 | 16.18 | Deleted (covered by 380064): SAE aspects of Emergency Calls | milestone | 0d? | 2008-03-03 A | 2008-03-03 A | 100% |  | 2008-03-03 | 2008-03-03 | 0d? |  | start no earlier than 2008-03-03 | S2 |  |  | SAES-SA-EmCall | NSN | Rel-8 | Maurice |  | SP-37 |
| 108 | 16.19 | Deleted - CT1 aspects of SAES |  | 16.7d? | 2007-09-04 A | 2007-09-27 A | 100% |  | 2007-09-04 | 2007-09-27 | 16.7d? |  | start no earlier than 2007-09-04 | CP,C1 | 133.62h | 133.62h | SAES-St3 |  | Rel-8 | Andrijana |  | SP-37 |
| 109 | 16.20 | Deleted - CT1 aspects of SAES | milestone | 0d? | 2007-09-04 A | 2007-09-04 A | 100% |  | 2007-09-04 | 2007-09-04 | 0d? |  | start no earlier than 2007-09-04 | C1 |  |  | SAES-St3 |  | Rel-8 | Andrijana |  | SP-37 |
| 110 | 16.21 | Deleted - Interoperability | milestone | 0d? | 2008-03-14 A | 2008-03-14 A | 100% |  | 2008-03-14 | 2008-03-14 | 0d? |  | start no earlier than 2008-03-14 | C1 |  |  | SAES-St3-interop |  | Rel-8 | Andrijana |  | SP-37 |
| 111 | 16.22 | Deleted - CT3 aspects of SAES | milestone | 0d? | 2007-09-04 A | 2007-09-04 A | 100% |  | 2007-09-04 | 2007-09-04 | 0d? |  | start no earlier than 2007-09-04 | C3 |  |  | SAES-St3 |  | Rel-8 | Gwiho |  | SP-37 |
| 112 | 16.23 | Deleted - CT4 aspects of SAES | milestone | 0d? | 2007-09-04 A | 2007-09-04 A | 100% |  | 2007-09-04 | 2007-09-04 | 0d? |  | start no earlier than 2007-09-04 | C4 |  |  | SAES-St3 |  | Rel-8 | Kimmo |  | SP-37 |
| 113 | 16.24 | Deleted - UE to EPC NAS signalling (incl. MBMS and QoS aspects) | milestone | 0d? | 2008-03-14 A | 2008-03-14 A | 100% |  | 2008-03-14 | 2008-03-14 | 0d? |  | start no earlier than 2008-03-14 | C1 |  |  | SAES-St3-sig |  | Rel-8 | Andrijana |  | SP-37 |
| 114 | 16.25 | Deleted -User and Control plane protocols | milestone | 0d? | 2007-09-21 A | 2007-09-21 A | 100% |  | 2007-09-21 | 2007-09-21 | 0d? |  | start no earlier than 2007-09-21 | C4 |  |  | SAES-St3-prot |  | Rel-8 | Kimmo |  | SP-37 |
| 115 | 16.26 | Deleted - GPRS enhancements for LTE access | milestone | 0d? | 2007-09-04 A | 2007-09-04 A | 100% |  | 2007-09-04 | 2007-09-04 | 0d? |  | start no earlier than 2007-09-04 | S2 |  |  | SAES-GPRS_LTE | Vodafone | Rel-8 | Maurice | chris.pudney@vodafone.com | SP-34 |
| 116 | 16.27 | Deleted - Architecture enhancements for non-3GPP accesses | milestone | 0d? | 2007-09-04 A | 2007-09-04 A | 100% |  | 2007-09-04 | 2007-09-04 | 0d? |  | start no earlier than 2007-09-04 | S2 |  |  | SAES-non_3GPP | Motorola | Rel-8 | Maurice | Irfan.Ali@motorola.com | SP-34 |
| 117 | 16.28 | Deleted: Stage 2 of architecture for the 3GPP System Architecture Evolution | milestone | 0d? | 2007-10-02 A | 2007-10-02 A | 100% |  | 2007-10-02 | 2007-10-02 | 0d? |  | start no earlier than 2007-10-02 | S2 |  |  | SAES-St2 | Vodafone | Rel-8 | Maurice | chris.pudney@vodafone.com | SP-34 |
| 118 | 16.29 | Deleted - SA aspects of System Architecture Evolution |  | 384d? | 2006-04-12 A | 2007-10-02 A | 100% |  | 2006-04-12 | 2007-10-02 | 384d? |  | finish no earlier than 2007-10-02 | S2 | 3072h | 3072h | SAES-SA |  | Rel-8 | Maurice |  | SP-34 |
| 119 | 17 | GERAN support for GERAN - 3G Long Term Evolution interworking |  | 576d? | 2006-09-08 A | 2008-11-21 | 45% | 316.8d? | 2006-09-08 | 2008-11-21 | 576d? | 285d | finish no earlier than 2008-11-21 | GP | 4608h | 2073.6h | GELTE | Nokia, NSN | Rel-8 | Paolo | sergio.parolari@nsn.com, vlora.rexhepi@nokia.com |  |
| 120 | 18 | **Enhancements for VGCS Applications (EVA)** |  | 588d? | 2006-03-15 A | 2008-06-15 | 97% | 18.49d? | 2006-03-15 | 2008-06-15 | 588d? | 400d |  | S1,C1,C4,G2 | 18216h | 14615.2h | EVA | Nortel | Rel-8 | Alain | deola@nortel.com |  |
| 121 | 18.1 | SA1 aspects of EVA |  | 191d? | 2006-03-15 A | 2006-12-06 A | 100% |  | 2006-03-15 | 2006-12-06 | 191d? |  | finish no earlier than 2006-12-06 | S1 | 1528h | 1528h | EVA-s1 | Nortel | Rel-8 | Alain | deola@nortel.com |  |
| 122 | 18.2 | VGCS/VBS and GPRS Interactions |  | 145d? | 2007-09-03 A | 2008-03-21 A | 100% |  | 2007-09-03 | 2008-03-21 | 145d? |  | finish no earlier than 2008-03-21 | S1 | 1160h | 1160h | EVA | Huawei | Rel-8 | Alain |  |  |
| 123 | 18.3 | CT1 aspects of EVA |  | 531d? | 2006-06-02 A | 2008-06-15 | 90% | 53.1d? | 2006-06-02 | 2008-06-15 | 531d? | 400d | finish no earlier than 2008-06-15 | C1 | 4248h | 3823.2h | EVA | Nortel | Rel-8 | Andrijana | milanpa@nortel.com |  |
| 124 | 18.4 | CT4 aspects of EVA |  | 391d? | 2006-06-02 A | 2007-11-30 A | 100% |  | 2006-06-02 | 2007-11-30 | 391d? |  | finish no earlier than 2007-06-01 | C4 | 3128h | 3128h | EVA | Nortel | Rel-8 | Kimmo |  |  |
| 125 | 18.5 | GERAN2 aspects of EVA |  | 431d? | 2006-06-30 A | 2008-02-22 A | 100% |  | 2006-06-30 | 2008-02-22 | 431d? |  | finish no earlier than 2008-02-22 | G2 | 3448h | 3448h | EVA-EVGCSA | Nortel | Rel-8 | Gert | frank.billenkamp@nortel.com |  |

Notes:
- 99: 12/07 SA#38 WID Approval / Text3: new32.751/2/3/5
- 100: SA#39 WID Approval / Text3: 32.4xy
- 101: SA#38 WID Approval / Text3: 32.240/296/251/252/298/299
- 102: Text3: 24.801
- 103: Text3: 29.804
- 104: Text3: 29.803
- 105: Text3: 31.102, 31.111
- 106: SA#37 stopped
- 107: SA#37 stopped
- 108: SA#37 stopped
- 109: SA#37 stopped
- 110: SA#37 stopped
- 111: SA#37 stopped
- 112: SA#37 stopped / Text3: 29.803
- 113: SA#37 stopped
- 114: SA#37 stopped
- 115: SA#34 stopped / Text3: 23.401
- 116: SA#34 stopped / Text3: 23.402
- 117: SA#34 stopped / Text3: 23.002,23.060,23.107,23.203,23.228,23.234,23.246,23.271,23.279
- 118: SA#34 stopped
- 119: Text3: 24.008,43.055,43.129,43.246,44.018,44.060,45.002,45.008,45.010,48.008,48.018,51.010
- 121: Text3: 42.068
- 122: is this a one-CR WI? / Text3: 42.068,42.069
- 123: Not reviewed at WG, directly from CT#37 / Text3: 43.068,44.068
- 124: CT4#32: CRs are presented and in principle agreed, waiting for the approval of stage2... / Text3: 29.002
- 125: Text3: 44.018,48.008

| ID | WBS | Task | Type | Duration | Start | Finish | Complete | Remaining | Baseline start | Baseline finish | Baseline duration | Total slack | Constraint | Resources | Work | Actual work | Text1 | Text4 | Text5 | Text6 | Text8 | Text3 | Text12 |
| --- | --- | --- | --- | --- | --- | --- | --- | --- | --- | --- | --- | --- | --- | --- | --- | --- | --- | --- | --- | --- | --- | --- | --- |
| 126 | 19 | **Personal Network Management** |  | 835d? | 2005-07-11 A | 2008-09-19 | 61% | 325.69d? | 2005-07-11 | 2008-09-19 | 835d? | 330d |  | S1,C1 | 20168h | 8656h | PNM | Vodafone | armin.toepfer@vodafone.com | Rel-8 | Alain |  |  |
| 127 | 19.1 | Stage 1 for PNM |  | 276d? | 2005-07-11 A | 2006-07-31 A | 100% |  | 2005-07-11 | 2006-07-31 | 276d? |  | start no earlier than 2005-07-11 | S1 | 2208h | 2208h | PNM | Vodafone |  | Rel-8 | Alain | 22.259,23.818 |  |
| 128 | 19.2 | Stage 2 for PNM |  | 320d? | 2007-03-26 A | 2008-06-15 | 95% | 16d? | 2007-03-26 | 2008-06-15 | 320d? | 400d | finish no earlier than 2008-06-15 | C1 | 2560h | 2432h | PNM | Vodafone | yang.lu@vodafone.com | Rel-8 | Andrijana | 23.259 |  |
| 129 | 19.3 | **Stage 3 for PNM** |  | 390d? | 2007-03-26 A | 2008-09-19 | 30% | 272.72d? | 2007-03-26 | 2008-09-19 | 390d? | 330d |  | C1,C4 | 8720h | 1808h | PNM | Vodafone | yang.lu@vodafone.com | Rel-8 | Andrijana |  |  |
| 130 | 19.3.1 | CT1 aspects of Stage 3 PNM |  | 390d? | 2007-03-26 A | 2008-09-19 | 50% | 195d? | 2007-03-26 | 2008-09-19 | 390d? | 330d | finish no earlier than 2008-09-19 | C1 | 3120h | 1560h | PNM | Vodafone | yang.lu@vodafone.com | Rel-8 | Andrijana | 24.229,24.259 |  |
| 131 | 19.3.2 | CT4 aspects of Stage 3 PNM |  | 310d? | 2007-03-26 A | 2008-05-30 | 5% | 294.5d? | 2007-03-26 | 2008-05-30 | 310d? | 410d | finish no earlier than 2008-05-30 | C4 | 2480h | 124h | PNM | Vodafone |  | Rel-8 | Kimmo | 23.008,23.018,29.002,29.328,29.329 |  |
| 132 | 19.4 | Deleted - Actual Requirements of PNM | milestone | 0d? | 2007-03-26 A | 2007-03-26 A | 100% |  | 2007-03-26 | 2007-03-26 | 0d? |  | finish no earlier than 2007-03-26 | C1 |  |  | PNM | Ericsson |  | Rel-8 | Andrijana |  | SP-37 |
| 133 | 20 | **IMS Service Brokering enhancements** |  | 69d? | 2005-12-07 A | 2006-03-13 A | 100% |  | 2005-12-07 | 2006-03-13 | 69d? |  |  | S1 | 1104h | 1104h | ISB | Telcordia | jbakker@telcordia.com | Rel-8 | Alain | 22.228 |  |
| 134 | 20.1 | Stage 1 for ISB |  | 69d? | 2005-12-07 A | 2006-03-13 A | 100% |  | 2005-12-07 | 2006-03-13 | 69d? |  | finish no earlier than 2006-03-13 | S1 | 552h | 552h | ISB-s1 | Telcordia | jbakker@telcordia.com | Rel-8 | Alain | 22.228 |  |
| 135 | 21 | **eCall Data Transfer** |  | 380d? | 2006-09-28 A | 2008-03-12 A | 100% |  | 2006-09-28 | 2008-03-12 | 380d? |  |  | S1 | 6080h | 6080h | EData | Airbiquity | rrobinson@airbiquity.com | Rel-8 | Alain | 22.101,22.105 |  |
| 136 | 21.1 | eData Requirements |  | 380d? | 2006-09-28 A | 2008-03-12 A | 100% |  | 2006-09-28 | 2008-03-12 | 380d? |  | finish no earlier than 2006-12-07 | S1 | 3040h | 3040h | EData | Airbiquity | rrobinson@airbiquity.com | Rel-8 | Alain | 22.101,22.105 |  |
| 137 | 22 | Local Charging Zone Requirements |  | 380d? | 2006-09-28 A | 2008-03-12 A | 100% |  | 2006-09-28 | 2008-03-12 | 380d? |  | finish no earlier than 2006-12-07 | S1 | 3040h | 3040h | LCZR | China Mobile | liuhongyfw@chinamobile.com | Rel-8 | Alain | 22.115 |  |
| 138 | 23 | **Customized Alerting Tone (CAT)** |  | 464d? | 2006-12-06 A | 2008-09-15 | 56% | 203.3d? | 2006-12-06 | 2008-09-15 | 464d? | 334d |  | S1,C1,C3 | 7670.4h | 3880h | CAT | China Mobile | fenglingjuan@chinamobile.com | Rel-8 | Alain |  |  |
| 139 | 23.1 | Stage 1 for CAT |  | 207d? | 2006-12-06 A | 2007-09-20 A | 100% |  | 2006-12-06 | 2007-09-20 | 207d? |  | start no earlier than 2006-12-06 | S1 | 1656h | 1656h | CAT | China Mobile | (fenglingjuan@chinamobile.com) | Rel-8 | Alain | 22.182 |  |
| 140 | 23.2 | TISPAN requirements for customized multimedia information services |  | 71d? | 2007-09-03 A | 2007-12-10 A | 100% |  | 2007-09-03 | 2007-12-10 | 71d? |  | finish no earlier than 2007-12-10 | S1 | 568h | 568h | TISCMI | Ericsson |  | Rel-8 | Alain | 22.182 |  |
| 141 | 23.3 | IMS CAT Supplementary Service |  | 164d? | 2008-01-30 | 2008-09-15 |  |  | 2008-01-30 | 2008-09-15 | 164d? | 334d | finish no earlier than 2008-09-15 | C1 | 1312h |  | CAT_SS | Nortel | milanpa@nortel.com | Rel-8 | Andrijana | 24.182 |  |
| 142 | 23.4 | CAT solution for voice and video call in CS domain |  | 52.8d? | 2008-03-12 | 2008-06-04 |  |  | 2008-03-12 | 2008-06-04 | 52.8d? | 407d | finish no earlier than 2008-06-04 | C3 | 422.4h |  | CAT_SS | Ericsson |  | Rel-8 | Gwiho |  |  |
| 143 | 24 | **I-WLAN Network Selection Principle (NSP)** |  | 326d? | 2007-06-14 A | 2008-09-12 |  | 326d? | 2007-06-14 | 2008-09-12 | 326d? | 335d |  | S1,C1 | 3696h |  | IWLANNSP | Telefonica O2 | chris.friel@o2.com | Rel-8 | Alain |  |  |
| 144 | 24.1 | Stage 1 for I-WLAN NSP | milestone | 0d? | 2007-06-14 A | 2007-06-14 A | 100% |  | 2007-06-14 | 2007-06-14 | 0d? |  |  | S1 |  |  | IWLANNSP | Telefonica O2 | chris.friel@o2.com | Rel-8 | Alain | 22.234 |  |
| 145 | 24.2 | Stage 3 for I-WLAN NSP |  | 136d? | 2008-03-07 | 2008-09-12 |  |  | 2008-03-07 | 2008-09-12 | 136d? | 335d | finish no earlier than 2008-09-12 | C1 | 1088h |  | IWLANNSP | RIM |  | Rel-8 | Andrijana | 24.234 |  |
| 146 | 25 | **Service-Level Interworking for Messaging Services** |  | 249d? | 2007-03-26 A | 2008-03-07 | 99% | 0d? | 2007-03-26 | 2008-03-07 | 249d? | 0d |  | S1,S2 | 3808h | 1816h | MESSIW | Huawei | ling.liu@huawei.com; duanxiaoqin@huawei.com | Rel-8 | Alain |  |  |
| 147 | 25.1 | Stage 1 for MESSIW | milestone | 0d? | 2007-03-26 A | 2007-03-26 A | 100% |  | 2007-03-26 | 2007-03-26 | 0d? |  | finish no earlier than 2007-12-01 | S1 |  |  | MESSIW-St1 | Huawei | ling.liu@huawei.com | Rel-8 | Alain | 22.105,22.340 |  |
| 148 | 25.2 | Stage 2 for MESSIW |  | 227d? | 2007-04-26 A | 2008-03-07 A | 100% |  | 2007-04-26 | 2008-03-07 | 227d? |  | finish no earlier than 2008-03-07 | S2 | 1816h | 1816h | MESSIW-St2 | Huawei | patrice.hede@huawei.com | Rel-8 | Maurice | 23.811,23.204 |  |
| 149 | 26 | **Multimedia Priority Service** |  | 592d? | 2006-06-08 A | 2008-09-14 | 47% | 311.93d? | 2006-06-08 | 2008-09-14 | 592d? | 335d |  | S1,C1,C3,C4 | 16128h | 7629.88h | PRIOR | Telcordia | jgarraha@telcordia.com | Rel-8 | Alain |  |  |
| 150 | 26.1 | Service Requirements for PRIOR |  | 521d? | 2006-06-08 A | 2008-06-05 | 90% | 52.1d? | 2006-06-08 | 2008-06-05 | 521d? | 406d | finish no earlier than 2007-11-30 | S1 | 4168h | 3751.2h | PRIOR-EMR | Telcordia | jgarraha@telcordia.com | Rel-8 | Alain | 22.153 |  |
| 151 | 26.2 | Stage 3 (CT1) for PRIOR |  | 466d? | 2006-12-01 A | 2008-09-14 | 42% | 270.28d? | 2006-12-01 | 2008-09-14 | 466d? | 335d | finish no earlier than 2008-09-14 | C1 | 3728h | 1565.76h | PRIOR-MM | ALU | drage@alcatel-lucent.com | Rel-8 | Andrijana | 24.229 |  |
| 152 | 26.3 | Stage 3 PRIOR-MM |  | 256d? | 2007-09-21 | 2008-09-14 |  |  | 2007-09-21 | 2008-09-14 | 256d? | 335d | finish no earlier than 2008-09-14 | C3 | 2048h |  | PRIOR-MM | ALU | drage@alcatel-lucent.com | Rel-8 | Gwiho | 29.212,29.213,29.214,29.163 |  |
| 153 | 26.4 | Stage 3 (CT4) for PRIOR |  | 181d? | 2007-09-21 A | 2008-05-30 | 5% | 171.95d? | 2007-09-21 | 2008-05-30 | 181d? | 410d | finish no earlier than 2008-05-30 | C4 | 1448h | 72.4h | PRIOR-MM | ALU |  | Rel-8 | Kimmo | 23.008,29.228,29.229 |  |

Notes:
- 126: Moved from FS section Feb 06. SP-33: Create new section to capture the PNM stage 2 aspects and identify any impacts to existing stage 2 specifications. S2 added as secondary responsibility
- 127: Moved from FS section Feb 06: SP-33: Create new section to capture the PNM stage 2 aspects and identify any impacts to existing stage 2 specifications.
- 129: Moved from FS section Feb 06: SP-33: Create new section to capture the PNM stage 2 aspects and identify any impacts to existing stage 2 specifications.
- 132: SA#37 stopped
- 133: No Rel-8 changes
- 134: No Rel-8 changes
- 135: Check SA4 related activity. SA#39 completed
- 136: Check SA4 related activity. SA#39 completed
- 137: SA#39 completed
- 138: Acronym changed from "CusAlert" to "CAT"
- 140: SA#38 completed
- 144: SA#36 completed
- 148: SA#39 work completed
- 150: SA#39: Was 100% complete 11/2007. New WID approved (Stage 1 CR for Jun 2008). Az: Was exception granted to Jun 2008 ?

| ID | WBS | Task | Duration | Start | Finish | Complete | Remaining | Baseline start | Baseline finish | Baseline duration | Total slack | Constraint | Resources | Work | Actual work | Text1 | Text4 | Text5 | Text6 | Text8 | Text3 | Text7 | Text12 |
| --- | --- | --- | --- | --- | --- | --- | --- | --- | --- | --- | --- | --- | --- | --- | --- | --- | --- | --- | --- | --- | --- | --- | --- |
| 154 | 27 | **Registration in Densely-populated area (RED)** | 391d? | 2007-03-12 A | 2008-09-08 | 51% | 192.42d? | 2007-03-12 | 2008-09-08 | 391d? | 339d |  | S1,S2 | 5160h | 1064h | RED | NTT DoCoMo | takakurat@s1.nttdocomo.co.jp | Rel-8 | Alain |  |  |  |
| 155 | 27.1 | Stage 1 for RED | 4d? | 2007-03-12 A | 2007-03-15 A | 100% |  | 2007-03-12 | 2007-03-15 | 4d? |  | start no earlier than 2007-03-12 | S1 | 32h | 32h | RED-St1 | NTT DoCoMo | takakurat@s1.nttdocomo.co.jp | Rel-8 | Alain | 22.101 |  |  |
| 156 | 27.2 | Stage 2 for RED | 250d? | 2007-09-25 A | 2008-09-08 | 50% | 125d? | 2007-09-25 | 2008-09-08 | 250d? | 339d | finish no earlier than 2008-09-08 | S2 | 2000h | 1000h | RED-St2 | NTT DoCoMo | tanakai@nttdocomo.co.jp | Rel-8 | Maurice | 23.880 |  |  |
| 157 | 28 | **OSA Rel-8** | 351d? | 2007-08-23 A | 2008-12-25 | 99% | 0d? | 2007-08-23 | 2008-12-25 | 351d? | 0d |  | S1,C5 | 35112h | 32664h | OSA8 | Orange |  | Rel-8 | Alain |  | TSG |  |
| 158 | 28.1 | OSA Stage 1 - Service Requirements | 145d? | 2007-08-23 A | 2008-03-12 A | 100% |  | 2007-08-23 | 2008-03-12 | 145d? |  | finish no earlier than 2007-12-04 | S1 | 1160h | 1160h | OSA8 | Orange, AePONA |  | Rel-8 | Alain | 22.127 | TSG |  |
| 159 | 28.2 | OSA Stage 1 - NGN Service Requirement | 140d? | 2007-09-03 A | 2008-03-14 A | 100% |  | 2007-09-03 | 2008-03-14 | 140d? |  | finish no earlier than 2008-03-14 | S1 | 1120h | 1120h | OSA8-IMS | Orange |  | Rel-8 | Alain | 22.127 |  |  |
| 160 | 28.3 | **OSA Stage 2/3 enhancements** | 306d? | 2007-10-25 A | 2008-12-25 A | 100% |  | 2007-10-25 | 2008-12-25 | 306d? |  |  | C5 | 30384h | 30384h | OSA8 | Orange |  | Rel-8 | Adrian | 23.198,29.198/9 |  |  |
| 161 | 28.3.1 | Delete - Ensure Parlay-X composable with identity management frameworks, in particular Liberty Alliance | 306d? | 2007-10-25 A | 2008-12-25 A | 100% |  | 2007-10-25 | 2008-12-25 | 306d? |  | finish no earlier than 2008-12-25 | C5 | 2448h | 2448h | OSA8 | Ericsson, FT/Orange, Sprint, Telecom Italia | catherine.mulligan@ericsson.com | Rel-8 | Adrian | existing 29.199-xy |  | CP-40 |
| 162 | 28.3.2 | Parlay-X Content Management web service (store/manage meta-data) | 157d? | 2007-10-25 A | 2008-05-30 A | 100% |  | 2007-10-25 | 2008-05-30 | 157d? |  | finish no earlier than 2008-12-04 | C5 | 1256h | 1256h | OSA8 | ETRI | Yoo, Hyunkyung (hkyoo@etri.re.kr) | Rel-8 | Adrian | 29.199-21 |  |  |
| 163 | 28.3.3 | Parlay-X Policy web service | 157d? | 2007-10-25 A | 2008-05-30 A | 100% |  | 2007-10-25 | 2008-05-30 | 157d? |  | finish no earlier than 2008-12-04 | C5 | 1256h | 1256h | OSA8 | ETRI | Park, Yoo-mi ( parkym@etri.re.kr) | Rel-8 | Adrian | 29.199-22 |  |  |
| 164 | 28.3.4 | Parlay-X Terminal status web service | 112d? | 2007-10-25 A | 2008-03-28 A | 100% |  | 2007-10-25 | 2008-03-28 | 112d? |  | finish no earlier than 2008-05-30 | C5 | 896h | 896h | OSA8 | Orange | salim.mouniralaoui@orange-ftgroup.com | Rel-8 | Adrian | 29.199-08 |  |  |
| 165 | 28.3.5 | Delete - Identify communication format used by a particular application | 157d? | 2007-10-25 A | 2008-05-30 A | 100% |  | 2007-10-25 | 2008-05-30 | 157d? |  | finish no earlier than 2008-05-30 | C5 | 1256h | 1256h | OSA8 | Ericsson | catherine.mulligan@ericsson.com | Rel-8 | Adrian | existing 29.199-xy |  | CP-40 |
| 166 | 28.3.6 | Delete - Security on User Profile Management - reuse GUP API (22.127 CR 0084 S1-071794) | 277d? | 2007-12-05 A | 2008-12-25 A | 100% |  | 2007-12-05 | 2008-12-25 | 277d? |  | finish no earlier than 2008-12-25 | C5 | 2216h | 2216h | OSA8 | Telecom Italia | vincenzo.amorino@telecomitalia.it | Rel-8 | Adrian | PXWS Framework |  | CP-40 |
| 167 | 28.3.7 | Delete - Privacy on Subscriber Identity (Liberty Alliance, OASIS) (22.127 CR 0085 S1-071835) | 277d? | 2007-12-05 A | 2008-12-25 A | 100% |  | 2007-12-05 | 2008-12-25 | 277d? |  | finish no earlier than 2008-12-25 | C5 | 2216h | 2216h | OSA8 | Telecom Italia | vincenzo.amorino@telecomitalia.it | Rel-8 | Adrian | PXWS Framework |  | CP-40 |
| 168 | 28.3.8 | Delete - Topology Hiding (22.127 CR 0086 S1-071838) | 277d? | 2007-12-05 A | 2008-12-25 A | 100% |  | 2007-12-05 | 2008-12-25 | 277d? |  | finish no earlier than 2008-12-25 | C5 | 2216h | 2216h | OSA8 | Telecom Italia | vincenzo.amorino@telecomitalia.it | Rel-8 | Adrian | PXWS Framework |  | CP-40 |
| 169 | 28.3.9 | Delete - Subscriber event notification (22.127 CR 0087 S1-071836) | 277d? | 2007-12-05 A | 2008-12-25 A | 100% |  | 2007-12-05 | 2008-12-25 | 277d? |  | finish no earlier than 2008-12-25 | C5 | 2216h | 2216h | OSA8 | Telecom Italia | vincenzo.amorino@telecomitalia.it | Rel-8 | Adrian | PXWS Framework |  | CP-40 |
| 170 | 28.3.10 | Delete - Event notification (22.127 CR 0088 S1-071762) | 277d? | 2007-12-05 A | 2008-12-25 A | 100% |  | 2007-12-05 | 2008-12-25 | 277d? |  | finish no earlier than 2008-12-25 | C5 | 2216h | 2216h | OSA8 | Telecom Italia | vincenzo.amorino@telecomitalia.it | Rel-8 | Adrian | PXWS Framework |  | CP-40 |
| 171 | 28.3.11 | Delete - Access policy (22.127 CR 0089 S1-071763) | 277d? | 2007-12-05 A | 2008-12-25 A | 100% |  | 2007-12-05 | 2008-12-25 | 277d? |  | finish no earlier than 2008-12-25 | C5 | 2216h | 2216h | OSA8 | Telecom Italia | vincenzo.amorino@telecomitalia.it | Rel-8 | Adrian | PXWS Framework |  | CP-40 |
| 172 | 28.3.12 | Delete - API usage accounting (22.127 CR 0090 S1-071792) | 277d? | 2007-12-05 A | 2008-12-25 A | 100% |  | 2007-12-05 | 2008-12-25 | 277d? |  | finish no earlier than 2008-12-25 | C5 | 2216h | 2216h | OSA8 | Telecom Italia | vincenzo.amorino@telecomitalia.it | Rel-8 | Adrian | PXWS Framework |  | CP-40 |
| 173 | 28.3.13 | Presence alignment with OMA and IETF (22.127 CR 0092 S1-071764) | 128d? | 2007-12-05 A | 2008-05-30 A | 100% |  | 2007-12-05 | 2008-05-30 | 128d? |  | finish no earlier than 2008-05-30 | C5 | 1024h | 1024h | OSA8 | Ericsson | catherine.mulligan@ericsson.com | Rel-8 | Adrian | 29.199-14/13 |  |  |
| 174 | 28.3.14 | Delete - Service identification (22.127 CR 0095 S1-071837) | 128d? | 2007-12-05 A | 2008-05-30 A | 100% |  | 2007-12-05 | 2008-05-30 | 128d? |  | finish no earlier than 2008-05-30 | C5 | 1024h | 1024h | OSA8 | Ericsson | catherine.mulligan@ericsson.com | Rel-8 | Adrian | existing 29.199-xy |  | CP-40 |
| 175 | 28.3.15 | Framework Enterprise Operator (Service Subscription function) | 102d? | 2008-01-10 A | 2008-05-30 A | 100% |  | 2008-01-10 | 2008-05-30 | 102d? |  | finish no earlier than 2008-05-30 | C5 | 816h | 816h | OSA8 | AePONA | Alan.Taylor@aepona.com | Rel-8 | Adrian | 29.198-03 |  |  |
| 176 | 28.3.16 | Mobility Emergency Location | 102d? | 2008-01-10 A | 2008-05-30 A | 100% |  | 2008-01-10 | 2008-05-30 | 102d? |  | finish no earlier than 2008-05-30 | C5 | 816h | 816h | OSA8 | AePONA | Alan.Taylor@aepona.com | Rel-8 | Adrian | 29.198-06 |  |  |
| 177 | 28.3.17 | Connectivity Manager SCF | 102d? | 2008-01-10 A | 2008-05-30 A | 100% |  | 2008-01-10 | 2008-05-30 | 102d? |  |  | C5 | 816h | 816h | OSA8 | AePONA | Alan.Taylor@aepona.com | Rel-8 | Adrian | 29.198-10 |  |  |
| 178 | 28.3.18 | PAM Presence Agent | 102d? | 2008-01-10 A | 2008-05-30 A | 100% |  | 2008-01-10 | 2008-05-30 | 102d? |  | finish no earlier than 2008-05-30 | C5 | 816h | 816h | OSA8 | AePONA | Alan.Taylor@aepona.com | Rel-8 | Adrian | 29.198-14 |  |  |

Notes:
- 154: One CR at SA #35
- 155: SA#35 completed
- 156: SP#37 WID approved
- 161: CT#40: Work moved to OMA
- 166: SA#38 SP-070853 R8 CRs 22.127 OSA Stage 1. CT#40: Work moved to OMA
- 167: SA#38 SP-070853 R8 CRs 22.127 OSA Stage 1. CT#40: Work moved to OMA
- 168: SA#38 SP-070853 R8 CRs 22.127 OSA Stage 1. CT#40: Work moved to OMA
- 169: SA#38 SP-070853 R8 CRs 22.127 OSA Stage 1. CT#40: Work moved to OMA
- 170: SA#38 SP-070853 R8 CRs 22.127 OSA Stage 1. CT#40: Work moved to OMA
- 171: SA#38 SP-070853 R8 CRs 22.127 OSA Stage 1. CT#40: Work moved to OMA
- 172: SA#38 SP-070853 R8 CRs 22.127 OSA Stage 1. CT#40: Work moved to OMA
- 173: SA#38 SP-070853 R8 CRs 22.127 OSA Stage 1
- 174: SA#38 SP-070853 R8 CRs 22.127 OSA Stage 1. CT#40: Work moved to OMA
- 175: SA#39: Stage 1 CR on ETSI TISPAN OSA transfer to CT5
- 176: SA#39: Stage 1 CR on ETSI TISPAN OSA transfer to CT5
- 177: SA#39: Stage 1 CR on ETSI TISPAN OSA transfer to CT5
- 178: SA#39: Stage 1 CR on ETSI TISPAN OSA transfer to CT5

| ID | WBS | Task | Duration | Start | Finish | Complete | Remaining | Baseline start | Baseline finish | Baseline duration | Total slack | Constraint | Resources | Work | Actual work | Text1 | Text4 | Text6 | Text8 | Text3 | Text5 |
| --- | --- | --- | --- | --- | --- | --- | --- | --- | --- | --- | --- | --- | --- | --- | --- | --- | --- | --- | --- | --- | --- |
| 179 | 29 | **Paging Permission with Access Control (PPACR)** | 264d? | 2007-06-12 A | 2008-06-14 | 41% | 154.65d? | 2007-06-12 | 2008-06-14 | 264d? | 400d |  | S1,C1 | 3888h | 1287.6h | PPACR | NTT DoCoMo | Rel-8 | Alain |  |  |
| 180 | 29.1 | Stage 1 for PPACR | 69d? | 2007-06-12 A | 2007-09-14 A | 100% |  | 2007-06-12 | 2007-09-14 | 69d? |  | finish no earlier than 2007-09-14 | S1 | 552h | 552h | PPACR-S1 | NTT DoCoMo | Rel-8 | Alain | 22.011 |  |
| 181 | 29.2 | Stage 3 for PPACR (CT1) | 153d? | 2007-11-14 A | 2008-06-14 | 15% | 130.05d? | 2007-11-14 | 2008-06-14 | 153d? | 400d | finish no earlier than 2008-06-14 | C1 | 1224h | 183.6h | PPACR-CT1 | NTT DoCoMo | Rel-8 | Andrijana | 24.008,23.122 |  |
| 182 | 30 | **IMS Centralized Service Control (ICSRA)** | 266d? | 2007-09-03 A | 2008-09-08 | 65% | 92.86d? | 2007-09-03 | 2008-09-08 | 266d? | 339d |  | S1,S2 | 4768h | 2822.4h | ICSRA | AT&T | Rel-8 | Alain |  | Randy Wohlert |
| 183 | 30.1 | Stage 1 for ICSRA | 138d? | 2007-09-03 A | 2008-03-12 A | 100% |  | 2007-09-03 | 2008-03-12 | 138d? |  | finish no earlier than 2007-12-14 | S1 | 1104h | 1104h | ICSRA-St1 | AT&T | Rel-8 | Alain | 22.101 | Randy Wohlert |
| 184 | 30.2 | Stage 2 for ICSRA | 192d? | 2007-12-14 A | 2008-09-08 | 40% | 115.2d? | 2007-12-14 | 2008-09-08 | 192d? | 339d | start no earlier than 2007-12-14 | S2 | 1536h | 614.4h | ICSRA-St2 | ALU | Rel-8 | Maurice | 23.206(Impacttobedetermined) |  |
| 185 | 31 | Value Added Services for Short Message Service | 133d? | 2007-09-10 A | 2008-03-12 A | 100% |  | 2007-09-10 | 2008-03-12 | 133d? |  | finish no earlier than 2008-03-21 | S1 | 1064h | 1064h | VAS4SMS | China Mobile | Rel-8 | Alain | 22.142,22.942 | wubin@chinamobile.com |
| 186 | 32 | **Earthquake and Tsunami Warning System** | 261d? | 2007-09-10 A | 2008-09-08 | 72% | 73.41d? | 2007-09-10 | 2008-09-08 | 261d? | 339d |  | S1,S2 | 4520h | 2812h | ETWS | NTT DoCoMo | Rel-8 | Alain |  | kitaharar@nttdocomo.co.jp |
| 187 | 32.1 | Stage 1 for ETWS | 133d? | 2007-09-10 A | 2008-03-12 A | 100% |  | 2007-09-10 | 2008-03-12 | 133d? |  | finish no earlier than 2008-03-12 | S1 | 1064h | 1064h | ETWS-S1 | NTT DoCoMo | Rel-8 | Alain | 22.168 | kitaharar@nttdocomo.co.jp |
| 188 | 32.2 | Stage 2 for ETWS | 171d? | 2008-01-14 A | 2008-09-08 | 50% | 85.5d? | 2008-01-14 | 2008-09-08 | 171d? | 339d | finish no earlier than 2008-09-08 | S2 | 1368h | 684h | ETWS-S2 | NTT DoCoMo | Rel-8 | Maurice | 23.828 | tanakai@nttdocomo.co.jp |
| 189 | 33 | Storage and easy access of In Case of Emergency numbers on USIM | 70d? | 2007-12-06 A | 2008-03-12 A | 100% |  | 2007-12-06 | 2008-03-12 | 70d? |  | finish no earlier than 2008-03-12 | S1 | 560h | 560h | ICE | Telecom Italia | Rel-8 | Alain | 22.030,22.101 |  |
| 190 | 34 | **IP Interconnection of Services** | 70d? | 2007-12-06 A | 2008-03-12 A | 100% |  | 2007-12-06 | 2008-03-12 | 70d? |  |  | S1 | 1120h | 1120h | IPinterc | Telefonica O2 | Rel-8 | Alain | 22.101,22.228 | chris.friel@O2.com |
| 191 | 34.1 | Stage 1 for Ipinterc | 70d? | 2007-12-06 A | 2008-03-12 A | 100% |  | 2007-12-06 | 2008-03-12 | 70d? |  | start no earlier than 2007-12-06 | S1 | 560h | 560h | IPinterc | Telefonica O2 | Rel-8 | Alain | 22.101,22.228 | chris.friel@O2.com |
| 192 | 35 | Network Selection for non-3GPP Access | 136d? | 2007-12-06 | 2008-06-12 |  |  | 2007-12-06 | 2008-06-12 | 136d? | 401d | finish no earlier than 2008-06-12 | S1 | 1088h |  | N3GTONSP | Telecom Italia | Rel-8 | Alain |  |  |
| 193 | 36 | **Charging for multi-phases services** | 70d? | 2007-12-06 A | 2008-03-12 A | 100% |  | 2007-12-06 | 2008-03-12 | 70d? |  |  | S1 | 1120h | 1120h | CHRGMPH | Telecom Italia | Rel-8 | Alain |  | Marco.DeLuca1@telecomitalia.it |
| 194 | 36.1 | Stage 1 for CHRGMPH | 70d? | 2007-12-06 A | 2008-03-12 A | 100% |  | 2007-12-06 | 2008-03-12 | 70d? |  | start no earlier than 2007-12-06 | S1 | 560h | 560h | CHRGMPH-s1 | Telecom Italia | Rel-8 | Alain | 22.115 | Marco.DeLuca1@telecomitalia.it |
| 195 | 37 | **Home NodeB / eNodeB** | 70d? | 2007-12-06 A | 2008-03-12 A | 100% |  | 2007-12-06 | 2008-03-12 | 70d? |  |  | S1 | 1120h | 1120h | HomeNB | Telecom Italia | Rel-8 | Alain |  |  |
| 196 | 37.1 | Stage 1 for HNB_eHNB | 70d? | 2007-12-06 A | 2008-03-12 A | 100% |  | 2007-12-06 | 2008-03-12 | 70d? |  | start no earlier than 2007-12-06 | S1 | 560h | 560h | HomeNB-S1 | Telecom Italia | Rel-8 | Alain | 22.011,22.115 |  |
| 197 | 38 | **3GPP2 Input to Common IMS** | 200d? | 2008-03-07 A | 2008-12-11 | 5% | 189.63d? | 2008-03-07 | 2008-12-11 | 200d? | 271d |  | S1,S2,S3,C1,C3,C4 | 9317.2h | 400h | CIMS_3GPP2 | Nortel | Rel-8 | Alain |  | Amar Deol |
| 198 | 38.1 | Stage 1 CIMS_3GPP2 (SA1) | 35.65d? | 2008-03-12 | 2008-06-12 |  |  | 2008-03-12 | 2008-06-12 | 35.65d? | 401d | finish no earlier than 2008-06-12 | S1 | 285.2h |  | CIMS_3GPP2 | Nortel | Rel-8 | Alain | 22.228,22.173,22.101,22.153 | Amar Deol |
| 199 | 38.2 | Stage 2 CIMS_3GPP2 (SA2) | 132d? | 2008-03-12 | 2008-09-11 |  |  | 2008-03-12 | 2008-09-11 | 132d? | 336d | finish no earlier than 2008-09-11 | S2 | 1056h |  | IMS_Common | NSN | Rel-8 | Maurice |  |  |
| 200 | 38.3 | Security CIMS_3GPP2 (SA3) | 197d? | 2008-03-12 | 2008-12-11 |  |  | 2008-03-12 | 2008-12-11 | 197d? | 271d | finish no earlier than 2008-12-11 | S3 | 1576h |  | IMS_Common | NSN | Rel-8 | Dionisio |  |  |
| 201 | 38.4 | Stage 3 CIMS_3GPP2 (CT1) | 200d? | 2008-03-07 A | 2008-12-11 | 25% | 150d? | 2008-03-07 | 2008-12-11 | 200d? | 271d | finish no earlier than 2008-12-11 | C1 | 1600h | 400h | REDOC_3GPP2 | ALU | Rel-8 | Andrijana |  | orsic@alcatel-lucent.com |
| 202 | 38.5 | Stage 3 CIMS_3GPP2 (CT3) | 200d? | 2008-03-07 | 2008-12-11 |  |  | 2008-03-07 | 2008-12-11 | 200d? | 271d | finish no earlier than 2008-12-11 | C3 | 1600h |  | REDOC_3GPP2 | ALU | Rel-8 | Gwiho |  | orsic@alcatel-lucent.com |
| 203 | 38.6 | Stage 3 CIMS_3GPP2 (CT4) | 200d? | 2008-03-07 | 2008-12-11 |  |  | 2008-03-07 | 2008-12-11 | 200d? | 271d | finish no earlier than 2008-12-11 | C4 | 1600h |  | REDOC_3GPP2 | ALU | Rel-8 | Kimmo |  | Milo Orsic, Alcatel-Lucent |

Notes:
- 179: Forgotten after SA#36
- 180: Forgotten after SA#36
- 181: CT1-50: C1-072820
- 183: SA#39 completed
- 184: SA#38 WID approved
- 185: Check SA4 related activity. SA#39 completed
- 187: Check SA4 related activity. SA#39 completed
- 188: SA#38 WID approved
- 189: Check SA4 related activity. SA#39 completed
- 190: Inform GSMA of progress
- 191: SA#39 completed
- 192: SA#39 exception granted to Jun 2008
- 193: Check SA4 related activity. SA#39 completed
- 194: SA#39 completed
- 196: Check SA4 related activity. SA#39 completed
- 197: SA#39 WID approved & exception granted to Jun 2008
- 198: SA#39 WID approved. Target exceptions: IP Service Architecture,IP Multimedia Domain,End-to-End QoS,All-IP Emergency Call Support Stage 1,Multi-Media Priority Stage 1,MMD Policy Enhancements,Enhanced MMD Security. SA2 approved CR with CIMS_3GPP2
- 199: SA#39 WID approved.
- 200: SA#39 WID approved
- 201: CT#39 WID approved. CT1 approved CRs with REDOC_3GPP2
- 202: CT#39 WID approved
- 203: CT#39 WID approved

| ID | WBS | Task | Type | Duration | Start | Finish | Complete | Remaining | Baseline start | Baseline finish | Baseline duration | Total slack | Constraint | Resources | Work | Actual work | Text1 | Text4 | Text6 | Text8 | Text3 | Text5 | Text12 |
| --- | --- | --- | --- | --- | --- | --- | --- | --- | --- | --- | --- | --- | --- | --- | --- | --- | --- | --- | --- | --- | --- | --- | --- |
| 204 | 39 | **System enhancements for interconnection interfaces between two IMSs** |  | 548d? | 2006-08-16 A | 2008-09-19 | 77% | 124.58d? | 2006-08-16 | 2008-09-19 | 548d? | 330d |  | S2,S5,C3 | 9784h | 4828.4h | IMS_NNI | Orange | Rel-8 | Maurice |  |  |  |
| 205 | 39.1 | Stage 2 for IMS_NNI |  | 131d? | 2007-06-22 A | 2007-12-21 A | 100% |  | 2007-06-22 | 2007-12-21 | 131d? |  | finish no earlier than 2007-12-21 | S2 | 1048h | 1048h | IMS_NNI | Orange | Rel-8 | Maurice |  |  |  |
| 206 | 39.2 | IMS inter-operator service interconnection interface |  | 341d? | 2007-06-01 A | 2008-09-19 | 55% | 153.45d? | 2007-06-01 | 2008-09-19 | 341d? | 330d | finish no earlier than 2008-09-19 | C3 | 2728h | 1500.4h | FBI2-IOPSI | Telecom Italia | Rel-8 | Gwiho | 29.865 | mauro.ficaccio@telecomitalia.it |  |
| 207 | 39.3 | Charging harmonization for NGN between 3GPP and ATIS-TMOC |  | 51d? | 2006-09-28 A | 2006-12-07 A | 100% |  | 2006-09-28 | 2006-12-07 | 51d? |  | finish no earlier than 2006-12-07 | S5 | 408h | 408h | FBI2-TISP2-CH | Amdocs | Rel-8 | Dionisio | 32.297 |  |  |
| 208 | 39.4 | Deleted - Protocol impact of FBI for TISPAN R2 |  | 152d? | 2006-08-16 A | 2007-03-15 A | 100% |  | 2006-08-16 | 2007-03-15 | 152d? |  | finish no earlier than 2007-03-15 | C1 | 1216h | 1216h | FBI2-TISP2-c1 | Ericsson | Rel-8 | Andrijana |  |  | SP-38 |
| 209 | 39.5 | Deleted (never approved) - Stage 2 of FBI for TISPAN R2 - Rel 8 | milestone | 0d? | 2007-11-30 A | 2007-11-30 A | 100% |  | 2007-11-30 | 2007-11-30 | 0d? |  | finish no earlier than 2007-11-30 | S2 |  |  | FBI2-TISP2-s2 | NSN | Rel-8 | Maurice |  |  | SP-36 |
| 210 | 40 | **IMS System enhancements for corporate network access** |  | 326d? | 2007-06-22 A | 2008-09-19 | 13% | 282.79d? | 2007-06-22 | 2008-09-19 | 326d? | 330d |  | S1,S2,C1,C4 | 7052.8h | 934.91h | IMS_Corp | Orange | Rel-8 | Maurice |  | Delphin Barankanira |  |
| 211 | 40.1 | SA1 aspects of IMS System enhancements for corporate network access |  | 23.6d? | 2008-03-12 A | 2008-06-05 |  | 23.6d? | 2008-03-12 | 2008-06-05 | 23.6d? | 406d | finish no earlier than 2008-06-05 | S1 | 188.8h |  | IMS_Corp | Telecom Italia | Rel-8 | Alain |  |  |  |
| 212 | 40.2 | SA2 aspects of IMS System enhancements for corporate network access |  | 250d? | 2007-06-22 A | 2008-06-05 | 15% | 211.6d? | 2007-06-22 | 2008-06-05 | 250d? | 406d | finish no earlier than 2008-06-05 | S2 | 2000h | 307.2h | IMS_Corp | Orange | Rel-8 | Maurice | 23.228 | Delphin Barankanira |  |
| 213 | 40.3 | CT1 aspects of IMS protocol enhancements for corporate network access |  | 141d? | 2008-03-07 A | 2008-09-19 | 25% | 105.75d? | 2008-03-07 | 2008-09-19 | 141d? | 330d | finish no earlier than 2008-09-19 | C1 | 1128h | 282h | IMS_Corp | ALU | Rel-8 | Andrijana | 24.229 | drage@alcatel-lucent.com |  |
| 214 | 40.4 | CT4 aspects of IMS protocol enhancements for corporate network access |  | 141d? | 2008-02-26 | 2008-09-19 |  |  | 2008-02-26 | 2008-09-19 | 141d? | 330d | finish no earlier than 2008-09-19 | C4 | 1128h |  | IMS_Corp | ALU | Rel-8 | Kimmo | 29.228,29.229,23.003,23.008 |  |  |
| 215 | 41 | **IMS Enhancements for support of Packet Cable access** |  | 393d? | 2006-12-06 A | 2008-06-06 | 98% | 9.12d? | 2006-12-06 | 2008-06-06 | 393d? | 405d |  | S2,S3,C1,C3,C4 | 27656h | 23790h | PktCbl | NSN | Rel-8 | Maurice |  |  |  |
| 216 | 41.1 | **IMS Enhancements for Cable Client Types and Deployment Models** |  | 345d? | 2007-02-05 A | 2008-05-30 A | 100% |  | 2007-02-05 | 2008-05-30 | 345d? |  |  | S2,C1 | 6968h | 6968h | PktCbl-Deploy |  | Rel-8 | Maurice |  |  |  |
| 217 | 41.1.1 | Architecture aspects of PktCbl-Deploy |  | 216d? | 2007-02-05 A | 2007-12-03 A | 100% |  | 2007-02-05 | 2007-12-03 | 216d? |  | finish no earlier than 2007-12-03 | S2 | 1728h | 1728h | PktCbl-Deploy |  | Rel-8 | Maurice |  |  |  |
| 218 | 41.1.2 | CT1 aspects of PktCbl-Deploy |  | 310d? | 2007-03-26 A | 2008-05-30 A | 100% |  | 2007-03-26 | 2008-05-30 | 310d? |  | finish no earlier than 2008-06-15 | C1 | 2480h | 2480h | PktCbl-Deploy | Cablelabs | Rel-8 | Andrijana |  | D.Hancock@ CableLabs.com |  |
| 219 | 41.2 | **IMS Inter-working aspects in Support of Cable Regulatory requirements** |  | 290d? | 2007-02-05 A | 2008-03-15 A | 100% |  | 2007-02-05 | 2008-03-15 | 290d? |  |  | S2,C1,C3 | 5640h | 5640h | PktCbl-Intw | Cablelabs | Rel-8 | Maurice | 23.228 | B.McKibben@CableLabs.com |  |
| 220 | 41.2.1 | Architecture PktCbl-Interwork |  | 160d? | 2007-02-05 A | 2007-09-14 A | 100% |  | 2007-02-05 | 2007-09-14 | 160d? |  | start no earlier than 2007-02-05 | S2 | 1280h | 1280h | PktCbl-Intw | Cablelabs | Rel-8 | Maurice | 23.228 | B.McKibben@CableLabs.com |  |
| 221 | 41.2.2 | CT1,CT3 PktCbl-Interwork |  | 255d? | 2007-03-26 A | 2008-03-15 A | 100% |  | 2007-03-26 | 2008-03-15 | 255d? |  | finish no earlier than 2008-03-15 | C1,C3 | 2040h | 2040h | PktCbl-Intw | Cablelabs | Rel-8 | Andrijana | 24.229 | D.Hancock@ CableLabs.com |  |
| 222 | 41.3 | **IMS Enhancements for Security Requirements in Support of Cable Deployments** |  | 393d? | 2006-12-06 A | 2008-06-06 | 96% | 16.96d? | 2006-12-06 | 2008-06-06 | 393d? | 405d |  | S3,C1,C3,C4 | 11904h | 10558h | PktCbl-Sec | Cablelabs | Rel-8 | Dioniso |  | s.dotson@cablelabs.com |  |
| 223 | 41.3.1 | S3 Aspects of PktCbl-Sec |  | 331d? | 2006-12-06 A | 2008-03-12 A | 100% |  | 2006-12-06 | 2008-03-12 | 331d? |  | finish no earlier than 2007-12-20 | S3 | 2648h | 2648h | PktCbl-Sec | Cablelabs | Rel-8 | Dioniso | 33.203,33.210,33.220,24.229 | s.dotson@cablelabs.com |  |
| 224 | 41.3.2 | CT1 Aspects of PktCbl-Sec |  | 315d? | 2007-03-26 A | 2008-06-06 | 85% | 47.25d? | 2007-03-26 | 2008-06-06 | 315d? | 405d | finish no earlier than 2008-06-06 | C1 | 2520h | 2142h | PktCbl-Sec | Cablelabs | Rel-8 | Andrijana | 24.229,24.109 | D.Hancock@ CableLabs.com |  |
| 225 | 41.3.3 | CT3 Aspects of PktCbl-Sec |  | 194d? | 2007-03-26 A | 2007-12-20 A | 100% |  | 2007-03-26 | 2007-12-20 | 194d? |  | finish no earlier than 2008-03-15 | C3 | 1552h | 1552h | PktCbl-Intw | Cablelabs | Rel-8 | Gwiho | 24.229,24.109 | D.Hancock@ CableLabs.com |  |
| 226 | 41.3.4 | CT4 Aspects of PktCbl-Sec |  | 255d? | 2007-03-26 A | 2008-03-14 A | 100% |  | 2007-03-26 | 2008-03-14 | 255d? |  | finish no earlier than 2008-03-14 | C4 | 2040h | 2040h | PktCbl-Sec | Cablelabs | Rel-8 | Kimmo | 29.228,29.229,23.008, | D.Hancock@ CableLabs.com |  |
| 227 | 42 | **Mobility between 3GPP-WLAN Interworking and 3GPP Systems** |  | 257d? | 2007-09-14 A | 2008-09-08 | 55% | 115.65d? | 2007-09-14 | 2008-09-08 | 257d? | 339d |  | S2 | 4112h | 2261.6h | IWLAN_Mob | Orange | Rel-8 | Maurice |  | xiaobao.chen@orange-ftgroup.com |  |
| 228 | 42.1 | Stage 2: I-WLAN Mobility |  | 257d? | 2007-09-14 A | 2008-09-08 | 55% | 115.65d? | 2007-09-14 | 2008-09-08 | 257d? | 339d | finish no earlier than 2008-09-08 | S2 | 2056h | 1130.8h | IWLAN_Mob | Orange | Rel-8 | Maurice | 23.234 | xiaobao.chen@orange-ftgroup.com |  |
| 229 | 43 | Harmonization of Gq'/Rx for Common IMS |  | 171d? | 2008-01-14 A | 2008-09-08 | 20% | 136.8d? | 2008-01-14 | 2008-09-08 | 171d? | 339d | finish no earlier than 2008-09-08 | S2 | 1368h | 273.6h | IMS_Comm_GqRx_Harm | Alcatel-Lucent | Rel-8 | Maurice | 23.8xx,23203 | geoffrey.cristallo@alcatel-lucent.be |  |

Notes:
- 204: Name changed from "System enhancements for TISPAN Rel2" at SA36
- 206: CP-36: WI approved. C3-36: draft 29.865 advanced.
- 207: SA#33 WID approved
- 208: SA#38 stopped
- 209: SA#36 stopped
- 211: SA#39 AI: SA1 to check Stage 1
- 218: Supporting Companies:
- 219: Supporting Companies: CableLabs, Nortel, Cisco, Samsung, Alcatel-Lucent, Siemens, Motorola, Hewlett-Packard, Ericsson
- 220: Supporting Companies: CableLabs, Nortel, Cisco, Samsung, Alcatel-Lucent, Siemens, Motorola, Hewlett-Packard, Ericsson
- 221: Supporting Companies:
- 223: SA#39 completed
- 224: Supporting Companies:
- 225: Added as 100% complete at CT#38
- 226: Supporting Companies:
- 227: Name changed before SA#38 (was "Mobility between 3GPP-WLAN Interworking and 3GPP Systems")
- 229: WID approved SA#38. per OPs & ETSI GA 39. This is a joint effort of SA WG2 and TISPAN WG2

| ID | WBS | Task | Duration | Start | Finish | Complete | Remaining | Baseline start | Baseline finish | Baseline duration | Total slack | Constraint | Resources | Work | Actual work | Text1 | Text4 | Text6 | Text8 | Text3 | Text7 |
| --- | --- | --- | --- | --- | --- | --- | --- | --- | --- | --- | --- | --- | --- | --- | --- | --- | --- | --- | --- | --- | --- |
| 230 | 44 | **IMS Service Continuity** | 129d? | 2008-03-12 | 2008-09-08 |  |  | 2008-03-12 | 2008-09-08 | 129d? | 339d |  | S1,S2 | 3096h |  | IMS-Cont | LG Electronics | Rel-8 | Maurice |  |  |
| 231 | 44.1 | Stage 1 IMS Service Continuity | 129d? | 2008-03-12 | 2008-09-08 |  |  | 2008-03-12 | 2008-09-08 | 129d? | 339d | start no earlier than 2008-03-12 | S1 | 1032h |  | IMS-Cont | Telecom Italia | Rel-8 | Alain |  |  |
| 232 | 44.2 | Stage 2 IMS Service Continuity | 129d? | 2008-03-12 | 2008-09-08 |  |  | 2008-03-12 | 2008-09-08 | 129d? | 339d | start no earlier than 2008-03-12 | S2 | 1032h |  | IMS-Cont | NSN | Rel-8 | Maurice | 23.xyz,23.292 |  |
| 233 | 45 | Access Security Enhancements | 152d? | 2007-07-02 A | 2008-01-29 | 75% | 38d? | 2007-07-02 | 2008-01-29 | 152d? | 498d | start no earlier than 2007-07-01 | S3 | 1216h | 912h | ACCSEC2 | Ericsson | Rel-8 | Dioniso | 33.102,43.020 | TSG |
| 234 | 46 | Lawful Interception in the 3GPP Rel-8 | 265d? | 2007-03-12 A | 2008-03-14 | 25% | 198.75d? | 2007-03-12 | 2008-03-14 | 265d? | 465d | finish no earlier than 2008-03-14 | S3 | 2120h | 530h | LI8 | BMWi | Rel-8 | Dioniso | 33.106,33.107,33.108 |  |
| 235 | 47 | **Security Enhancements for IMS** | 476d? | 2007-03-01 A | 2008-12-25 | 46% | 258.83d? | 2007-03-01 | 2008-12-25 | 476d? | 261d |  | S3,C1,C4 | 12240h | 4406.94h | IMS-Sec | Ericsson | Rel-8 | Dioniso |  |  |
| 236 | 47.1 | SA3 aspects of IMSSec | 476d? | 2007-03-01 A | 2008-12-25 | 60% | 190.4d? | 2007-03-01 | 2008-12-25 | 476d? | 261d | finish no earlier than 2008-12-25 | S3 | 3808h | 2284.8h | IMS-Sec | Ericsson | Rel-8 | Dioniso | 33.978,33.178,33.203,33.828,33.803 |  |
| 237 | 47.2 | CT1 aspects of IMSSec | 207d? | 2007-06-07 | 2008-03-21 |  |  | 2007-06-07 | 2008-03-21 | 207d? | 460d | finish no earlier than 2008-03-21 | S3 | 1656h |  | IMS-Sec | Ericsson | Rel-8 | Andrijana |  |  |
| 238 | 47.3 | CT1 part of NASS Bundled Authentication | 218d? | 2007-11-14 A | 2008-09-12 | 40% | 130.8d? | 2007-11-14 | 2008-09-12 | 218d? | 335d | start no earlier than 2007-11-14 | C1 | 1744h | 697.6h | NBA | ALU | Rel-8 | Andrijana | 24.229 |  |
| 239 | 47.4 | CT4 part of NASS Bundled Authentication | 153d? | 2007-11-14 A | 2008-06-13 | 71% | 44.93d? | 2007-11-14 | 2008-06-13 | 153d? | 400d | start no earlier than 2007-11-14 | C4 | 1224h | 864.53h | NBA-C4 | ALU | Rel-8 | Kimmo | 29.229,29.228,23.008 |  |
| 240 | 48 | Generic Bootstrapping Architecture Push Function | 132d? | 2008-03-12 A | 2008-09-11 | 40% | 79.2d? | 2008-03-12 | 2008-09-11 | 132d? | 336d | finish no earlier than 2008-03-21 | S3 | 1056h | 422.4h | GBAPush | Ericsson | Rel-8 | Dioniso | 33.223,33.224,29.109,24.109 |  |
| 241 | 49 | MTSI Video - Dynamic Rate Adaptation/Signalling of Image Size | 206d? | 2007-12-06 A | 2008-09-18 | 20% | 164.8d? | 2007-12-06 | 2008-09-18 | 206d? | 331d | finish no earlier than 2008-09-18 | S4 | 1648h | 329.6h | MTSIV_DRASIS | Qualcomm, Samsung | Rel-8 | Paolo | 26.114 |  |
| 242 | 50 | eCall data transfer Phase 2: Comparison of alternative in-band modem solutions and standardization of one in-band modem solution | 391d? | 2007-12-06 A | 2009-06-04 | 50% | 195.5d? | 2007-12-06 | 2009-06-04 | 391d? | 146d | finish no earlier than 2009-06-04 | S4 | 3128h | 1564h | eCall_Phase2 | Airbiquity | Rel-8 | Paolo | 26.xxx,26.9xx |  |
| 243 | 51 | Requirements and Test methods for Wideband Terminals | 197d? | 2008-03-12 A | 2008-12-11 | 5% | 187.15d? | 2008-03-12 | 2008-12-11 | 197d? | 271d | start no earlier than 2008-03-12 | S4 | 1576h | 78.8h | RETEM_WB_T | FT, Ericsson | Rel-8 | Paolo | 26.131,26.132 |  |
| 244 | 52 | Extending PSS and MBMS User Services for optimized Mobile TV | 266d? | 2007-12-06 A | 2008-12-11 | 15% | 226.1d? | 2007-12-06 | 2008-12-11 | 266d? | 271d | finish no earlier than 2008-12-11 | S4 | 2128h | 319.2h | PSS_MBMS_OMTV | Ericsson | Rel-8 | Paolo | 26.234,26.346,26.946 |  |
| 245 | 53 | **IMS initiated and controlled PSS and MBMS User Service** | 132d? | 2008-06-11 A | 2008-12-11 | 5% | 125.4d? | 2008-06-11 | 2008-12-11 | 132d? | 271d |  | S4,S3 | 3168h | 158.4h | IMS_PSS_MBMS_US | FT, Ericsson | Rel-8 | Paolo |  |  |
| 246 | 53.1 | SA3 IMS initiated and controlled PSS and MBMS User Service | 132d? | 2008-06-11 | 2008-12-11 |  |  | 2008-06-11 | 2008-12-11 | 132d? | 271d | finish no earlier than 2008-12-11 | S3 | 1056h |  | IMS_PSS_MBMS_US | FT, Ericsson | Rel-8 | Dioniso | 26.xyz,26.234,26.346 |  |
| 247 | 53.2 | SA4 IMS initiated and controlled PSS and MBMS User Service | 132d? | 2008-06-11 A | 2008-12-11 | 10% | 118.8d? | 2008-06-11 | 2008-12-11 | 132d? | 271d | finish no earlier than 2008-12-11 | S4 | 1056h | 105.6h | IMS_PSS_MBMS_US | FT, Ericsson | Rel-8 | Paolo | 33.246 |  |
| 248 | 54 | **OAM&P 8** | 402d? | 2007-06-07 A | 2008-12-19 | 71% | 117.21d? | 2007-06-07 | 2008-12-19 | 402d? | 265d |  | S5,C1 | 35225.6h | 21615.6h | OAM8 | Huawei | Rel-8 | Dionisio |  |  |
| 249 | 54.1 | **Network Infrastructure Management 8** | 396d? | 2007-06-07 A | 2008-12-11 | 70% | 118.47d? | 2007-06-07 | 2008-12-11 | 396d? | 271d |  | S5 | 14864h | 9472.33h | OAM8-NIM | Huawei | Rel-8 | Dionisio |  |  |
| 250 | 54.1.1 | Telecom Management Methodology | 396d? | 2007-06-07 A | 2008-12-11 | 70% | 118.8d? | 2007-06-07 | 2008-12-11 | 396d? | 271d | finish no earlier than 2008-12-11 | S5 | 3168h | 2217.6h | OAM8 | Ericsson | Rel-8 | Dionisio | 32.155,32.153 |  |
| 251 | 54.1.2 | Advanced Alarming on Itf-N (Study + Implementation) | 266d? | 2007-06-07 A | 2008-06-12 A | 100% |  | 2007-06-07 | 2008-06-12 | 266d? |  | finish no earlier than 2008-12-11 | S5 | 2128h | 2128h | OAM8 | NSN | Rel-8 | Dionisio | 32.121/2/3 |  |
| 252 | 54.1.3 | CN CS Bearer Transport Network (BTN) relative NRM | 266d? | 2007-06-07 A | 2008-06-12 A | 100% |  | 2007-06-07 | 2008-06-12 | 266d? |  | finish no earlier than 2008-12-11 | S5 | 2128h | 2128h | OAM8 | China Mobile | Rel-8 | Dionisio | 32.632/3/5 |  |
| 253 | 54.1.4 | End point modelling for reference point | 324d? | 2007-09-17 A | 2008-12-11 | 60% | 129.6d? | 2007-09-17 | 2008-12-11 | 324d? | 271d | finish no earlier than 2008-12-11 | S5 | 2592h | 1555.2h | OAM8 | Motorola | Rel-8 | Dionisio | 32.152,32.62/3/4x,32.73x |  |
| 254 | 54.1.5 | Alignment with eTOM and M.3060 architectural concepts | 210d? | 2008-02-22 A | 2008-12-11 | 10% | 189d? | 2008-02-22 | 2008-12-11 | 210d? | 271d | start no earlier than 2008-02-22 | S5 | 1680h | 168h | OAM8 | TeliaSonera | Rel-8 | Dionisio | 32.101/2,32.xyz |  |

Notes:
- 230: SA#39 WID approved / Text5: JaeSeung SONG (anthonys@lge.com)
- 231: SA#39: SA1/SA2 to check new User requirements
- 232: SA#39: SA1/SA2 to check new User requirements
- 233: Moved from Rel-7 to Rel-8 at SA#38 / Text5: Bengt.Sahlin@ericsson.com
- 234: End date to be determined when Rel-8 frozen. / Text5: berthold.wilhelm@bnetza.de
- 235: WID approved at SP-36 / Text5: Bengt Sahlin
- 236: SA#39: SA3 to remove Stage 3 from 33.178-100 for CT1 work / Text5: Bengt Sahlin
- 237: SA#39: SA3 to remove Stage 3 from 33.178-100 for CT1 work
- 238: Text5: drage@alcatel-lucent.com
- 240: SA#39 WID approved / Text5: Rolf Blom
- 241: Text5: nleung@qualcomm.com & kyunghun.jung@samsung.com
- 242: Text5: lhong@airbiquity.com & rrobinson@airbiquity.com
- 243: Text5: stephane.ragot@orange-ftgroup.com, wanqing.shi@sonyericsson.com
- 244: Text5: thorsten.lohmar@ericsson.com
- 245: Text5: olle.franceschi@ericsson.com
- 246: SA#39 WID approved
- 247: Text5: olle.franceschi@ericsson.com
- 254: SA#39 WID Approval

| ID | WBS | Task | Duration | Start | Finish | Complete | Remaining | Baseline start | Baseline finish | Baseline duration | Total slack | Constraint | Resources | Work | Actual work | Text1 | Text4 | Text6 | Text8 | Text3 | Text12 | Text5 |
| --- | --- | --- | --- | --- | --- | --- | --- | --- | --- | --- | --- | --- | --- | --- | --- | --- | --- | --- | --- | --- | --- | --- |
| 255 | 54.2 | **Performance Management 8** | 396d? | 2007-06-07 A | 2008-12-11 | 81% | 75.5d? | 2007-06-07 | 2008-12-11 | 396d? | 271d |  | S5 | 14800h | 11978.4h | OAM8-PM | Huawei | Rel-8 | Dionisio |  |  |  |
| 256 | 54.2.1 | Deleted IP bearer network Performance measurement definitions | 396d? | 2007-06-07 A | 2008-12-11 A | 100% |  | 2007-06-07 | 2008-12-11 | 396d? |  | finish no earlier than 2008-12-11 | S5 | 3168h | 3168h | OAM7-PM | China Mobile | Rel-8 | Dionisio | 32.321/2/3/5 | SP-36 |  |
| 257 | 54.2.2 | IP bearer network Performance measurement definitions | 266d? | 2007-06-07 A | 2008-06-12 A | 100% |  | 2007-06-07 | 2008-06-12 | 266d? |  | finish no earlier than 2008-12-11 | S5 | 2128h | 2128h | OAM8 | China Mobile | Rel-8 | Dionisio | 32.321/2/3/5 |  |  |
| 258 | 54.2.3 | HSUPA performance measurements | 396d? | 2007-06-07 A | 2008-12-11 | 70% | 118.8d? | 2007-06-07 | 2008-12-11 | 396d? | 271d | finish no earlier than 2008-12-11 | S5 | 3168h | 2217.6h | OAM8 | China Mobile | Rel-8 | Dionisio | 32.405 |  |  |
| 259 | 54.2.4 | Key Performance Indicators (KPIs) for UMTS/GERAN | 396d? | 2007-06-07 A | 2008-12-11 | 60% | 158.4d? | 2007-06-07 | 2008-12-11 | 396d? | 271d | finish no earlier than 2008-12-11 | S5 | 3168h | 1900.8h | OAM8 | China Mobile | Rel-8 | Dionisio | 32.xyz |  |  |
| 260 | 54.3 | **Trace Management 8** | 206d? | 2008-03-07 A | 2008-12-19 | 5% | 195.7d? | 2008-03-07 | 2008-12-19 | 206d? | 265d |  | S5,C1 | 3296h | 164.8h | OAM8-Trace | Huawei | Rel-8 | Dionisio |  |  |  |
| 261 | 54.3.1 | Service Level Tracing in IMS | 206d? | 2008-03-07 A | 2008-12-19 | 5% | 195.7d? | 2008-03-07 | 2008-12-19 | 206d? | 265d | start no earlier than 2008-03-07 | C1 | 1648h | 82.4h | OAM8-Trace | Nokia | Rel-8 | Andrijana | 24.229,24.167,29.228,29.229,29.163,29.332 |  | jari.jansson@nokia.com |
| 262 | 55 | **Charging Management small Enhancements** | 716d? | 2006-03-16 A | 2008-12-11 | 71% | 208.48d? | 2006-03-16 | 2008-12-11 | 716d? | 271d |  | S5 | 12056h | 8545.66h | CH8 | Orange | Rel-8 | Dionisio | 32.2xy |  |  |
| 263 | 55.1 | Online charging correlation | 457d? | 2006-03-16 A | 2007-12-14 A | 100% |  | 2006-03-16 | 2007-12-14 | 457d? |  | start no earlier than 2006-03-16 | S5 | 3656h | 3656h | CH8 | Orange | Rel-8 | Dionisio | 32.240,32.296 |  |  |
| 264 | 55.2 | SMS online charging | 137d? | 2007-06-07 A | 2007-12-14 A | 100% |  | 2007-06-07 | 2007-12-14 | 137d? |  | finish no earlier than 2007-12-14 | S5 | 1096h | 1096h | CH8 | Vodafone | Rel-8 | Dionisio | 32.274,32.240/299/298 |  |  |
| 265 | 55.3 | WLAN Offline Charging | 244d? | 2008-01-07 | 2008-12-11 |  |  | 2008-01-07 | 2008-12-11 | 244d? | 271d | finish no earlier than 2008-12-11 | S5 | 1952h |  | CH8 | ALU | Rel-8 | Dionisio | 32.252/298/299 |  |  |
| 266 | 56 | IMS Stage-3 IETF Protocol Alignment | 387d? | 2007-06-22 A | 2008-12-15 | 40% | 232.2d? | 2007-06-22 | 2008-12-15 | 387d? | 269d | finish no earlier than 2008-12-15 | C1 | 3096h | 1238.4h | IMSProtoc2 | ALU | Rel-8 | Andrijana | 23.218,24.229 |  | drage@alcatel-lucent.com |
| 267 | 57 | **IMS Multimedia Telephony and Supplementary Services** | 421d? | 2007-05-02 A | 2008-12-10 | 33% | 282.5d? | 2007-05-02 | 2008-12-10 | 421d? | 272d |  | S1,S5,C1,C3,C4 | 33198.4h | 7765.6h | IMSTSS | Ericsson | Rel-8 | Andrijana |  |  |  |
| 268 | 57.1 | **General aspects of IMS Sup Services** | 270d? | 2007-09-03 A | 2008-09-12 | 58% | 113.81d? | 2007-09-03 | 2008-09-12 | 270d? | 335d |  | S1,C1,C3,C4 | 6712h | 3233.2h | IMSSS-Gal | Telecom Italia | Rel-8 | Alain |  |  |  |
| 269 | 57.1.1 | Service and Capability for Core IMS - inclusion of TISPAN requirements | 75d? | 2007-09-03 A | 2007-12-14 A | 100% |  | 2007-09-03 | 2007-12-14 | 75d? |  | finish no earlier than 2007-12-14 | S1 | 600h | 600h | TISCAPR8, CIMS8-TIS | Ericsson | Rel-8 | Alain | 22.228,22.115,22.101 |  | Susana Sabater |
| 270 | 57.1.2 | Documentation of TISPAN R1 and R2 in CT1 | 143d? | 2007-11-28 A | 2008-06-15 | 75% | 35.75d? | 2007-11-28 | 2008-06-15 | 143d? | 400d | finish no earlier than 2008-06-15 | C1 | 1144h | 858h | REDOC_TIS-C1 | NSN | Rel-8 | Andrijana |  |  | peter.leis@nsn.com |
| 271 | 57.1.3 | Documentation of TISPAN R1 and R2 in CT3 | 143d? | 2007-11-28 A | 2008-06-15 | 30% | 100.1d? | 2007-11-28 | 2008-06-15 | 143d? | 400d | finish no earlier than 2008-06-15 | C3 | 1144h | 343.2h | REDOC_TIS-C3 | NSN | Rel-8 | Gwiho |  |  | peter.leis@nsn.com |
| 272 | 57.1.4 | Documentation of TISPAN R1 and R2 in CT4 | 208d? | 2007-11-28 A | 2008-09-12 | 50% | 104d? | 2007-11-28 | 2008-09-12 | 208d? | 335d | finish no earlier than 2008-09-12 | C4 | 1664h | 832h | REDOC_TIS-C4 | NSN | Rel-8 | Kimmo |  |  |  |
| 273 | 57.2 | **IMS Multimedia Telephony Service** | 328d? | 2007-09-10 A | 2008-12-10 | 37% | 207.02d? | 2007-09-10 | 2008-12-10 | 328d? | 272d |  | S1,S5 | 4568h | 1428.8h | IMS-MMTel | Telecom Italia | Rel-8 | Alain |  |  |  |
| 274 | 57.2.1 | Merging TISPAN MMTel [requirements] for Common IMS | 65d? | 2007-09-10 A | 2007-12-07 A | 100% |  | 2007-09-10 | 2007-12-07 | 65d? |  | finish no earlier than 2007-12-07 | S1 | 520h | 520h | TMMTEL | NSN | Rel-8 | Alain | 22.173 |  |  |
| 275 | 57.2.2 | MMTel and Supplementary Services Charging | 243d? | 2008-01-07 A | 2008-12-10 | 20% | 194.4d? | 2008-01-07 | 2008-12-10 | 243d? | 272d | finish no earlier than 2008-12-10 | S5 | 1944h | 388.8h | MMTel-CH | ALU | Rel-8 | Dionisio | 32.275,32.298/299 |  |  |
| 276 | 57.3 | **Call Completion on Busy Subscriber (CCBS)/Call Completion on Non-Reachable (CCNR) on IMS** | 304d? | 2007-05-02 A | 2008-06-30 | 5% | 289.08d? | 2007-05-02 | 2008-06-30 | 304d? | 389d |  | C1,C3 | 7208h | 234.4h | CCBS_CCNR | Deutsche Telekom | Rel-8 | Andrijana | 29.163,24.229,24.173 |  | martin.huelsemann@telekom.de |
| 277 | 57.3.1 | Stage 3 CCBS_CCNR | 293d? | 2007-05-02 A | 2008-06-15 | 10% | 263.7d? | 2007-05-02 | 2008-06-15 | 293d? | 400d | finish no earlier than 2008-06-15 | C1 | 2344h | 234.4h | CCBS_CCNR | Deutsche Telekom | Rel-8 | Andrijana | 24.642, 24.229, 24.173 |  | martin.huelsemann@telekom.de |
| 278 | 57.3.2 | Stage 3 CCBS_CCNR | 304d? | 2007-05-02 | 2008-06-30 |  |  | 2007-05-02 | 2008-06-30 | 304d? | 389d | finish no earlier than 2008-06-30 | C3 | 2432h |  | CCBS_CCNR | Deutsche Telekom | Rel-8 | Gwiho | 29.163 |  | martin.huelsemann@telekom.de |

Notes:
- 256: SA#36 moved to Rel-8 under new UID
- 257: SA#36 moved to Rel-8 under new UID
- 261: Cannot proceed without substantial IETF contribution
- 263: WID approved SA#35
- 265: SA#38 WID approved
- 269: SA#39 completed
- 274: SA#38 completed
- 275: SA#38 WID approved
- 276: C1-50: C1-073083/C3-071084
- 277: C1-50: C1-073083/C3-071084
- 278: C1-50: C1-073083/C3-071084

| ID | WBS | Task | Duration | Start | Finish | Complete | Remaining | Baseline start | Baseline finish | Baseline duration | Total slack | Constraint | Resources | Work | Actual work | Text1 | Text4 | Text5 | Text6 | Text8 |
| --- | --- | --- | --- | --- | --- | --- | --- | --- | --- | --- | --- | --- | --- | --- | --- | --- | --- | --- | --- | --- |
| 279 | 57.4 | **Flexible Alerting** | 164d? | 2008-01-30 A | 2008-09-15 | 48% | 86.1d? | 2008-01-30 | 2008-09-15 | 164d? | 334d |  | S1,C1 | 3870.4h | 1246.4h | FA | Nortel | milanpa@nortel.com | Rel-8 | Alain |
| 280 | 57.4.1 | Stage 1 FA | 164d? | 2008-01-30 A | 2008-09-15 | 90% | 16.4d? | 2008-01-30 | 2008-09-15 | 164d? | 334d |  | S1 | 1246.4h | 1115.2h | CIMS_3GPP2 | Telecom Italia |  | Rel-8 | Alain |
| 281 | 57.4.2 | Stage 3 FA | 164d? | 2008-01-30 A | 2008-09-15 | 5% | 155.8d? | 2008-01-30 | 2008-09-15 | 164d? | 334d | start no earlier than 2008-01-30 | C1 | 1312h | 65.6h | FA | Nortel | milanpa@nortel.com | Rel-8 | Andrijana |
| 282 | 57.5 | **Communication Wait on IMS** | 211d? | 2007-11-30 A | 2008-09-19 | 4% | 202.55d? | 2007-11-30 | 2008-09-19 | 211d? | 330d |  | C1,C3 | 4504h | 112.8h | CW_IMS | Deutsche Telekom | martin.huelsemann@telekom.de | Rel-8 | Andrijana |
| 283 | 57.5.1 | Stage 3 CW-IMS | 141d? | 2007-11-30 A | 2008-06-15 | 10% | 126.9d? | 2007-11-30 | 2008-06-15 | 141d? | 400d | finish no earlier than 2008-06-15 | C1 | 1128h | 112.8h | CW_IMS | Deutsche Telekom | martin.huelsemann@telekom.de | Rel-8 | Andrijana |
| 284 | 57.5.2 | Stage 3 CW-IMS | 211d? | 2007-11-30 | 2008-09-19 |  |  | 2007-11-30 | 2008-09-19 | 211d? | 330d | finish no earlier than 2008-09-19 | C3 | 1688h |  | CW_IMS | Deutsche Telekom | martin.huelsemann@telekom.de | Rel-8 | Gwiho |
| 285 | 57.6 | Advice of Charge (AoC) support in IMS Charging | 243d? | 2008-01-07 A | 2008-12-10 | 25% | 182.25d? | 2008-01-07 | 2008-12-10 | 243d? | 272d | finish no earlier than 2008-12-10 | S5 | 1944h | 486h | IMSTSS | NSN |  | Rel-8 | Dionisio |
| 286 | 57.7 | Add Interconnection Border Control Function (IBCF) to IMS Charging | 128d? | 2007-09-17 A | 2008-03-12 A | 100% |  | 2007-09-17 | 2008-03-12 | 128d? |  | finish no earlier than 2008-03-12 | S5 | 1024h | 1024h | IMSTSS | ALU |  | Rel-8 | Dionisio |
| 287 | 58 | **Interworking between User-to-User Signalling (UUS) and SIP** | 152d? | 2007-11-30 A | 2008-06-30 | 65% | 53.2d? | 2007-11-30 | 2008-06-30 | 152d? | 389d |  | C1,C3 | 3648h | 1580.8h | UUSIW | Huawei | kadyyang@huawei.com | Rel-8 | Kimmo |
| 288 | 58.1 | Stage 3 MGCF UUSIW | 152d? | 2007-11-30 A | 2008-06-30 | 70% | 45.6d? | 2007-11-30 | 2008-06-30 | 152d? | 389d | start no earlier than 2007-11-30 | C1 | 1216h | 851.2h | UUSIW | Huawei | kadyyang@huawei.com | Rel-8 | Kimmo |
| 289 | 58.2 | Stage 3 MGCF UUSIW | 152d? | 2007-11-30 A | 2008-06-30 | 60% | 60.8d? | 2007-11-30 | 2008-06-30 | 152d? | 389d | start no earlier than 2007-11-30 | C3 | 1216h | 729.6h | UUSIW | Huawei | kadyyang@huawei.com | Rel-8 | Gwiho |
| 290 | 59 | AS/MRFC stage 2 and 3 work | 218d? | 2007-11-14 A | 2008-09-12 | 5% | 207.1d? | 2007-11-14 | 2008-09-12 | 218d? | 335d | finish no earlier than 2008-09-12 | C1 | 1744h | 87.2h | MRFC_TS | HP | mark.syrett@hp.com | Rel-8 | Andrijana |
| 291 | 60 | **Maintenance of TISPAN documentation** | 255d? | 2007-07-02 A | 2008-06-20 | 78% | 56.94d? | 2007-07-02 | 2008-06-20 | 255d? | 395d |  | S2,C1,C3,C4 | 6160h | 4112h | MAINTISP | Ericsson |  | Rel-8 | Andrijana |
| 292 | 60.1 | Maintenance of TISPAN R1 | 86d? | 2007-11-09 A | 2008-03-07 A | 100% |  | 2007-11-09 | 2008-03-07 | 86d? |  | start no earlier than 2007-11-09 | C1,C3,C4 | 688h | 688h | MAINT_R1 | ALU | drage@alcatel-lucent.com | Rel-7 | Kimmo |
| 293 | 60.2 | Maintenance of TISPAN R2 | 86d? | 2007-11-09 A | 2008-03-07 A | 100% |  | 2007-11-09 | 2008-03-07 | 86d? |  | start no earlier than 2007-11-09 | C1,C3,C4 | 688h | 688h | MAINT_R2 | ALU | drage@alcatel-lucent.com | Rel-8 | Kimmo |
| 294 | 60.3 | Documentation of TISPAN NGN R1 and R2 in 3GPP SA WG2 | 115d? | 2008-01-14 | 2008-06-20 |  |  | 2008-01-14 | 2008-06-20 | 115d? | 395d | finish no earlier than 2008-06-20 | S2 | 920h |  | IMS_Comm_Doc | NSN | jozsef.varga@nsn.com | Rel-8 | Maurice |
| 295 | 60.4 | Maintenance of TISPAN release 1 common IMS | 114d? | 2007-07-02 A | 2007-12-06 A | 100% |  | 2007-07-02 | 2007-12-06 | 114d? |  | finish no earlier than 2007-12-06 | S2 | 912h | 912h | IMS_Comm_Mtce8 | Telecom Italia | antonio.ascolese@telecomitalia.it | Rel-7 | Maurice |
| 296 | 60.5 | Maintenance of TISPAN release 2 common IMS | 114d? | 2007-07-02 A | 2007-12-06 A | 100% |  | 2007-07-02 | 2007-12-06 | 114d? |  | finish no earlier than 2007-12-06 | S2 | 912h | 912h | IMS_Comm_Mtce8 | Telecom Italia | antonio.ascolese@telecomitalia.it | Rel-8 | Maurice |
| 297 | 61 | **Multimedia interworking between IMS and CS networks** | 846d? | 2005-09-23 A | 2008-12-19 | 59% | 351.08d? | 2005-09-23 | 2008-12-19 | 846d? | 265d |  | S2,C3,C4 | 11224h | 2998.8h | MIW-IMS | Vodafone | nico.gabriele@vodafone.com | Rel-8 | Gwiho |
| 298 | 61.1 | Note: Stages 1 and 2 defined in earlier Release | 49d? | 2005-09-23 A | 2005-11-30 A | 100% |  | 2005-09-23 | 2005-11-30 | 49d? |  | start no earlier than 2005-09-23 | S2 | 392h | 392h | MIW-IMS | Vodafone |  | Rel-8 | Maurice |
| 299 | 61.2 | Stage 3 for MW-IMS, MONA extension | 225d? | 2007-11-05 A | 2008-09-12 | 35% | 146.25d? | 2007-11-05 | 2008-09-12 | 225d? | 335d | finish no earlier than 2008-09-12 | C3 | 1800h | 630h | MIW-IMS | Vodafone | Christer.Holmberg@ericsson.com | Rel-8 | Gwiho |
| 300 | 61.3 | Mn interface (MGCF – IM MGW) | 283d? | 2007-11-21 A | 2008-12-19 | 70% | 84.9d? | 2007-11-21 | 2008-12-19 | 283d? | 265d | finish no earlier than 2008-12-19 | C4 | 2264h | 1584.8h | MIW-IMS | Vodafone |  | Rel-8 | Kimmo |
| 301 | 62 | **Support of Overlap signalling** | 126d? | 2007-11-30 A | 2008-05-23 | 2% | 123.48d? | 2007-11-30 | 2008-05-23 | 126d? | 415d |  | C1,C3 | 3024h | 40.33h | Overlap | Deutsche Telekom | r.jesske@telekom.de | Rel-8 | Gwiho |
| 302 | 62.1 | Stage 3 Overlap (CT1) | 126d? | 2007-11-30 A | 2008-05-23 | 2% | 123.48d? | 2007-11-30 | 2008-05-23 | 126d? | 415d | finish no earlier than 2008-05-23 | C1 | 1008h | 20.16h | Overlap | Deutsche Telekom | r.jesske@telekom.de | Rel-8 | Andrijana |
| 303 | 62.2 | Stage 3 Overlap (CT3) | 126d? | 2007-11-30 A | 2008-05-23 | 2% | 123.48d? | 2007-11-30 | 2008-05-23 | 126d? | 415d | finish no earlier than 2008-05-23 | C3 | 1008h | 20.17h | Overlap | Deutsche Telekom | r.jesske@telekom.de | Rel-8 | Gwiho |

Notes:
- 280: SA#39: CR approved. SA1 consider "Pilot Identity" concept need / Text3: 22.173
- 281: Text3: 24.239,24.173
- 282: C1-50: C1-073084/C3-071085 / Text3: 29.163,24.229,24.173
- 283: C1-50: C1-073084/C3-071085 / Text3: 24.615, 24.229, 24.173
- 284: C1-50: C1-073084/C3-071085 / Text3: 29.163
- 285: SA#38 WID approved / Text3: 32.280,32.240/260/296/298/299
- 286: SA#39 completed / Text3: 32.240/260/298/299
- 287: Text3: 29.163,24.279,24.229
- 288: C3-46: WID in C1-073199/ C3-071126 / Text3: 24.279, 24.229
- 289: C3-46: WID in C1-073199/ C3-071126 / Text3: 29.163
- 290: Text3: 23.218,24.229,24.147,24.247
- 292: C3-46: WID in C1-073189 / C3-071114 / C4-072032. / Text3: 24.229,24.127,29.162,29.163,29.228,29.229,24.xxx
- 293: C3-46: WID in C1-073189 / C3-071114 / C4-072032. / Text3: 24.229,24.127,29.162,29.163,29.228,29.229,24.xxx
- 294: WID approved SA#38. per OPs & ETSI GA 39. This is a joint effort of SA WG2 and TISPAN WG2 / Text3: 23.xxx,23.228,23.204,23.167,23.xyz(TBD)
- 295: WID and TSs approved at SA#38 / Text3: 23.517(ETSIES282.007),23.506(ETSI182.006),23.521(ETSI182.021),23.507(ETSI182.007)
- 296: WID and TSs approved at SA#38 / Text3: 23.517(ETSIES282.007),23.506(ETSI182.006),23.521(ETSI182.021),23.507(ETSI182.007)
- 297: Text3: 29.163,29.332
- 298: Moved from FS section Feb 06
- 299: C3-46: New stage 3 element to cater for MONA extension. / Text3: 29.163
- 300: Text3: 29.332
- 301: Text3: 29.163,24.229,29.228,29.229
- 302: C3-46: WID in C1-073126 / C3-071127 /C4-072008. / Text3: 24.229
- 303: C3-46: WID in C1-073126 / C3-071127 /C4-072008. / Text3: 29.163,29.228,29.229

| ID | WBS | Task | Type | Duration | Start | Finish | Complete | Remaining | Baseline start | Baseline finish | Baseline duration | Total slack | Constraint | Resources | Work | Actual work | Text1 | Text4 | Text5 | Text6 | Text8 | Text12 | Text7 |
| --- | --- | --- | --- | --- | --- | --- | --- | --- | --- | --- | --- | --- | --- | --- | --- | --- | --- | --- | --- | --- | --- | --- | --- |
| 304 | 63 | **Support of (G)MSC-S – (G)MSC-S Nc Interface based on the SIP-I protocol** |  | 266d? | 2007-09-14 A | 2008-09-19 | 47% | 141.87d? | 2007-09-14 | 2008-09-19 | 266d? | 330d |  | C4,C3 | 8512h | 3192h | SIP_Nc | Vodafone | David.Hutton@vodafone.com | Rel-8 | Kimmo |  |  |
| 305 | 63.1 | SIP-I based circuit-switched core network; Stage 2 |  | 266d? | 2007-09-14 A | 2008-09-19 | 70% | 79.8d? | 2007-09-14 | 2008-09-19 | 266d? | 330d | finish no earlier than 2008-09-19 | C4 | 2128h | 1489.6h | SIP_Nc-St2 | Vodafone |  | Rel-8 | Kimmo |  |  |
| 306 | 63.2 | Application of SIP-I Protocols to Circuit Switched (CS) core network architecture; Stage 3 |  | 266d? | 2007-09-14 A | 2008-09-19 | 60% | 106.4d? | 2007-09-14 | 2008-09-19 | 266d? | 330d | finish no earlier than 2008-09-19 | C4 | 2128h | 1276.8h | SIP_Nc-St3 | Vodafone |  | Rel-8 | Kimmo |  |  |
| 307 | 63.3 | Interworking between the 3GPP CS domain with SIP-I as signalling protocol and other networks |  | 266d? | 2007-09-14 A | 2008-09-19 | 10% | 239.4d? | 2007-09-14 | 2008-09-19 | 266d? | 330d | finish no earlier than 2008-09-19 | C3 | 2128h | 212.8h | SIP_Nc | Vodafone | David.Hutton@vodafone.com | Rel-8 | Gwiho |  |  |
| 308 | 64 | **Conferencing enhancements for Mp interface** |  | 266d? | 2007-11-30 A | 2008-12-05 | 9% | 242.47d? | 2007-11-30 | 2008-12-05 | 266d? | 275d |  | C4 | 5944h | 525.87h | eMp | Huawei | Chencheng@huawei.com | Rel-8 | Kimmo |  |  |
| 309 | 64.1 | Stage 2 for eMp |  | 211d? | 2007-11-30 A | 2008-09-19 | 20% | 168.8d? | 2007-11-30 | 2008-09-19 | 211d? | 330d | finish no earlier than 2008-09-19 | C4 | 1688h | 337.6h | eMp | Huawei | Chencheng@huawei.com | Rel-8 | Kimmo |  |  |
| 310 | 64.2 | Stage 3 for eMp |  | 266d? | 2007-11-30 | 2008-12-05 |  |  | 2007-11-30 | 2008-12-05 | 266d? | 275d | finish no earlier than 2008-12-05 | C4 | 2128h |  | eMp | Huawei | Chencheng@huawei.com | Rel-8 | Kimmo |  |  |
| 311 | 65 | **Contact Manager for 3GPP UICC applications** |  | 577d? | 2006-06-22 A | 2008-09-05 | 65% | 199.43d? | 2006-06-22 | 2008-09-05 | 577d? | 340d |  | C6 | 12312h | 8056.55h | eUPHBOOK | Giesecke & Devrient |  | Rel-8 | Xavier |  |  |
| 312 | 65.1 | Requirements for Contact Manager |  | 392d? | 2006-06-22 A | 2007-12-21 A | 100% |  | 2006-06-22 | 2007-12-21 | 392d? |  | finish no earlier than 2007-12-21 | C6 | 3136h | 3136h | eUPHBOOK-St1 | Giesecke & Devrient |  | Rel-8 | Xavier |  |  |
| 313 | 65.2 | External interface for eUPHBOOK |  | 220d? | 2007-05-07 A | 2008-03-07 A | 100% |  | 2007-05-07 | 2008-03-07 | 220d? |  | finish no earlier than 2008-03-07 | C6 | 1760h | 1760h | eUPHBOOK | Giesecke & Devrient |  | Rel-8 | Xavier |  |  |
| 314 | 65.3 | Internal interface for eUPHBOOK |  | 350d? | 2007-05-07 A | 2008-09-05 | 5% | 332.5d? | 2007-05-07 | 2008-09-05 | 350d? | 340d | finish no earlier than 2008-09-05 | C6 | 2800h | 140h | eUPHBOOK | Giesecke & Devrient |  | Rel-8 | Xavier |  |  |
| 315 | 65.4 | Deleted - Implementation of eUPHBOOK | milestone | 0d? | 2007-06-21 A | 2007-06-21 A | 100% |  | 2007-06-21 | 2007-06-21 | 0d? |  | start no earlier than 2007-06-21 | C6 |  |  | eUPHBOOK-St23 |  |  | Rel-8 | Xavier | SP-33 |  |
| 316 | 66 | Definition of 3GPP UICC services over the new high-speed interface |  | 200d? | 2007-12-10 | 2008-09-12 |  |  | 2007-12-10 | 2008-09-12 | 200d? | 335d | finish no earlier than 2008-09-12 | C6 | 1600h |  | UICCHS | Gemalto | jacques.seif@gemalto.com | Rel-8 | Xavier |  |  |
| 317 | 67 | **Rel-8 Improvements of the Radio Interface** |  | 532d? | 2007-03-05 A | 2009-03-17 | 46% | 288.95d? | 2007-03-05 | 2009-03-17 | 532d? | 203d |  | RP,R5 | 23832h | 7974.8h | RInImp8 | Alcatel-Lucent |  | Rel-8 | MCC_RAN |  |  |
| 318 | 67.1 | UMTS 1500 MHz |  | 140d? | 2007-03-05 A | 2007-09-14 A | 100% |  | 2007-03-05 | 2007-09-14 | 140d? |  | finish no earlier than 2007-09-14 | R4 | 1120h | 1120h | RInImp8-UMTS1500 | NTT DoCoMo | NTT DoCoMo | Rel-8 | MCC_RAN |  | TSG |
| 319 | 67.2 | UMTS 700 MHz |  | 334d? | 2007-03-05 A | 2008-06-12 | 95% | 16.7d? | 2007-03-05 | 2008-06-12 | 334d? | 401d | finish no earlier than 2008-06-12 | R4 | 2672h | 2538.4h | RInImp8-UMTS700 | Nokia |  | Rel-8 | MCC_RAN |  | TSG |
| 320 | 67.3 | UMTS 2300 MHz |  | 334d? | 2007-03-05 A | 2008-06-12 | 20% | 267.2d? | 2007-03-05 | 2008-06-12 | 334d? | 401d | finish no earlier than 2008-06-12 | R4 | 2672h | 534.4h | RInImp8-UMTS2300 | AT&T | marc.grant@cingular.com | Rel-8 | MCC_RAN |  | TSG |
| 321 | 67.4 | UMTS/LTE 3500 MHz |  | 327d? | 2007-12-17 A | 2009-03-17 | 10% | 294.3d? | 2007-12-17 | 2009-03-17 | 327d? | 203d | finish no earlier than 2009-03-17 | R4 | 2616h | 261.6h | RInImp8-UMTSLTE3500 | Ericsson | johan.skold@ericsson.com | Rel-8 | MCC_RAN |  |  |
| 322 | 67.5 | UMTS 2300 MHz TDD |  | 327d? | 2007-12-17 A | 2009-03-17 | 15% | 277.95d? | 2007-12-17 | 2009-03-17 | 327d? | 203d | finish no earlier than 2009-03-17 | R4 | 2616h | 392.4h | RInImp8-UMTS2300TDD | Datang | songyuexia@datangmobile.cn | Rel-8 | MCC_RAN |  |  |
| 323 | 67.6 | Further Improved Minimum Performance Requirements for HSDPA UE (FDD) - Two-Branch Interference Cancellation |  | 265d? | 2007-03-05 A | 2008-03-07 A | 100% |  | 2007-03-05 | 2008-03-07 | 265d? |  | finish no earlier than 2008-03-12 | R4 | 2120h | 2120h | RInImp8-2BIC | AT&T | marc.grant@cingular.com | Rel-8 | MCC_RAN |  |  |
| 324 | 67.7 | **CS Voice Service over HSPA** |  | 329d? | 2007-06-01 | 2008-09-03 |  |  | 2007-06-01 | 2008-09-03 | 329d? | 342d |  | R2,R5 | 5264h |  | RInImp8-CsHspa | NSN | woonhee.hwang@nsn.com | Rel-8 | MCC_RAN |  |  |
| 325 | 67.7.1 | Conformance Test Aspects – CS Voice Service over HSPA |  | 329d? | 2007-06-01 | 2008-09-03 |  |  | 2007-06-01 | 2008-09-03 | 329d? | 342d | finish no earlier than 2008-09-03 | R5 | 2632h |  | RInImp8-CsHspa_UEConTest | Bao Yi (Huawei) | baoyi@huawei.com | Rel-8 | Stoyan Baev |  |  |
| 326 | 67.8 | Performance requirements for 15 code reception with 16QAM/QPSK |  | 126d? | 2007-06-11 A | 2008-03-07 A | 100% |  | 2007-06-11 | 2008-03-07 | 126d? |  | finish no earlier than 2008-06-12 | R4 | 1008h | 1008h | RInImp8-Hsdpa15codes | Vodafone | tim.frost@vodafone.com | Rel-8 | MCC_RAN |  |  |
| 327 | 68 | **Rel-8 RAN improvements** |  | 400d? | 2007-06-04 A | 2008-12-12 | 38% | 247.48d? | 2007-06-04 | 2008-12-12 | 400d? | 270d |  | RP | 21320h | 8129.37h | RANimp | Alcatel-Lucent |  | Rel-8 | MCC_RAN |  |  |
| 328 | 68.1 | Combination of 64QAM and MIMO for HSDPA (FDD) |  | 260d? | 2007-06-04 A | 2008-05-30 | 50% | 130d? | 2007-06-04 | 2008-05-30 | 260d? | 410d | finish no earlier than 2008-05-30 | R1 | 2080h | 1040h | RANimp-64QamMimoHsdpa | Ericsson | Johan.Bergman@ericsson.com | Rel-8 | MCC_RAN |  |  |
| 329 | 68.2 | Improved L2 for uplink |  | 186d? | 2007-09-14 A | 2008-05-30 | 95% | 9.3d? | 2007-09-14 | 2008-05-30 | 186d? | 410d | finish no earlier than 2008-05-30 | R2 | 1488h | 1413.6h | RANimp-UplinkL2dataRates | Ericsson | Janne.Peisa@ericsson.com | Rel-8 | MCC_RAN |  |  |
| 330 | 68.3 | Enhanced Uplink for CELL_FACH State in FDD |  | 186d? | 2007-09-14 A | 2008-05-30 | 50% | 93d? | 2007-09-14 | 2008-05-30 | 186d? | 410d | finish no earlier than 2008-05-30 | R2 | 1488h | 744h | RANimp-UplinkEnhState | NSN | markus.wimmer@nsn.com | Rel-8 | MCC_RAN |  |  |
| 331 | 68.4 | Enhanced UE DRX for FDD |  | 186d? | 2007-09-14 A | 2008-05-30 | 50% | 93d? | 2007-09-14 | 2008-05-30 | 186d? | 410d | finish no earlier than 2008-05-30 | R2 | 1488h | 744h | RANimp-DRX | Nokia | luis.barreto@nokia.com | Rel-8 | MCC_RAN |  |  |
| 332 | 68.5 | Enhancements for SRNS Relocation Procedure |  | 186d? | 2007-09-14 A | 2008-05-30 | 75% | 46.5d? | 2007-09-14 | 2008-05-30 | 186d? | 410d | finish no earlier than 2008-05-30 | R3 | 1488h | 1116h | RANimp-SrnsReloc | NSN | masatoshi.nakamata@nsn.com | Rel-8 | MCC_RAN |  |  |
| 333 | 68.6 | Enhancements for FDD HSPA Evolution |  | 186d? | 2007-09-14 A | 2008-05-30 | 30% | 130.2d? | 2007-09-14 | 2008-05-30 | 186d? | 410d | finish no earlier than 2008-05-30 | R3 | 1488h | 446.4h | RANimp-HSPAEvo | NSN | masatoshi.nakamata@nsn.com | Rel-8 | MCC_RAN |  |  |
| 334 | 68.7 | 64QAM for 1.28 Mcps TDD HSDPA |  | 129d? | 2007-12-04 A | 2008-05-30 | 65% | 45.15d? | 2007-12-04 | 2008-05-30 | 129d? | 410d | finish no earlier than 2008-05-30 | R1 | 1032h | 670.8h | RANimp-64Qam1.28TDD | ZTE | zfmail@zte.com.cn | Rel-8 | MCC_RAN |  |  |
| 335 | 68.8 | Enhanced CELL_FACH state in 1.28 Mcps TDD |  | 204d? | 2007-12-04 A | 2008-09-12 | 40% | 122.4d? | 2007-12-04 | 2008-09-12 | 204d? | 335d | finish no earlier than 2008-09-12 | R2 | 1632h | 652.8h | RANimp-EnhState1.28TDD | ZTE | zhang.yincheng@zte.com.cn | Rel-8 | MCC_RAN |  |  |
| 336 | 68.9 | 1.28 Mcps TDD TDD Repeater Specification |  | 204d? | 2007-12-04 A | 2008-09-12 | 5% | 193.8d? | 2007-12-04 | 2008-09-12 | 204d? | 335d | finish no earlier than 2008-09-12 | R4 | 1632h | 81.6h | RANimp-Repeaters1.28TDD | RITT | qinyan@chinattl.com | Rel-8 | MCC_RAN |  |  |
| 337 | 68.10 | Continuous Connectivity for packet data users for 1.28Mcps TDD |  | 201d? | 2008-03-07 | 2008-12-12 |  |  | 2008-03-07 | 2008-12-12 | 201d? | 270d | finish no earlier than 2008-12-12 | R1 | 1608h |  | RANimp-LCRCPC |  |  | Rel-8 | MCC_RAN |  |  |
| 338 | 68.11 | HSPA VoIP to WCDMA/GSM CS continuity |  | 136d? | 2008-03-07 | 2008-09-12 |  |  | 2008-03-07 | 2008-09-12 | 136d? | 335d | start no earlier than 2008-03-07 | R2 | 1088h |  | RANimp-HSPAVoIP |  |  | Rel-8 | MCC_RAN |  |  |
| 339 | 68.12 | HS-DSCH Serving Cell Change Enhancements |  | 201d? | 2008-03-07 | 2008-12-12 |  |  | 2008-03-07 | 2008-12-12 | 201d? | 270d | finish no earlier than 2008-12-12 | R2 | 1608h |  | RANimp-HSDSCH |  |  | Rel-8 | MCC_RAN |  |  |
| 340 | 69 | MBSFN Downlink Optimized Broadcast 3.84 Mcps TDD |  | 141d? | 2007-06-04 A | 2007-12-17 | 30% | 98.7d? | 2007-06-04 | 2007-12-17 | 141d? | 529d | finish no earlier than 2007-12-17 | R1 | 1128h | 338.4h | MBSFN-DOB | Ericsson |  | Rel-8 | MCC_RAN |  |  |

Notes:
- 305: Text3: 23.231
- 306: Text3: 29.231
- 307: CP-37: WI corrected. C3-36: Skeleton of TR 29.235 available. / Text3: 29.235
- 308: Text3: 23.333,29.333
- 309: Text3: 23.333
- 310: Text3: 29.333
- 312: C6-43: Name Changed to Requirements for Contact Manager. Expected completion updated from CT#34 to CT#35. / Text3: 21.111
- 313: New TS 31.xyz to be produced / Text3: 31.220
- 314: Created at CT#37 / Text3: 31.xyz
- 315: SA#33 stopped / Text3: 31.102
- 318: Text3: 25.101,25.104,25.133,25.141,25.331,25.942,25.306,25.307,34.121
- 319: Status Report in RP-080037 / Text3: 25.101,25.104,25.133,25.141,25.331,25.942,25.306,25.307,34.121
- 320: Status Report in RP-080038 / Text3: 25.101,25.104,25.133,25.141,25.331,25.942,25.306,25.307,34.121
- 321: WI Description in RP-071012. Status Report in RP-080039 / Text3: 25.101,25.104,25.113,25.133,25.141,34.124,25.307,25.331,25.461,25.463,34.108,34.121,36.101,36.104,36.141,36.508,25.307,36.331,36.521-1,36.521-2
- 322: WI Description in RP-071016. Status Report in RP-080040 / Text3: 25.102,25.105,25.113,25.123,25.142,34.124,25.306,25.331,34.122
- 323: Status Report in RP-080041, WI completed in RP#39
- 324: WI Description in RP-070823. Status Report in RP-080042, WI completed in RP#39 / Text3: 25.323,25.331,25.322
- 325: Text3: TS34.108, TS 34.123-1, TS 34.123-2, TS 34.123-3
- 326: WI Description in RP-070824. Status Report in RP-080043, WI completed in RP#39 / Text3: 25.101
- 328: Status Report in RP-080044, 50% complete for RAN4 (100 for other WGs) / Text3: 25.308,25.211,25.212,25.213,25.306,25.331,25.433,25.435,25.423,25.425,25.101,25.104,25.141
- 329: Status Report in RP-080045 / Text3: 25.319,25.301,25.306,25.321,25.331,25.433,25.435,25.423,25.425,25.427
- 330: Status Report in RP-080046 / Text3: 25.309,25.211,25.214,25.321,25.331,25.423,25.433
- 331: Status Report in RP-080047 / Text3: 25.306,25.308,25.321,25.331,25.423
- 332: Status Report in RP-080048 / Text3: 25.306,25.308,25.321,25.331,25.423,25.433,25.214,25.133
- 333: Status Report in RP-080049 / Text3: 25.423,25.427,25.433
- 334: WI Description in RP-080050 / Text3: 25.201,25.221,25.222,25.223,25.224,25.306,25.308,25.321,25.331,25.423,25.433,25.102,25.105,25.142
- 335: WI Description in RP-080051 / Text3: 25.308,25.304,25.306,25.224,25.321,25.331,25.433,25.435,25.423,25.425,25.123
- 336: WI Description in RP-071003 / Text3: 25.113
- 337: WID in RP-080085 / Text3: 25.929
- 338: WID in RP-080229
- 339: WID in RP-080227
- 340: Status Report in RP-080218 / Text3: 25.346,25.201,25.221,25.222,25.223,25.306,25.331,25.402,25.433,25.102,25.105,25.123

| ID | WBS | Task | Type | Duration | Start | Finish | Complete | Remaining | Baseline start | Baseline finish | Baseline duration | Total slack | Constraint | Resources | Work | Actual work | Text1 | Text4 | Text6 | Text8 | Text7 | Text3 | Text12 |
| --- | --- | --- | --- | --- | --- | --- | --- | --- | --- | --- | --- | --- | --- | --- | --- | --- | --- | --- | --- | --- | --- | --- | --- |
| 341 | 70 | **(Draft WID) Support of UTRA HNB** |  | 136d? | 2008-03-07 | 2008-09-12 |  |  | 2008-03-07 | 2008-09-12 | 136d? | 335d |  | R2,R4 | 2176h |  | HNodeB | ALU | Rel-8 | MCC_RAN |  |  |  |
| 342 | 70.1 | FDD Home NodeB RF requirements |  | 136d? | 2008-03-07 | 2008-09-12 |  |  | 2008-03-07 | 2008-09-12 | 136d? | 335d | start no earlier than 2008-03-07 | R4 | 1088h |  | HNodeB-RF |  | Rel-8 | MCC_RAN | TSG |  |  |
| 343 | 71 | MS Antenna Performance Evaluation Method and Requirements |  | 731d? | 2005-01-28 A | 2007-11-16 A | 100% |  | 2005-01-28 | 2007-11-16 | 731d? |  | finish no earlier than 2007-11-16 | GP | 5848h | 5848h | APEMR | TeliaSonera | Rel-8 | Paolo |  | 25.914,25.144,45.005 |  |
| 344 | 72 | **GAN Enhancements** |  | 261d? | 2007-08-31 A | 2008-08-29 | 36% | 167.22d? | 2007-08-31 | 2008-08-29 | 261d? | 345d |  | GP | 5184h | 1862.62h | GANENH | T-Mobile | Rel-8 | Paolo |  | 43.318,44.318,51.010 |  |
| 345 | 72.1 | Update to GAN specifications |  | 126d? | 2007-08-31 A | 2008-02-22 A | 100% |  | 2007-08-31 | 2008-02-22 | 126d? |  | finish no earlier than 2008-02-22 | GP | 1008h | 1008h | GANENH-SPEC | T-Mobile | Rel-8 | Paolo |  | 43.318,44.318 |  |
| 346 | 72.2 | Update TS 51.010 Mobile Station (MS) Conformance Specification for GAN Enhancements |  | 261d? | 2007-08-31 A | 2008-08-29 | 5% | 247.95d? | 2007-08-31 | 2008-08-29 | 261d? | 345d | finish no earlier than 2008-08-29 | GP | 2088h | 104.4h | GANENH-MStest | T-Mobile | Rel-8 | Stoyan |  | 51.010 |  |
| 347 | 73 | AoIP (A-interface over IP) |  | 196d? | 2008-02-22 | 2008-11-21 |  |  | 2008-02-22 | 2008-11-21 | 196d? | 285d | start no earlier than 2008-02-22 | GP | 1568h |  | AoIP | China Mobile, Ericsson | Rel-8 | Paolo |  | 48.001,48.002,48.008,48.020,49.008 |  |
| 348 | 74 | New multicarrier BTS class |  | 186d? | 2007-08-31 A | 2008-05-16 | 70% | 55.8d? | 2007-08-31 | 2008-05-16 | 186d? | 420d | finish no earlier than 2008-05-16 | G1 | 1488h | 1041.6h | MCBTS | Alcatel-Lucent | Rel-8 | Paolo |  | 45.005,45.050,51.021 |  |
| 349 | 75 | **Conformance testing for the Latency Reductions feature** |  | 196d? | 2008-02-22 | 2008-11-21 |  |  | 2008-02-22 | 2008-11-21 | 196d? | 285d |  | G1, G3 | 4224h |  | CTLATRED | Ericsson | Rel-8 | Paolo, Stoyan |  | 51.010,51.021 |  |
| 350 | 75.1 | MS conformance testing for the Latency Reductions feature |  | 196d? | 2008-02-22 | 2008-11-21 |  |  | 2008-02-22 | 2008-11-21 | 196d? | 285d | finish no earlier than 2008-11-21 | G3 | 1568h |  | CTLATRED-MStest | Ericsson | Rel-8 | Stoyan |  | 51.010 |  |
| 351 | 75.2 | BTS conformance testing for the Latency Reductions feature |  | 136d? | 2008-02-22 | 2008-08-29 |  |  | 2008-02-22 | 2008-08-29 | 136d? | 345d | finish no earlier than 2008-08-29 | G1 | 1088h |  | CTLATRED-BTStest | Ericsson | Rel-8 | Paolo |  | 51.021 |  |
| 352 | 76 | Mobile Station conformance testing of Packet-switched Handover |  | 196d? | 2008-02-22 | 2008-11-21 |  |  | 2008-02-22 | 2008-11-21 | 196d? | 285d | finish no earlier than 2008-11-21 | G3 | 1568h |  | PSHCT_MStest | Rohde & Schwarz | Rel-8 | Stoyan |  | 51.010 |  |
| 353 | 77 | Mobile Station conformance testing of Support of Conversational Services in A/Gb mode via the PS domain |  | 321d? | 2008-02-22 | 2009-05-15 |  |  | 2008-02-22 | 2009-05-15 | 321d? | 160d | finish no earlier than 2009-05-15 | G3 | 2568h |  | SCSAGBCT_MStest | Nokia | Rel-8 | Stoyan |  | 51.010 |  |
| 354 | 78 | (Small) Technical Enhancements and Improvements for Rel-8 |  | 509d? | 2007-01-01 A | 2008-12-11 | 70% | 152.7d? | 2007-01-01 | 2008-12-11 | 509d? | 271d | finish no earlier than 2008-12-11 | All | 4072h | 2850.4h | TEI8 | ALL | Rel-8 |  |  |  |  |
| 355 | 79 | Deleted - was Rel7 - LCS for 3GPP Interworking WLAN | milestone | 0d? | 2007-09-28 A | 2007-09-28 A | 100% |  | 2007-09-28 | 2007-09-28 | 0d? |  | start no earlier than 2007-09-28 | S2 |  |  | LCS4_IWLAN | LG Electronics | Rel-8 | Maurice |  | 23.234,23.271,23.167 | SP-35 |
| 356 | 80 | Deleted - never approved- FBI Phase 2 | milestone | 0d | 2007-09-28 A | 2007-09-28 A | 100% |  | 2007-09-28 | 2007-09-28 | 0d |  | start no earlier than 2007-09-28 | S2 |  |  | FBI2 | NSN | Rel-8 | Maurice | TSG |  | SP-38 |
| 357 | 81 | Deleted -Enhancements to BS30 Bearer service for Videotelephony | milestone | 0d? | 2007-03-15 A | 2007-03-15 A | 100% |  | 2007-03-15 | 2007-03-15 | 0d? |  | finish no earlier than 2007-03-15 | S1 |  |  | BS30 |  | Rel-8 | Alain |  | 22.002,22.004,22.101,22.105,24.008 | SP-38 |
| 358 | 82 | Deleted - IMS Enhancements Rel-8 |  | 75d? | 2007-09-03 A | 2007-12-14 A | 100% |  | 2007-09-03 | 2007-12-14 | 75d? |  |  | S1 | 600h | 600h | IMS8 | Telecom Italia | Rel-8 | Alain |  |  | SP-38 |
| 359 | 83 | Deleted - U-TDOA Enhancement |  | 131d? | 2007-05-18 A | 2007-11-16 A | 100% |  | 2007-05-18 | 2007-11-16 | 131d? |  | finish no earlier than 2007-11-16 | GP | 1048h | 1048h | GUTEN | TruePosition | Rel-7 | Paolo |  | 43.059,45.008,48.071 | SP-39 |
| 360 | 84 | Rel-8 Feasibility Studies | milestone | 0d? | 2008-03-20 A | 2008-03-20 A | 100% |  | 2008-03-20 | 2008-03-20 | 0d? |  | finish no earlier than 2008-03-20 | CP,RAN,SA,GERAN |  |  |  |  | Rel-8 |  |  |  |  |
| 361 | 85 | Study on Facilitating Machine to Machine Communication in GSM and UMTS (M2M) |  | 350d? | 2005-11-04 A | 2007-03-08 A | 100% |  | 2005-11-04 | 2007-03-08 | 350d? |  | finish no earlier than 2006-06-16 | S1 | 2800h | 2800h | M2M | NSN | Rel-8 | Alain |  | 22.868 |  |
| 362 | 86 | Study on Network Composition |  | 526d? | 2005-12-07 A | 2007-12-12 A | 100% |  | 2005-12-07 | 2007-12-12 | 526d? |  | finish no earlier than 2006-09-27 | S1 | 4208h | 4208h | NetComp | NSN | Rel-8 | Alain |  | 22.980 |  |
| 363 | 87 | Study on Requirements of IMS Multimedia Conferencing |  | 330d? | 2006-06-08 A | 2007-09-12 A | 100% |  | 2006-06-08 | 2007-09-12 | 330d? |  | finish no earlier than 2007-03-21 | S1 | 2640h | 2640h | SI-IMSconf | China Mobile | Rel-8 | Alain |  | 22.948 |  |
| 364 | 88 | **Study on centralized IMS services** |  | 363d? | 2006-10-23 A | 2008-03-12 A | 100% |  | 2006-10-23 | 2008-03-12 | 363d? |  |  | S1,S2 | 5048h | 5048h | FSICS | Ericsson | Rel-8 | Alain |  | 22.892,23.892 |  |
| 365 | 88.1 | Study on centralized IMS services requirements |  | 268d? | 2007-03-05 A | 2008-03-12 A | 100% |  | 2007-03-05 | 2008-03-12 | 268d? |  | start no earlier than 2007-03-05 | S1 | 2144h | 2144h | FSICS-S1 | Ericsson | Rel-8 | Alain |  | 22.892 |  |
| 366 | 88.2 | Study on centralized IMS services control |  | 363d? | 2006-10-23 A | 2008-03-12 A | 100% |  | 2006-10-23 | 2008-03-12 | 363d? |  | finish no earlier than 2008-02-21 | S2 | 2904h | 2904h | IMS_CSC | Alcatel-Lucent | Rel-8 | Maurice |  | 23.892 |  |
| 367 | 89 | Study on Paging Permission with Access Control |  | 256d? | 2006-09-28 A | 2007-09-20 A | 100% |  | 2006-09-28 | 2007-09-20 | 256d? |  | finish no earlier than 2007-09-20 | S1 | 2048h | 2048h | PPAC | NTT DoCoMo | Rel-8 | Alain |  | 22.908 |  |
| 368 | 90 | Study on Non 3GPP access NSP |  | 249d? | 2006-12-06 A | 2007-11-19 A | 100% |  | 2006-12-06 | 2007-11-19 | 249d? |  | finish no earlier than 2007-11-19 | S1 | 1992h | 1992h | N3GtoNSP | Telefonica O2 | Rel-8 | Alain |  | 22.812 |  |
| 369 | 91 | Study on Value Added Services for Short Message Service |  | 263d? | 2006-12-06 A | 2007-12-07 A | 100% |  | 2006-12-06 | 2007-12-07 | 263d? |  | finish no earlier than 2007-12-07 | S1 | 2104h | 2104h | FSVAS4SMS | China Mobile | Rel-8 | Alain |  | 22.942 |  |
| 370 | 92 | Study on Services Alignment and Migration |  | 331d? | 2006-12-06 A | 2008-03-12 A | 100% |  | 2006-12-06 | 2008-03-12 | 331d? |  | finish no earlier than 2007-09-20 | S1 | 2648h | 2648h | FSServAl | China Mobile | Rel-8 | Alain |  | 22.983 |  |
| 371 | 93 | Study on support of a Public Warning System |  | 140d? | 2007-09-03 A | 2008-03-14 A | 100% |  | 2007-09-03 | 2008-03-14 | 140d? |  |  | S1 | 1120h | 1120h | PWS-SI | T-Mobile | Rel-8 | Alain |  | 22.968 |  |

Notes:
- 341: approved in principle, WID in RP-080159, to be reviewed
- 342: WID RP-080234
- 343: Reference to RAN4 specifications containing performance evaluation method included in Rel 7. GSM MS requirements open. / Text5: Ulf.Tegth@teliasonera.com
- 344: Completed / Text5: mohammed.versi@t-mobile.com
- 345: Completed / Text5: mohammed.versi@t-mobile.com
- 346: Not completed / Text5: mohammed.versi@t-mobile.com
- 347: Text5: wangshuaiyu@chinamobile.com and paul.schliwa-bertling@ericsson.com
- 348: Text5: thomas.bitzer@alcatel-lucent.de
- 349: Text5: mats.y.samuelsson@ericsson.com and hakan.e.grunditz@ericsson.com
- 350: Text5: hakan.e.grunditz@ericsson.com
- 351: Text5: mats.y.samuelsson@ericsson.com
- 352: Text5: Franz.Segerer@ROHDE-SCHWARZ.COM
- 353: Text5: arsi.heino@nokia.com
- 355: SA#35 stopped / Text5: dhshim@lge.com
- 356: SA#38 stopped
- 357: SA#38 stopped (no support) / Text5: andre.jarvis@three.co.uk
- 358: SA#38 stopped
- 359: SA#39: Included in Rel7 / Text5: terri.brooks@trueposition.com
- 361: SA#35 completed
- 362: SA#38 completed / Text5: joerg.swetina@siemens.com
- 363: SA#37 completed / Text5: zhengjianping@chinamobile.com
- 364: 22.892 planed to be withdrawn at SA#40 / Text5: peter.bleckert@ericsson.com
- 365: SA#39 completed / Text5: peter.bleckert@ericsson.com
- 366: SA#39 completed / Text5: andybennett@Alcatel-Lucent.com
- 367: Text5: noguchi@nttdocomo.co.jp
- 368: Text5: chris.friel@o2.com
- 369: Text5: wubin@chinamobile.com
- 370: SA#39 completed. Rel-9 SAM started / Text5: fenglingjuan@chinamobile.com
- 371: Acronym changed from "PWS-SI" to "FSPWS" / Text5: mark.younge@t-mobile.com

| ID | WBS | Task | Duration | Start | Finish | Complete | Remaining | Baseline start | Baseline finish | Baseline duration | Total slack | Constraint | Resources | Work | Actual work | Text1 | Text4 | Text6 | Text7 | Text8 | Text3 | Text5 | Text12 |
| --- | --- | --- | --- | --- | --- | --- | --- | --- | --- | --- | --- | --- | --- | --- | --- | --- | --- | --- | --- | --- | --- | --- | --- |
| 372 | 94 | **Study on 3GPP System Architecture Evolution** | 915d? | 2004-12-03 A | 2008-06-05 | 89% | 102.73d? | 2004-12-03 | 2008-06-05 | 915d? | 406d |  | S2,S3 | 18600h | 11512h | SAE | Vodafone | Rel-8 | TSG | Maurice |  |  |  |
| 373 | 94.1 | Stage 2 Interim conclusion for RAN Work to start | 854d? | 2004-12-03 A | 2008-03-12 | 90% | 85.4d? | 2004-12-03 | 2008-03-12 | 854d? | 467d | finish no earlier than 2005-09-23 | S2 | 6832h | 6148.8h | FS_SAE | Vodafone | Rel-8 |  | Maurice | 23.882 |  |  |
| 374 | 94.2 | Stage 2 study on 3GPP architectural development | 568d? | 2006-01-09 A | 2008-03-12 | 90% | 56.8d? | 2006-01-09 | 2008-03-12 | 568d? | 467d | finish no earlier than 2007-09-28 | S2 | 4544h | 4089.6h | FS_SAE | Vodafone | Rel-8 |  | Maurice | 23.882 | Chris Pudney |  |
| 375 | 94.3 | Security study for Inter-access mobility between non 3GPP and 3GPP system | 199d? | 2007-09-03 A | 2008-06-05 | 80% | 39.8d? | 2007-09-03 | 2008-06-05 | 199d? | 406d | start no earlier than 2007-09-01 | S3 | 1592h | 1273.6h | FS_SAE | Nokia | Rel-8 |  | Dioniso | 33.821,33.922 | dajiang.zhang@NOKIA.COM |  |
| 376 | 95 | Study on Stage 2 aspects of IMS Service Brokering | 581d? | 2006-06-19 A | 2008-09-08 | 55% | 261.45d? | 2006-06-19 | 2008-09-08 | 581d? | 339d | finish no earlier than 2008-09-08 | S2 | 4648h | 2556.4h | ISB_ST2_SDY | Telcordia | Rel-8 |  | Maurice | 23.810 | raquel@research.telcordia.com |  |
| 377 | 96 | Study on VCC support for Emergency Calls | 657d? | 2006-06-08 A | 2008-12-12 | 35% | 427.05d? | 2006-06-08 | 2008-12-12 | 657d? | 270d | finish no earlier than 2008-12-12 | S2 | 5256h | 1839.6h | FSVCCEm | Nortel | Rel-8 |  | Maurice | 23.826 |  |  |
| 378 | 97 | Study on IMS utilizing multicast bearer services | 444d? | 2006-03-22 A | 2007-12-03 A | 100% |  | 2006-03-22 | 2007-12-03 | 444d? |  | finish no earlier than 2007-12-03 | S2 | 3552h | 3552h | FS-MLTICAST-IMS | NSN | Rel-8 |  | Maurice | 23.847 |  |  |
| 379 | 98 | Study of Mobility between 3GPP-WLAN Interworking and 3GPP Systems | 129d? | 2007-03-20 A | 2007-09-14 A | 100% |  | 2007-03-20 | 2007-09-14 | 129d? |  | start no earlier than 2007-03-20 | S2 | 1032h | 1032h | SM3GWLAN | Orange | Rel-8 |  | Maurice | 23.837 | orange |  |
| 380 | 99 | Study on Multimedia Session Continuity | 291d? | 2007-04-26 A | 2008-06-05 | 90% | 29.1d? | 2007-04-26 | 2008-06-05 | 291d? | 406d | finish no earlier than 2008-06-05 | S2 | 2328h | 2095.2h | MMSC_FS | LG Electronics | Rel-8 |  | Maurice | 23.893 |  |  |
| 381 | 100 | Study on Protection against SMS and MMS spam | 657d? | 2006-06-08 A | 2008-12-12 | 30% | 459.9d? | 2006-06-08 | 2008-12-12 | 657d? | 270d | finish no earlier than 2008-12-12 | S3 | 5256h | 1576.8h | CPSMal | Orange | Rel-8 |  | Dioniso | 33.9xx | eric.gauthier@orange.ch |  |
| 382 | 101 | Study on Transferring of emergency call data – in-band modem solution | 265d? | 2006-12-07 A | 2007-12-12 A | 100% |  | 2006-12-07 | 2007-12-12 | 265d? |  | finish no earlier than 2008-09-18 | S4 | 2120h | 2120h | eCALLIBMS | Airbiquity | Rel-8 |  | Paolo | 26.967 | lhong@airbiquity.com |  |
| 383 | 102 | Deleted OAM&P Rel-8 Studies | 742d? | 2006-05-10 A | 2009-03-12 A | 100% |  | 2006-05-10 | 2009-03-12 | 742d? |  |  | S5 | 3425.6h | 3425.6h | OAM8-Studies |  | Rel-8 |  | Adrian |  |  | SP-39 |
| 384 | 103 | Study of Element Operations Systems Function (EOSF) definition | 266d? | 2007-06-07 A | 2008-06-12 A | 100% |  | 2007-06-07 | 2008-06-12 | 266d? |  | finish no earlier than 2008-12-11 | S5 | 2128h | 2128h | OAM8-Studies | China Mobile | Rel-8 |  | Dionisio | 32.819 |  |  |
| 385 | 104 | Deleted Study of Element Operations Systems Function (EOSF) definition | 396d? | 2007-06-07 A | 2008-12-11 A | 100% |  | 2007-06-07 | 2008-12-11 | 396d? |  | finish no earlier than 2008-12-11 | S5 | 3168h | 3168h | OAM7-NIM- EOSF | China Mobile | Rel-7 |  | Dionisio | 32.819 |  | SP-36 |
| 386 | 105 | Delete Study on SA5 MTOSI XML Harmonization | 351d? | 2006-05-10 A | 2007-09-12 A | 100% |  | 2006-05-10 | 2007-09-12 | 351d? |  | finish no earlier than 2007-12-14 | S5 | 2808h | 2808h | OAM7-NIM-XML | Nortel | Rel-7 |  | Dionisio | 32.818 |  | SP-36 |
| 387 | 106 | Study on SA5 MTOSI XML Harmonization | 351d? | 2006-05-10 A | 2007-09-12 A | 100% |  | 2006-05-10 | 2007-09-12 | 351d? |  | finish no earlier than 2007-12-14 | S5 | 2808h | 2808h | OAM8-Studies | Nortel | Rel-8 |  | Dionisio | 32.818 |  |  |
| 388 | 107 | Delete Study of Common Profile Storage (CPS) Framework of User Data for network services and management | 244d? | 2006-07-03 A | 2007-06-07 A | 100% |  | 2006-07-03 | 2007-06-07 | 244d? |  | finish no earlier than 2007-06-07 | S5 | 1952h | 1952h | OAM7-CPS | T-Mobile | Rel-8 |  | Dionisio | 32.808 |  | SP-36 |
| 389 | 108 | Study of Common Profile Storage (CPS) Framework of User Data for network services and management | 244d? | 2006-07-03 A | 2007-06-07 A | 100% |  | 2006-07-03 | 2007-06-07 | 244d? |  | finish no earlier than 2007-06-07 | S5 | 1952h | 1952h | OAM8-Studies | T-Mobile | Rel-8 |  | Dionisio | 32.808 |  |  |
| 390 | 109 | Study of Management for LTE and SAE | 526d? | 2006-12-07 A | 2008-12-11 | 90% | 52.6d? | 2006-12-07 | 2008-12-11 | 526d? | 271d | finish no earlier than 2008-12-11 | S5 | 4208h | 3787.2h | OAM8-Studies | Ericsson | Rel-8 |  | Dionisio | 32.816 |  |  |
| 391 | 110 | Study on Charging Aspects of 3GPP System Evolution | 179d? | 2007-04-02 A | 2007-12-06 A | 100% |  | 2007-04-02 | 2007-12-06 | 179d? |  | finish no earlier than 2007-12-06 | S5 | 1432h | 1432h | FSSAEcharg | NSN | Rel-8 |  | Dionisio | 32.820 |  |  |
| 392 | 111 | Study of System Maintenance over Itf-N | 396d? | 2007-06-07 A | 2008-12-11 | 60% | 158.4d? | 2007-06-07 | 2008-12-11 | 396d? | 271d | finish no earlier than 2008-12-11 | S5 | 3168h | 1900.8h | OAM8-Studies | ZTE | Rel-8 |  | Dionisio | 32.822 |  |  |
| 393 | 112 | Study of Self-Organizing Networks (SON) related OAM interfaces for Home NodeB | 396d? | 2007-06-07 A | 2008-12-11 | 40% | 237.6d? | 2007-06-07 | 2008-12-11 | 396d? | 271d | finish no earlier than 2008-12-11 | S5 | 3168h | 1267.2h | OAM8-Studies | Huawei | Rel-8 |  | Dionisio | 32.821 |  |  |
| 394 | 113 | Study on Self-healing of Self-Organizing Networks (SON) | 275d? | 2008-02-22 A | 2009-03-12 | 10% | 247.5d? | 2008-02-22 | 2009-03-12 | 275d? | 206d | finish no earlier than 2009-03-12 | S5 | 2200h | 220h | OAM8-Studies | ZTE | Rel-8 |  | Dionisio | 32.8xy |  |  |
| 395 | 114 | Study on AS-MRFC media server control protocol | 583d? | 2006-03-22 A | 2008-06-13 | 95% | 29.15d? | 2006-03-22 | 2008-06-13 | 583d? | 400d | finish no earlier than 2008-06-13 | C1 | 4664h | 4430.8h | MRFC | HP | Rel-8 |  | Andrijana | 24.880 | mark.syrett@hp.com |  |
| 396 | 115 | Study on Restoration Procedures | 310d? | 2007-03-26 A | 2008-05-30 | 80% | 62d? | 2007-03-26 | 2008-05-30 | 310d? | 410d | finish no earlier than 2008-05-30 | C4 | 2480h | 1984h | FS_IMS_RP | Ericsson | Rel-8 |  | Kimmo | 23.820 | german.blanco@ericsson.com |  |
| 397 | 116 | Study on IMS Application Server Service Data Descriptions for AS interoperability | 186d? | 2007-09-14 A | 2008-05-30 | 40% | 111.6d? | 2007-09-14 | 2008-05-30 | 186d? | 410d | finish no earlier than 2008-05-30 | C4 | 1488h | 595.2h | FS_IMS_ASIO | ALU | Rel-8 |  | Kimmo | 29.864 | nhberry@ALCATEL-LUCENT.COM |  |

Notes:
- 372: Moved from Rel-7
- 373: Moved from Rel-7. SA#39: TR 23.882 is 100% complete, but technically out-of-date. SA2 to submit for SA#40 Approval with disclaimer text.
- 374: Moved from Rel-7. SA#39: TR 23.882 is 100% complete, but technically out-of-date. SA2 to submit for SA#40 Approval with disclaimer text.
- 375: Moved from Rel-7
- 376: Study approved SA#32
- 378: SA#38 completed
- 380: SA#38 TR for information
- 381: Formerly called "Consumer protection against spam and malware"
- 383: Created to encompass the Rel7 FSs shifted to Re-8. Set SA5 FSs in-line (1) with the others
- 384: Moved from Rel-7
- 385: Moved from Rel-7
- 386: Moved from Rel-7
- 387: Moved from Rel-7
- 388: Moved from Rel-7
- 389: Moved from Rel-7
- 391: WID approved SA#35
- 394: SA#39 WID Approval

| ID | WBS | Task | Type | Duration | Start | Finish | Complete | Remaining | Baseline start | Baseline finish | Baseline duration | Total slack | Constraint | Resources | Work | Actual work | Text1 | Text3 | Text4 | Text5 | Text6 | Text8 | Text12 | Text7 |
| --- | --- | --- | --- | --- | --- | --- | --- | --- | --- | --- | --- | --- | --- | --- | --- | --- | --- | --- | --- | --- | --- | --- | --- | --- |
| 398 | 117 | **Study on Customized Alerting Tone (CAT) solution for voice and video call in CS domain** |  | 261d? | 2007-09-14 A | 2008-09-12 | 21% | 206.76d? | 2007-09-14 | 2008-09-12 | 261d? | 335d |  | C4,C3 | 6106.8h | 992.4h | FS_CAT_VVC_CS | 29.882 | China Mobile | zhanghao@chinamobile.com | Rel-8 | Kimmo |  |  |
| 399 | 117.1 | Study on CAT solution for voice and video call in CS domain |  | 261d? | 2007-09-14 A | 2008-09-12 | 40% | 156.6d? | 2007-09-14 | 2008-09-12 | 261d? | 335d | finish no earlier than 2008-09-12 | C4 | 2088h | 835.2h | FS_CAT_VVC_CS | 29.882 | CMCC | zhanghao@chinamobile.com | Rel-8 | Kimmo |  |  |
| 400 | 117.2 | CT3 Review of CT4's Study on CAT |  | 241.35d? | 2007-09-14 A | 2008-09-12 |  | 241.35d? | 2007-09-14 | 2008-09-12 | 241.35d? | 335d | finish no earlier than 2008-09-12 | C3 | 1930.8h |  | FS_CAT_VVC_CS | 29.882 | China Mobile | zhanghao@chinamobile.com | Rel-8 | Gwiho |  |  |
| 401 | 118 | Study on InterWorking Function between MAP based and Diameter based interfaces |  | 211d? | 2007-11-30 A | 2008-09-19 | 5% | 200.45d? | 2007-11-30 | 2008-09-19 | 211d? | 330d | finish no earlier than 2008-09-19 | C4 | 1688h | 84.4h | FS_MAP2Diam | 29.805 | Huawei | liming49985@HUAWEI.COM | Rel-8 | Kimmo |  |  |
| 402 | 119 | Study on Scope of future HSPA Evolution for 1.28Mcps TDD |  | 195d? | 2007-09-14 A | 2008-06-12 | 80% | 39d? | 2007-09-14 | 2008-06-12 | 195d? | 401d | finish no earlier than 2008-06-12 | R1 | 1560h | 1248h | FS_RAN-LCRTDDHSPAEvo | 25.824 | RITT |  | Rel-8 | MCC_RAN |  |  |
| 403 | 120 | Study on Synchronized E-DCH for UTRA FDD |  | 126d? | 2007-09-14 A | 2008-03-07 A | 100% |  | 2007-09-14 | 2008-03-07 | 126d? |  | finish no earlier than 2008-03-14 | R1 | 1008h | 1008h | FS_RAN-UplinkSync | 25.823 | NSN | Karri.Ranta-aho@nsn.com | Rel-8 | MCC_RAN |  |  |
| 404 | 121 | Study on Dual-Cell HSDPA operation |  | 196d? | 2008-03-07 | 2008-12-05 |  |  | 2008-03-07 | 2008-12-05 | 196d? | 275d | finish no earlier than 2008-12-05 | R1,R4 | 1568h |  | FS_RAN-DCHS | 25.9xx | ALU |  | Rel-8 | MCC_RAN |  |  |
| 405 | 122 | Study on Improved network controlled mobility between LTE and 3GPP2/mobile WiMAX radio technologies |  | 131d? | 2007-06-04 A | 2007-12-03 A | 100% |  | 2007-06-04 | 2007-12-03 | 131d? |  | finish no earlier than 2007-12-03 | R2 | 1048h | 1048h | FS_RAN-LTEmob | 36.938 | Motorola | hao.bi@Motorola.com | Rel-8 | MCC_RAN |  |  |
| 406 | 123 | Study on 3G Home NodeB/eNodeB |  | 274d? | 2007-03-05 A | 2008-03-20 | 90% | 27.4d? | 2007-03-05 | 2008-03-20 | 274d? | 461d | finish no earlier than 2008-03-20 | R4 | 2192h | 1972.8h | FS_NodeB | 25.820 | Motorola |  | Rel-8 | MCC_RAN |  |  |
| 407 | 124 | Study on Evaluation of the inclusion of Path Loss Based Technology in the UTRAN |  | 195d? | 2007-12-17 A | 2008-09-12 | 5% | 185.25d? | 2007-12-17 | 2008-09-12 | 195d? | 335d | start no earlier than 2007-12-17 | R4 | 1560h | 78h | FS_RAN-Pathloss | 25.9xx | Polaris Wireless |  | Rel-8 | MCC_RAN |  |  |
| 408 | 125 | Study on HS-PDSCH serving cell change enhancements |  | 60d? | 2007-12-17 A | 2008-03-07 A | 100% |  | 2007-12-17 | 2008-03-07 | 60d? |  | finish no earlier than 2008-06-12 | R4 | 480h | 480h | FS_RAN-HSPDSCH | 25.9xx | Qualcomm |  | Rel-8 | MCC_RAN |  |  |
| 409 | 126 | Study on A-interface over IP |  | 126d? | 2007-08-31 A | 2008-02-22 A | 100% |  | 2007-08-31 | 2008-02-22 | 126d? |  | finish no earlier than 2008-02-22 | GP | 1008h | 1008h | AINTIP | 43.903 | China Mobile, Ericsson | paul.schliwa-bertling@ericsson.com | Rel-8 | Paolo |  |  |
| 410 | 127 | Study on Multi-User Reusing-One-Slot |  | 196d? | 2007-11-16 A | 2008-08-15 | 20% | 156.8d? | 2007-11-16 | 2008-08-15 | 196d? | 355d | finish no earlier than 2008-08-15 | GP | 1568h | 313.6h | MUROS |  | NSN | juergen.hofmann@nsn.com | Rel-8 | Paolo |  |  |
| 411 | 128 | Study on Optimized Transmit Pulse Shape for Downlink EGPRS2-B |  | 206d? | 2007-11-16 A | 2008-08-29 | 10% | 185.4d? | 2007-11-16 | 2008-08-29 | 206d? | 345d | start no earlier than 2007-11-16 | G1 | 1648h | 164.8h | WIDER | 45.9xx | RIM, NSN | jdwyer@RIM.COM and eddie.riddington@nsn.com | Rel-8 | Paolo |  |  |
| 412 | 129 | Deleted - equals 340035 -FS on Service continuity between mobile and WLAN networks |  | 75d? | 2007-09-03 A | 2007-12-14 A | 100% |  | 2007-09-03 | 2007-12-14 | 75d? |  | finish no earlier than 2007-12-14 | S1 | 600h | 600h | FSSCMobToW | 22.937 | BT | mike.meyerstein@bt.com | Rel-8 | Alain | SP-39 |  |
| 413 | 130 | Deleted - Study on GAN Enhancements |  | 206d? | 2006-11-17 A | 2007-08-31 A | 100% |  | 2006-11-17 | 2007-08-31 | 206d? |  | start no earlier than 2006-11-17 | GP | 1648h | 1648h | EGAN | 43.902 | T-Mobile | janne.linkola@t-mobile.com | Rel-7 | Paolo | SP-37 |  |
| 414 | 131 | **Deleted - Study on All-IP Network** |  | 448d? | 2004-06-28 A | 2006-03-15 A | 100% |  | 2004-06-28 | 2006-03-15 | 448d? |  |  | S1 | 8672h | 8672h | AIPN | 22.978 | NTT DoCoMo | c.masyu@nttdocomo.co.jp | Rel-8 | Alain | SP-38 | TSG |
| 415 | 131.1 | Deleted - All-IP Network Feasibility Study |  | 188d? | 2004-06-28 A | 2005-03-16 A | 100% |  | 2004-06-28 | 2005-03-16 | 188d? |  | start no earlier than 2004-06-28 | S1 | 1504h | 1504h | AIPFS | 22.978 | NTT DoCoMo | c.masyu@nttdocomo.co.jp | Rel-8 | Alain | SP-27 | TSG |
| 416 | 131.2 | Deleted - draft Stage 1 |  | 448d? | 2004-06-28 A | 2006-03-15 A | 100% |  | 2004-06-28 | 2006-03-15 | 448d? |  | finish no earlier than 2006-03-15 | S1 | 3584h | 3584h | AIPN | 22.258 | NTT DoCoMo | c.masyu@nttdocomo.co.jp | Rel-8 | Alain | SP-38 | TSG |
| 417 | 132 | Rel-9 Feasibility Studies | milestone | 0d | 2000-01-03 | 2000-01-03 |  |  | 2000-01-03 | 2000-01-03 | 0d | 2604d | finish no earlier than 2000-01-03 | CP,RAN,SA,GERAN |  |  |  |  |  |  | Rel-9 |  |  |  |
| 418 | 133 | **Study on enhanced voice service requirements for the EPS** |  | 464d? | 2007-09-03 A | 2009-06-11 | 12% | 408.54d? | 2007-09-03 | 2009-06-11 | 464d? | 141d |  | S1,S4 | 8544h | 577.6h | FSEV_EPS | 22.813 | Orange | tim.haysom@orange-ftgroup.com | Rel-9 | Alain |  |  |
| 419 | 133.1 | Use cases definition and service and system requirements |  | 140d? | 2007-09-03 A | 2008-03-14 | 35% | 91d? | 2007-09-03 | 2008-03-14 | 140d? | 465d | start no earlier than 2007-09-03 | S1 | 1120h | 392h | FSEV_EPS-S1 | 22.813 | Orange | tim.haysom@orange-ftgroup.com | Rel-9 | Alain |  |  |
| 420 | 133.2 | Codec specific part of FSEV_EPS |  | 464d? | 2007-09-03 A | 2009-06-11 | 5% | 440.8d? | 2007-09-03 | 2009-06-11 | 464d? | 141d | finish no earlier than 2009-06-11 | S4 | 3712h | 185.6h | FSEV_EPS-S4 |  | Orange | tim.haysom@orange-ftgroup.com | Rel-9 | Paolo |  |  |
| 421 | 134 | Study on advanced requirements for IP interconnect |  | 78d? | 2007-12-04 | 2008-03-20 |  |  | 2007-12-04 | 2008-03-20 | 78d? | 461d | finish no earlier than 2008-03-20 | S1 | 624h |  | IPXS | 22.893 | Telefonica O2 | chris.friel@O2.com | Rel-9 | Alain |  |  |
| 422 | 135 | Study on Service continuity between mobile and WLAN networks |  | 537d? | 2006-12-06 A | 2008-12-25 | 90% | 53.7d? | 2006-12-06 | 2008-12-25 | 537d? | 261d | finish no earlier than 2008-12-25 | S1 | 4296h | 3866.4h | SMLSWLAN | 22.937 | BT | mike.meyerstein@bt.com | Rel-9 | Alain |  |  |
| 423 | 136 | Study on CS Domain Services over EPS access |  | 359d? | 2007-04-25 A | 2008-09-08 | 70% | 107.7d? | 2007-04-25 | 2008-09-08 | 359d? | 339d | finish no earlier than 2008-09-08 | S2 | 2872h | 2010.4h | FS_CSoPS | 23.879 | T-Mobile | Sabine.Demel@T-Mobile.at | Rel-9 | Maurice |  |  |
| 424 | 137 | Study on Extended Support of IMS Emergency Calls |  | 320d? | 2007-09-24 A | 2008-12-12 | 15% | 272d? | 2007-09-24 | 2008-12-12 | 320d? | 270d | finish no earlier than 2008-12-12 | S2 | 2560h | 384h | FS_IMS-eCALL | 23.868 | Qualcomm |  | Rel-9 | Maurice |  |  |
| 425 | 138 | Study on System enhancements for the use of IMS services in local breakout |  | 315d? | 2007-10-01 A | 2008-12-12 | 20% | 252d? | 2007-10-01 | 2008-12-12 | 315d? | 270d | finish no earlier than 2008-12-12 | S2 | 2520h | 504h | FS_IMS_LBO | 23.894 | Telecom Italia | mario.madella@telecomitalia.it, victor.kueh@bt.com | Rel-9 | Maurice |  |  |
| 426 | 139 | Evaluation of LCS Control Plane Solution for EPS |  | 310d? | 2008-01-14 A | 2009-03-20 | 20% | 248d? | 2008-01-14 | 2009-03-20 | 310d? | 200d | finish no earlier than 2009-03-20 | S2 | 2480h | 496h | FS_LCS_EPS | 23.8xx | SiRF Technology |  | Rel-9 | Maurice |  |  |
| 427 | 140 | Study on Architecture of Customized Alerting Tone (CAT) |  | 200d? | 2007-12-04 A | 2008-09-08 | 10% | 180d? | 2007-12-04 | 2008-09-08 | 200d? | 339d | finish no earlier than 2008-09-08 | S2 | 1600h | 160h | FSCusAlert-St2 |  | China Mobile | wangjing@chinamobilecom | Rel-9 | Maurice |  |  |
| 428 | 141 | Study on Intra Domain Connection of RAN Nodes to Multiple CN Nodes |  | 262d? | 2008-03-12 | 2009-03-12 |  |  | 2008-03-12 | 2009-03-12 | 262d? | 206d | finish no earlier than 2009-03-12 | S2 | 2096h |  | FS_IDC | 23.8xy(linkedto23.236) | China Mobile | LIU HONG (liuhongyfw@chinamobile.com) | Rel-9 | Maurice |  |  |
| 429 | 142 | Study on Remote management of USIM application on M2M Equipment |  | 263d? | 2007-09-19 A | 2008-09-19 | 40% | 157.8d? | 2007-09-19 | 2008-09-19 | 263d? | 330d | finish no earlier than 2008-09-19 | S3 | 2104h | 841.6h | FSUM2M | 33.8yz | Ericsson | vesa.lehtovirta@ericsson.com | Rel-9 | Dioniso |  |  |
| 430 | 143 | Study on UTRAN key management enhancements |  | 192d? | 2007-12-20 | 2008-09-12 |  |  | 2007-12-20 | 2008-09-12 | 192d? | 335d | finish no earlier than 2008-09-12 | S3 | 1536h |  | FSUKM |  | Ericsson |  | Rel-9 | Dioniso |  |  |
| 431 | 144 | Study on Home (e)NodeB Security |  | 192d? | 2007-12-20 A | 2008-09-12 | 10% | 172.8d? | 2007-12-20 | 2008-09-12 | 192d? | 335d | start no earlier than 2007-12-20 | S3 | 1536h | 153.6h | FSHNB |  | Huawei | yangyanmei@huawei.com | Rel-9 | Dioniso |  |  |
| 432 | 145 | Study on LTE-Advanced |  | 66d? | 2008-03-07 | 2008-12-05 |  |  | 2008-03-07 | 2008-12-05 | 66d? | 275d | start no earlier than 2008-03-07 | R1 | 528h |  | FS_LTEA | 25.9xx | ALU |  | Rel-9 | MCC_RAN |  |  |
| 433 | 146 | RAN5 Rel-7 Testing | milestone | 0d | 2000-01-01 | 2000-01-01 |  |  | 2000-01-01 | 2000-01-01 | 0d | 2605d |  | R5 |  |  |  |  |  |  |  |  |  |  |

Notes:
- 398: CT#37 WID approved
- 402: Status Report in RP-080067
- 403: Status Report in RP-080068. RAN#39 completed
- 404: SID in RP-080228
- 405: Status Report in RP-070827. RAN#38 completed
- 406: Status Report in RP-070826080066, complete for RAN1,2,4, remains open for RAN3
- 407: SID in RP-080069
- 408: SI Description in RP-080070, new WI in RP-080227. RAN#39 completed
- 409: Completed
- 412: SA#39 stopped
- 413: SA#37 Included in Rel7
- 414: SA#38 stopped
- 415: SA#27 stopped
- 416: 22.258 withdrawn, superseded by 22.278 (UID 320022). SA#38 stopped
- 418: Moved to Rel9
- 419: Moved to Rel9
- 420: Moved to Rel9
- 422: SA#39 moved to Rel-9
- 423: Move to Rel-9
- 424: Move to Rel-9
- 425: SA#39 Revised SID approved. Move to Rel-9
- 426: SID approved SA#38. Moved to Rel-9 SI
- 428: SA#39: SID approved. Linked to 23.236
- 432: SID in RP-080137

| ID | WBS | Task | Duration | Start | Finish | Complete | Remaining | Baseline start | Baseline finish | Baseline duration | Total slack | Constraint | Deadline | Resources | Work | Actual work | Text1 | Text6 | Text8 | Text4 | Text5 | Text10 | Text7 |
| --- | --- | --- | --- | --- | --- | --- | --- | --- | --- | --- | --- | --- | --- | --- | --- | --- | --- | --- | --- | --- | --- | --- | --- |
| 434 | 147 | **Rel-7 Improvements of the Radio Interface** | 667d? | 2005-11-11 A | 2008-06-02 | 91% | 58.22d? | 2005-11-11 | 2008-06-02 | 667d? | 409d |  |  | RP | 21720h | 16121.9h | RInImp | Rel-7 | Cesar |  |  |  |  |
| 435 | 147.1 | **Rel-7 Improvements of the Radio Interface UE Confromance Testing** | 667d? | 2005-11-11 A | 2008-06-02 | 91% | 58.22d? | 2005-11-11 | 2008-06-02 | 667d? | 409d |  |  | R5 | 16384h | 14953.9h | RInImp-UEConTest | Rel-7 | Stoyan Baev | RAN5 |  |  |  |
| 436 | 16.5.1 | UE conformance testing for UMTS 2600 MHz | 146d | 2005-11-11 A | 2006-06-02 A | 100% |  | 2005-11-11 | 2006-06-02 | 146d |  | finish no earlier than 2006-06-02 | 2006-06-02 | R5 | 1168h | 1168h | RInImp-UMTS2600_Test | Rel-7 | Stoyan Baev | Nokia | Aleksi Heino | Fri 7/11/05 |  |
| 437 | 16.5.1 | UE Conformance Test for UMTS in 900 MHz band (band VIII) | 146d | 2005-11-11 A | 2006-06-02 A | 100% |  | 2005-11-11 | 2006-06-02 | 146d |  | finish no earlier than 2006-06-02 | 2006-06-02 | R5 | 1168h | 1168h | RInImp-UMTS900_Test | Rel-7 | Stoyan Baev | Qualcomm | hanye@qualcomm.com | Fri 11/03/05 |  |
| 438 | 147.1.3 | Conformance Test Aspects – Improved Performance of HSDPA Receiver type 3 | 191d? | 2006-03-10 A | 2006-12-01 A | 100% |  | 2006-03-10 | 2006-12-01 | 191d? |  | finish no earlier than 2006-12-01 |  | R5 | 1528h | 1528h | RInImp-HSPerf-Type3_Test | Rel-7 | Stoyan Baev | Motorola | carolyn.taylor@motorola.com |  |  |
| 439 | 147.1.4 | UE antenna Over The Air (OTA) conformance testing | 444d? | 2006-09-20 A | 2008-06-02 | 70% | 133.2d? | 2006-09-20 | 2008-06-02 | 444d? | 409d | finish no earlier than 2008-06-02 |  | R5 | 3552h | 2486.4h | RInImp-UEAnt_Test | Rel-7 | Stoyan Baev | Nokia | Aleksi.Heino@nokia.com |  |  |
| 440 | 147.1.5 | UE conformance testing for FDD Inter-Band Operation | 131d? | 2006-06-02 A | 2006-12-01 A | 100% |  | 2006-06-02 | 2006-12-01 | 131d? |  | finish no earlier than 2006-12-01 |  | R5 | 1048h | 1048h | RInImp-InterBand_Test | Rel-7 | Stoyan Baev | NEC, Motorola | Jacob.John@motorola.com |  |  |
| 441 | 147.1.6 | Conformance Test Aspects – Extended UMTS 1.7/2.1 GHz | 131d? | 2006-12-01 A | 2007-06-01 A | 100% |  | 2006-12-01 | 2007-06-01 | 131d? |  | finish no earlier than 2007-06-01 |  | R5 | 1048h | 1048h | RInImp-UEConTest_UMTS1721Ext | Rel-7 | Stoyan Baev | Motorola | carolyn.taylor@motorola.com |  |  |
| 442 | 147.1.7 | Conformance Test Aspects – Minimum UE performance requirement for downlink physical channels in support of E-DCH operation based on type 1 enhanced receiver (Rx-Diversity) | 136d? | 2007-06-01 A | 2007-12-07 A | 100% |  | 2007-06-01 | 2007-12-07 | 136d? |  | finish no earlier than 2007-12-07 |  | R5 | 1088h | 1088h | RInImp-UEConTest_RxDivEDCH | Rel-7 | Stoyan Baev | Motorola | carolyn.taylor@motorola.com |  |  |
| 443 | 147.1.8 | Conformance Test Aspects – Minimum UE performance requirement for downlink physical channels in support of MTCGH and MCCH operation based on type 1 enhanced receiver (Rx-Diversity) | 201d? | 2007-06-01 A | 2008-03-07 A | 100% |  | 2007-06-01 | 2008-03-07 | 201d? |  | finish no earlier than 2008-03-07 |  | R5 | 1608h | 1608h | RInImp-UEConTest_RxDivMBMS | Rel-7 | Stoyan Baev | Ericsson | leif.mattisson@ericsson.com |  |  |
| 444 | 148 | **Rel-7 RAN improvements** | 518d? | 2006-09-20 A | 2008-09-12 | 68% | 168.24d? | 2006-09-20 | 2008-09-12 | 518d? | 335d |  |  | RP | 25456h | 15082.5h | RANimp | Rel-7 | MCC_RAN |  |  |  | TSG |
| 445 | 148.1 | **UE Conformance Testing for Rel-7 RAN improvements** | 518d? | 2006-09-20 A | 2008-09-12 | 68% | 168.24d? | 2006-09-20 | 2008-09-12 | 518d? | 335d |  |  | R5 | 21312h | 14390.1h | RANimp-UEConTest | Rel-7 | Stoyan Baev | RAN5 |  |  |  |
| 446 | 148.1.1 | Conformance Test Aspects - 3.84 Mcps and 7.68 Mcps TDD Enhanced Uplink | 518d? | 2006-09-20 A | 2008-09-12 | 45% | 284.9d? | 2006-09-20 | 2008-09-12 | 518d? | 335d | finish no earlier than 2008-09-12 |  | R5 | 4144h | 1864.8h | RANimp-UEConTest_EDCHTDH | Rel-7 | Stoyan Baev | IPWireless | tspeight@ipwireless.com |  |  |
| 447 | 148.1.2 | Conformance Test Aspects – 64QAM for HSDPA (FDD) | 257d? | 2007-03-09 A | 2008-03-03 A | 100% |  | 2007-03-09 | 2008-03-03 | 257d? |  | finish no earlier than 2008-03-03 |  | R5 | 2056h | 2056h | RANimp-UEConTest_64QamDownlink | Rel-7 | Stoyan Baev | Ericsson | leif.mattisson@ericsson.com |  |  |
| 448 | 148.1.3 | Conformance Test Aspects – 16QAM for HSUPA (FDD) | 396d? | 2007-03-09 A | 2008-09-12 | 95% | 19.8d? | 2007-03-09 | 2008-09-12 | 396d? | 335d | finish no earlier than 2008-09-12 |  | R5 | 3168h | 3009.6h | RANimp-UEConTest_16QamUplink | Rel-7 | Stoyan Baev | Motorola | carolyn.taylor@motorola.com |  |  |
| 449 | 148.1.4 | Conformance Test Aspects – Improved L2 support for high data rates | 257d? | 2007-03-09 A | 2008-03-03 A | 100% |  | 2007-03-09 | 2008-03-03 | 257d? |  | finish no earlier than 2008-03-03 |  | R5 | 2056h | 2056h | RANimp-UEConTest_L2DataRates | Rel-7 | Stoyan Baev | Ericsson | leif.mattisson@ericsson.com |  |  |
| 450 | 148.1.5 | Conformance Test Aspects – Continuous connectivity for packet data users | 322d? | 2007-03-09 A | 2008-06-02 | 95% | 16.1d? | 2007-03-09 | 2008-06-02 | 322d? | 409d | finish no earlier than 2008-06-02 |  | R5 | 2576h | 2447.2h | RANimp-UEConTest_CPC | Rel-7 | Stoyan Baev | Nokia | jarkko.hellsten@nokia.com |  |  |
| 451 | 148.1.6 | Conformance Test Aspects – Enhanced CELL_FACH state in FDD | 396d? | 2007-03-09 A | 2008-09-12 | 5% | 376.2d? | 2007-03-09 | 2008-09-12 | 396d? | 335d | finish no earlier than 2008-09-12 |  | R5 | 3168h | 158.4h | RANimp–UEConTest_EnhancedCellFACHState | Rel-7 | Stoyan Baev | Nokia | jarkko.hellsten@nokia.com |  |  |
| 452 | 149 | **1.28 Mcps TDD Enhanced Uplink** | 257d? | 2007-09-11 A | 2008-09-03 | 15% | 218.45d? | 2007-09-11 | 2008-09-03 | 257d? | 342d |  |  | RP | 2680h | 630.27h | LCRTDD-EDCH | Rel-7 | MCC_RAN | CATT | Haijing Hu |  |  |
| 453 | 149.1 | UE conformance test aspects - 1.28Mcps TDD Enhanced Uplink | 257d? | 2007-09-11 A | 2008-09-03 | 15% | 218.45d? | 2007-09-11 | 2008-09-03 | 257d? | 342d | start no earlier than 2007-09-11 |  | R5 | 624h |  | LCRTDD-EDCH-UEConTest | Rel-7 | Stoyan Baev | CATT | chenxiaozhong@datangmobile.cn |  |  |
| 454 | 150 | **Multimedia Telephony Service for IMS** | 649d? | 2006-03-10 A | 2008-09-03 | 80% | 128.3d? | 2006-03-10 | 2008-09-03 | 649d? | 342d |  |  | S1,C1,S4,R5 | 10528h | 6264h | MTSI | Rel-7 | Mike | Supporting Companies: | peter.bleckert @ericsson.com |  |  |
| 455 | 150.1 | Stage 1 of MTSI | 191d? | 2006-03-15 A | 2006-12-06 A | 100% |  | 2006-03-15 | 2006-12-06 | 191d? |  | start no earlier than 2006-03-15 |  | S1 | 1528h | 1528h | MTSI-REQ | Rel-7 | Mike |  | peter.bleckert @ericsson.com |  |  |
| 456 | 150.2 | Stage 3 of MTSI | 330d? | 2006-03-10 A | 2007-06-15 A | 100% |  | 2006-03-10 | 2007-06-15 | 330d? |  | finish no earlier than 2007-06-15 |  | C1 | 2640h | 2640h | MTSI | Rel-7 | Andrijana | Christer Holmberg (Ericsson) | christer.holmberg@ericsson.com |  |  |
| 457 | 150.3 | Media handling and interaction in MTSI | 262d? | 2006-03-15 A | 2007-03-15 A | 100% |  | 2006-03-15 | 2007-03-15 | 262d? |  | finish no earlier than 2007-03-15 |  | S4 | 2096h | 2096h | MTSI-MHI | Rel-7 | Paolo | Olle Franceschi (Ericsson) | olle.franceschi@ericsson.com |  |  |
| 458 | 150.4 | Conformance Test Aspects – Multimedia Telephony Services for IMS (MTSI) | 257d | 2007-09-11 A | 2008-09-03 | 20% | 205.6d | 2007-09-11 | 2008-09-03 | 257d | 342d | start no earlier than 2007-09-11 |  | R5 | 624h |  | MTSI-UEConfTest | Rel-7 | Stoyan Baev | CATT | chenxiaozhong@datangmobile.cn |  |  |

Notes:
- 434: Status not tracked. Only Testing WIs tracked.
- 435: BB place holder for a number of RAN5 Tasks
- 436: Text3: TS 34.108, 34.121
- 437: Text3: TS 34.108, 34.121
- 438: Text3: TS34.121, TS 34.108
- 439: Text3: TS 34.114
- 440: Text3: TS34.108, TS34.123-1, TS34.123-2, TS34.123-3
- 441: Text3: TS 34.108, TS 34.121-1, TS 34.121-2
- 442: Text3: 11/06/2007 08:00
- 443: Text3: 11/06/2007 08:00
- 444: Generic feature
- 445: BB place holder for a number of RAN5 Tasks
- 446: Covers also requirements in Feature EDCHTDD / Text3: TS34.108, TS34.122, TS 34.123-1, TS 34.123-2, TS 34.123-3
- 447: Text3: TS34.108, TS 34.121-1, TS 34.121-2, TS 34.123-1, TS 34.123-2, TS 34.123-3
- 448: Text3: TS34.108, TS 34.121-1, TS 34.121-2, TS 34.123-1, TS 34.123-2, TS 34.123-3
- 449: Text3: TS34.108, TS 34.123-1, TS 34.123-2, TS 34.123-3
- 450: Text3: TS34.108, TS 34.121-1, TS 34.121-2, TS 34.123-1, TS 34.123-2, TS 34.123-3
- 451: Text3: TS34.108, TS 34.123-1, TS 34.123-2, TS 34.123-3
- 453: Text3: 34.108,34.122,34.123-1/2/3
- 456: TS 24.173:IMS Multimedia telephony service and supplementary services / Text3: New TS 24.173
- 457: Text3: 26.114
- 458: Text3: 34.108,34.122,34.123-1/2/3

| ID | WBS | Task | Duration | Start | Finish | Complete | Remaining | Baseline start | Baseline finish | Baseline duration | Total slack | Constraint | Resources | Work | Actual work | Text1 | Text4 | Text5 | Text6 | Text8 |
| --- | --- | --- | --- | --- | --- | --- | --- | --- | --- | --- | --- | --- | --- | --- | --- | --- | --- | --- | --- | --- |
| 459 | 151 | **Network selection enhancements** | 2325d? | 2000-01-03 A | 2008-11-28 | 60% | 934.3d? | 2000-01-03 | 2008-11-28 | 2325d? | 280d |  | S1,C1,R5 | 23256h | 4656h | NSP-CR | Chris Friel, O2 | chris.friel@o2.com | Rel-7 | Michael |
| 460 | 151.1 | Stage 1 of NSP | 191d? | 2006-03-15 A | 2006-12-06 A | 100% |  | 2006-03-15 | 2006-12-06 | 191d? |  | start no earlier than 2006-03-15 | S1 | 1528h | 1528h | NSP-TS | Chris Friel, O2 | chris.friel@o2.com | Rel-7 | Michael |
| 461 | 151.2 | Procedural aspects of NSP | 391d? | 2000-01-03 A | 2001-07-02 A | 100% |  | 2000-01-03 | 2001-07-02 | 391d? |  |  | C1 | 3128h | 3128h | NSP-CR | Andrew Howell (Motorola) | andrew.howell@motorola.com | Rel-7 | Andrijana |
| 462 | 151.3 | Conformance Test Aspects - Network Selection Enhancements | 391d? | 2007-06-01 | 2008-11-28 |  |  | 2007-06-01 | 2008-11-28 | 391d? | 280d | finish no earlier than 2008-11-28 | R5 | 3128h |  | NSP-CR_UEConTest | Jarkko Hellsten (Nokia) | jarkko.hellsten@nokia.com | Rel-7 | Stoyan Baev |
| 463 | 152 | **MBMS Enhancements** | 2395d? | 2000-01-03 A | 2009-03-06 | 67% | 794.15d? | 2000-01-03 | 2009-03-06 | 2395d? | 210d |  | S1 | 37884.6h | 8050.64h | MBMSE | Liu Hong, China Mobile | liuhongyfw@chinamobile.com | Rel-7 | Mike |
| 464 | 152.1 | Stage 1 of MBMSE | 109d? | 2005-07-11 A | 2005-12-08 A | 100% |  | 2005-07-11 | 2005-12-08 | 109d? |  | finish no earlier than 2005-12-08 | S1 | 872h | 872h | MBMSE | Liu Hong, China Mobile | liuhongyfw@chinamobile.com | Rel-7 | Mike |
| 465 | 152.2 | MBMS FDD Physical layer Enhancements | 117.29d? | 2006-12-15 A | 2007-06-04 A | 100% |  | 2006-12-15 | 2007-06-04 | 117.29d? |  | finish no earlier than 2007-06-04 | R1 | 938.32h | 938.32h | MBMSE-RANPhysFDD | Lars Lindbom | Lars.Lindbom@ericsson.com | Rel-7 |  |
| 466 | 152.3 | **MBMS TDD Physical layer Enhancements** | 2395d? | 2000-01-03 A | 2009-03-06 | 50% | 1197.5d? | 2000-01-03 | 2009-03-06 | 2395d? | 210d |  | R1,R5 | 26498.3h | 3650.32h | MBMSE-RANPhysTDD | Nicholas Anderson |  | Rel-7 |  |
| 467 | 152.3.1 | MBMS TDD Physical layer Enhancements | 461d? | 2007-06-01 A | 2009-03-06 A | 100% |  | 2007-06-01 | 2009-03-06 | 461d? |  |  | R1 | 3650.32h | 3650.32h | MBMSE-RANPhysTDD | Nicholas Anderson |  | Rel-7 |  |
| 468 | 152.3.2 | Conformance Test Aspects – MBSFN for HCR and VHCR TDD | 461d? | 2000-01-03 | 2001-10-08 |  |  | 2000-01-03 | 2001-10-08 | 461d? | 2144d |  | R5 | 3688h |  | MBMSE-RANPhysTDD_UEConTest | IPWireless | tspeight@ipwireless.com | Rel-7 | Stoyan Baev |
| 469 | 152.4 | MBMS Low Chip Rate TDD Physical Layer Enhancement | 127d? | 2007-03-16 A | 2007-09-10 A | 100% |  | 2007-03-16 | 2007-09-10 | 127d? |  | finish no earlier than 2007-09-10 | R1 | 1016h | 1016h | MBMSE-RANPhysLCRTDD |  |  | Rel-7 |  |
| 470 | 152.5 | MBMS Mz interface | 115d? | 2006-12-04 A | 2007-05-11 A | 100% |  | 2006-12-04 | 2007-05-11 | 115d? |  | finish no earlier than 2007-05-11 | C3 | 920h | 920h | MBMSMz | Deng Tingting, Huawei | ttdeng@huawei.com | Rel-7 | Seung Don |
| 471 | 153 | GERAN3 Rel-7 Testing | 1d? | 2000-01-03 | 2000-01-03 |  |  | 2000-01-03 | 2000-01-03 | 1d? | 2604d |  | G3 | 8h |  |  |  |  | Rel-7 |  |
| 472 | 154 | **Downlink Dual Carrier** | 741d? | 2006-01-20 A | 2008-11-21 | 51% | 365.28d? | 2006-01-20 | 2008-11-21 | 741d? | 285d |  | GP | 17028.8h | 9066.55h | GDCDL | Leonardo Provvedi, Nokia Siemens Networks | leonardo.provvedi@roke.co.uk | Rel-7 | Paolo |
| 473 | 154.1 | Downlink Dual Carrier Stage 2 | 116d? | 2006-01-20 A | 2006-06-30 A | 100% |  | 2006-01-20 | 2006-06-30 | 116d? |  | finish no earlier than 2006-06-30 | G1 | 928h | 928h | GDCDL-Stage2 | Leonardo Provvedi, Nokia Siemens Networks | leonardo.provvedi@roke.co.uk | Rel-7 | Paolo |
| 474 | 154.2 | Downlink Dual Carrier Stage 3 | 421d? | 2006-01-20 A | 2007-08-31 A | 100% |  | 2006-01-20 | 2007-08-31 | 421d? |  | finish no earlier than 2007-08-31 | G2; G1 | 4244.8h | 4244.8h | GDCDL-Stage3 | Leonardo Provvedi, Nokia Siemens Networks | leonardo.provvedi@roke.co.uk | Rel-7 | Gert, Paolo |
| 475 | 154.3 | Downlink Dual Carrier – MS Conformance Test | 741d? | 2006-01-20 A | 2008-11-21 | 15% | 630d? | 2006-01-20 | 2008-11-21 | 741d? | 285d | finish no earlier than 2008-11-21 | G3 | 5928h | 888h | GDCDL-MStest | Leonardo Provvedi, Nokia Siemens Networks | leonardo.provvedi@roke.co.uk | Rel-7 | Stoyan |
| 476 | 155 | **Higher Uplink performance for GERAN Evolution** | 441d? | 2006-09-08 A | 2008-05-16 | 54% | 201.4d? | 2006-09-08 | 2008-05-16 | 441d? | 420d |  | GP | 21296h | 9804.15h | HUGE | NSN, Ericsson) | eddie.riddington@nokia.com, stefan.g.eriksson@ericsson.com | Rel-7 | Paolo |
| 477 | 155.1 | Stage 2 of HUGE | 261d? | 2006-09-08 A | 2007-09-07 A | 100% |  | 2006-09-08 | 2007-09-07 | 261d? |  | finish no earlier than 2007-09-07 | G1 | 2088h | 2088h | HUGE-Stage2 | NSN, Ericsson) | eddie.riddington@nokia.com, stefan.g.eriksson@ericsson.com | Rel-7 | Paolo |
| 478 | 155.2 | Layer 1 Support of HUGE | 381d? | 2006-09-08 A | 2008-02-22 A | 100% |  | 2006-09-08 | 2008-02-22 | 381d? |  | finish no earlier than 2008-02-22 | G1 | 3048h | 3048h | HUGE-Layer1 | NSN, Ericsson) | eddie.riddington@nokia.com, stefan.g.eriksson@ericsson.com | Rel-7 | Paolo |
| 479 | 155.3 | Layer 2/3 Support of HUGE | 256d? | 2006-09-08 A | 2007-08-31 A | 100% |  | 2006-09-08 | 2007-08-31 | 256d? |  | finish no earlier than 2007-08-31 | G2 | 2048h | 2048h | HUGE-Layer23 | NSN, Ericsson) | eddie.riddington@nokia.com, stefan.g.eriksson@ericsson.com | Rel-7 | Gert |
| 480 | 155.4 | Performance requirements | 441d? | 2006-09-08 A | 2008-05-16 | 70% | 132.3d? | 2006-09-08 | 2008-05-16 | 441d? | 420d | finish no earlier than 2008-05-16 | G1 | 3528h | 2469.6h | HUGE-Perfreq | NSN, Ericsson) | eddie.riddington@nokia.com, stefan.g.eriksson@ericsson.com | Rel-7 | Paolo |
| 481 | 155.5 | MS Conformance Test | 441d? | 2006-09-08 | 2008-05-16 |  |  | 2006-09-08 | 2008-05-16 | 441d? | 420d | finish no earlier than 2008-05-16 | G3 | 3528h |  | HUGE-Mstest | NSN, Ericsson) | eddie.riddington@nokia.com, stefan.g.eriksson@ericsson.com | Rel-7 | Stoyan |
| 482 | 155.6 | BTS Conformance Test | 441d? | 2006-09-08 | 2008-05-16 |  |  | 2006-09-08 | 2008-05-16 | 441d? | 420d | finish no earlier than 2008-05-16 | G1 | 3528h |  | HUGE-BTStest | NSN, Ericsson) | eddie.riddington@nokia.com, stefan.g.eriksson@ericsson.com | Rel-7 | Paolo |

Notes:
- 459: Text3: 22.101, 22.011, 23.122, 24.008, 25.304, 31.102, 45.008
- 460: Text3: 22.101, 22.011, 23.122, 24.008, 25.304, 31.102, 45.008
- 461: Text3: 23.122, 24.008, 31.102
- 462: Text3: TS34.108, TS 34.123-1, TS 34.123-2, TS 34.123-3
- 464: Strucutre created by MCC to include RAN aspects under SA1 Feature
- 465: closed at 78% / Text3: 25.211, 25.212, 25.213, 25.101, 25.104, 25.331, 25.433, 25.346, 25.306
- 466: closed at 94% / Text3: 25.346, 25.221, 25.222, 25.223, 25.224, 25.306, 25.331, 25.402, 25.433, 25.102, 25.105, 25.123
- 467: closed at 94% / Text3: 25.346, 25.221, 25.222, 25.223, 25.224, 25.306, 25.331, 25.402, 25.433, 25.102, 25.105, 25.123
- 468: Text3: 34.108,34.122,34.123-1/2/3
- 469: closed at 75%
- 470: 08/03/2007 08:00 / Text3: 29.061
- 472: Text3: 24.008, 43.055, 43.064, 44.018, 44.060, 45.001, 45.002, 45.005, 45.008, 51.010
- 473: Text3: 43.055, 43.064
- 474: Text3: 24.008, 44.018, 44.060, 45.001, 45.002, 45.005, 45.008
- 475: Text3: 51.010
- 476: Exception sheet in GP-071567 / Text3: 24.008, 43.055, 43.064, 44.018, 44.060, 45.001, 45.002, 45.003, 45.004, 45.005, 45.008, 45.010, 51.010, 51.021
- 477: Text3: 43.055, 43.064
- 478: Text3: 45.001, 45.002, 45.003, 45.004, 45.008
- 479: Text3: 24.008, 44.018, 44.060
- 480: Text3: 45.005
- 481: Text3: 51.010
- 482: Text3: 51.021

| ID | WBS | Task | Duration | Start | Finish | Complete | Remaining | Baseline start | Baseline finish | Baseline duration | Total slack | Constraint | Resources | Work | Actual work | Text1 | Text4 | Text5 | Text6 | Text8 |
| --- | --- | --- | --- | --- | --- | --- | --- | --- | --- | --- | --- | --- | --- | --- | --- | --- | --- | --- | --- | --- |
| 483 | 156 | **REduced symbol Duration, Higher Order modulation and Turbo coding (RED HOT) for downlink** | 466d? | 2006-11-17 A | 2008-08-29 | 40% | 280.93d? | 2006-11-17 | 2008-08-29 | 466d? | 345d |  | GP | 15360h | 4675.07h | REDHOT | Ericsson, NSN, Marvell | stefan.g.eriksson@ericsson.com | Rel-7 | Paolo |
| 484 | 156.1 | Stage 2 for REDHOT | 206d? | 2006-11-17 A | 2007-08-31 A | 100% |  | 2006-11-17 | 2007-08-31 | 206d? |  | finish no earlier than 2007-08-31 | G1 | 1648h | 1648h | REDHOT-Stage2 | Ericsson, NSN, Marvell | stefan.g.eriksson@ericsson.com | Rel-7 | Paolo |
| 485 | 156.2 | Stage 3 for REDHOT | 391d? | 2006-11-17 A | 2008-05-16 | 95% | 19.55d? | 2006-11-17 | 2008-05-16 | 391d? | 420d | finish no earlier than 2008-05-16 | G1 | 3128h | 2971.6h | REDHOT-Stage3 | Ericsson, NSN, Marvell | stefan.g.eriksson@ericsson.com | Rel-7 | Paolo |
| 486 | 156.3 | MS Conformance Tests | 466d? | 2006-11-17 | 2008-08-29 |  |  | 2006-11-17 | 2008-08-29 | 466d? | 345d | finish no earlier than 2008-08-29 | G3 | 3728h |  | REDHOT-Mstest | Ericsson | stefan.g.eriksson@ericsson.com | Rel-7 | Stoyan |
| 487 | 156.4 | BTS Conformance Tests | 391d? | 2006-11-17 | 2008-05-16 |  |  | 2006-11-17 | 2008-05-16 | 391d? | 420d | finish no earlier than 2008-05-16 | G1 | 3128h |  | REDHOT-BTStest | Ericsson, NSN, Marvell | stefan.g.eriksson@ericsson.com | Rel-7 | Paolo |

Notes:
- 483: Exception sheet in GP-071565 / Text3: 24.008, 43.064, 43.055, 44.018, 44.060, 45.001, 45.002, 45.003, 45.004, 45.005, 45.008, 51.010, 51.021
- 484: Text3: 43.055, 43.064
- 485: Text3: 24.008, 44.018, 44.060, 45.001, 45.002, 45.003, 45.004, 45.005, 45.008
- 486: Text3: 51.010
- 487: Text3: 51.021
